# ISO 9001 管理审核

Schedule from MS Project, 2007-01-01 to 2007-01-15.

## Calendars

- 标准: Mon-Fri 08:00-12:00, 13:00-17:00; Sat-Sun off.

## Resources

| Resource |
| --- |
| 高级管理工作组 |
| ISO 管理代表 |
| 质量保证经理 |

## Schedule

| ID | WBS | Task | Type | Duration | Start | Finish | Predecessors | Total slack | Free slack | Resources | Work |
| --- | --- | --- | --- | --- | --- | --- | --- | --- | --- | --- | --- |
| 1 | 1 | 阅读说明此模板用途的注释 | milestone | 0d | 2007-01-01 | 2007-01-01 |  | 0d |  | ISO 管理代表 |  |
| 2 | 2 | **审核设置** |  | 2d? | 2007-01-01 | 2007-01-02 |  | 0d |  |  | 16h |
| 3 | 2.1 | 准备议程 |  | 1d? | 2007-01-01 | 2007-01-01 | 1 | 0d |  | ISO 管理代表 | 8h |
| 4 | 2.2 | 准备审核文档表单或系统 |  | 1d? | 2007-01-02 | 2007-01-02 | 3 | 0d |  | ISO 管理代表 | 8h |
| 5 | 2.3 | 完成管理审核设置 | milestone | 0d | 2007-01-02 | 2007-01-02 | 4 | 0d |  |  |  |
| 6 | 3 | **汇编输入资料供审核** |  | 5d? | 2007-01-03 | 2007-01-09 |  | 0d |  |  | 160h |
| 7 | 3.1 | **1. 审核结果** |  | 5d? | 2007-01-03 | 2007-01-09 |  | 0d |  |  | 40h |
| 8 | 3.1.1 | 创建供质量管理系统内部审核用的比较报表 |  | 1d? | 2007-01-03 | 2007-01-03 | 5 | 0d |  | 质量保证经理 | 8h |
| 9 | 3.1.2 | 创建供 ISO 9000 登记员审核用的比较报表 |  | 1d? | 2007-01-04 | 2007-01-04 | 8 | 0d |  | ISO 管理代表 | 8h |
| 10 | 3.1.3 | 创建供客户审核用的比较报表 |  | 1d? | 2007-01-05 | 2007-01-05 | 9 | 0d |  | 质量保证经理 | 8h |
| 11 | 3.1.4 | 创建供管监管机构审核用的比较报表 |  | 1d? | 2007-01-08 | 2007-01-08 | 10 | 0d |  | ISO 管理代表 | 8h |
| 12 | 3.1.5 | 创建共单个流程负责人自我评估审核用的比较报表 |  | 1d? | 2007-01-09 | 2007-01-09 | 11 | 0d |  | 质量保证经理 | 8h |
| 13 | 3.1.6 | 第 1 项完成 | milestone | 0d | 2007-01-09 | 2007-01-09 | 12 | 0d |  |  |  |
| 14 | 3.2 | **2. 客户反馈** |  | 2d? | 2007-01-03 | 2007-01-04 |  | 3d |  |  | 16h |
| 15 | 3.2.1 | 将客户反馈与客户需要和期望的质量目标进行比较 |  | 1d? | 2007-01-03 | 2007-01-03 | 5 | 3d | 0d | 质量保证经理 | 8h |
| 16 | 3.2.2 | 撰写分析报告 |  | 1d? | 2007-01-04 | 2007-01-04 | 15 | 3d | 0d | 质量保证经理 | 8h |
| 17 | 3.2.3 | 第 2 项完成 | milestone | 0d | 2007-01-04 | 2007-01-04 | 16 | 3d |  |  |  |
| 18 | 3.3 | **3. 产品合格率** |  | 5d? | 2007-01-03 | 2007-01-09 |  | 0d |  |  | 40h |
| 19 | 3.3.1 | 分析产品特征结果 |  | 1d? | 2007-01-03 | 2007-01-03 | 5 | 0d |  | 质量保证经理 | 8h |
| 20 | 3.3.2 | 分析产品用途结果 |  | 1d? | 2007-01-04 | 2007-01-04 | 19 | 0d |  | 质量保证经理 | 8h |
| 21 | 3.3.3 | 分析实时交付表现 |  | 1d? | 2007-01-05 | 2007-01-05 | 20 | 0d |  | 质量保证经理 | 8h |
| 22 | 3.3.4 | 分析流程表现结果 |  | 1d? | 2007-01-08 | 2007-01-08 | 21 | 0d |  | 质量保证经理 | 8h |
| 23 | 3.3.5 | 撰写分析报告 |  | 1d? | 2007-01-09 | 2007-01-09 | 22 | 0d |  | 质量保证经理 | 8h |
| 24 | 3.3.6 | 第 3 项完成 | milestone | 0d | 2007-01-09 | 2007-01-09 | 23 | 0d |  |  |  |

Notes:
- 1: 此模板用于在管理审核流程中对用户进行符合 ISO 9001 标准的审核指导。该标准在英国以及欧盟的许多个国家(以及很多其他国家)中都适用，用于确保他们的做法以及制造的产品或提供的服务都与公认的国际标准相符。必须在预定间隔期间进行审核，同时必须严格遵循此模板中确定的指导原则。 / 管理审核中需要多个角色。高级管理工作组应包含下列角色(职务可能会有所不同): CEO、总裁、副总裁、运营经理、人力资源经理、销售/营销经理、总会计师(或财务代表)以及总经理。 / 此外还应包括 ISO 代表和质量保证经理。在此模板中，我们将此两种角色单独列出，因为他们必须执行额外的任务。 / ISO 9001 适用于所有类型的组织(无论组织大小和经营业务如何)，它可以帮助以提供产品为中心以及以提供服务为中心的组织取得全世界的认可和尊重的质量标准。(来源: Praxiom.com)
- 6: ISO 9001 标准要求输入本部分活动中确定的七个组件相关的资料。

| ID | WBS | Task | Type | Duration | Start | Finish | Predecessors | Total slack | Free slack | Resources | Work |
| --- | --- | --- | --- | --- | --- | --- | --- | --- | --- | --- | --- |
| 25 | 3.4 | **4. 纠正/预防措施反馈** |  | 3d? | 2007-01-03 | 2007-01-05 |  | 2d |  |  | 24h |
| 26 | 3.4.1 | 审核纠正/预防措施的结束时间 |  | 1d? | 2007-01-03 | 2007-01-03 | 5 | 2d | 0d | 质量保证经理 | 8h |
| 27 | 3.4.2 | 审核重复发生的程度 |  | 1d? | 2007-01-04 | 2007-01-04 | 26 | 2d | 0d | 质量保证经理 | 8h |
| 28 | 3.4.3 | 审核方法的有效性 |  | 1d? | 2007-01-05 | 2007-01-05 | 27 | 2d | 0d | 质量保证经理 | 8h |
| 29 | 3.4.4 | 第 4 项完成 | milestone | 0d | 2007-01-05 | 2007-01-05 | 28 | 2d |  |  |  |
| 30 | 3.5 | **5. 前期管理审核跟进** |  | 2d? | 2007-01-03 | 2007-01-04 |  | 3d |  |  | 16h |
| 31 | 3.5.1 | 准备纠正/预防措施状态报告 |  | 1d? | 2007-01-03 | 2007-01-03 | 5 | 3d | 0d | 质量保证经理 | 8h |
| 32 | 3.5.2 | 准备项目状态报告 |  | 1d? | 2007-01-04 | 2007-01-04 | 31 | 3d | 0d | 质量保证经理 | 8h |
| 33 | 3.5.3 | 第 5 项完成 | milestone | 0d | 2007-01-04 | 2007-01-04 | 32 | 3d |  |  |  |
| 34 | 3.6 | **6. 更改评估** |  | 2d? | 2007-01-03 | 2007-01-04 |  | 3d |  |  | 16h |
| 35 | 3.6.1 | 确定组织中影响质量管理系统的任何更改 |  | 1d? | 2007-01-03 | 2007-01-03 | 5 | 3d | 0d | 质量保证经理 | 8h |
| 36 | 3.6.2 | 撰写更改文档 |  | 1d? | 2007-01-04 | 2007-01-04 | 35 | 3d | 0d | 质量保证经理 | 8h |
| 37 | 3.6.3 | 第 6 项完成 | milestone | 0d | 2007-01-04 | 2007-01-04 | 36 | 3d |  |  |  |
| 38 | 3.7 | **7. 改进建议** |  | 1d? | 2007-01-03 | 2007-01-03 |  | 4d |  |  | 8h |
| 39 | 3.7.1 | 确定可以提高效率、创新或增加营销新机会的建议 |  | 1d? | 2007-01-03 | 2007-01-03 | 5 | 4d | 0d | 质量保证经理 | 8h |
| 40 | 3.7.2 | 第 7 项完成 | milestone | 0d | 2007-01-03 | 2007-01-03 | 39 | 4d |  |  |  |
| 41 | 3.8 | 完成输入资料审核 | milestone | 0d | 2007-01-09 | 2007-01-09 | 40, 37, 33, 29, 24, 17, 13 | 0d |  |  |  |
| 42 | 4 | **举行管理审核会议** |  | 1d? | 2007-01-10 | 2007-01-10 |  | 0d |  |  | 44h |
| 43 | 4.1 | 审核质量管理系统 |  | 1d? | 2007-01-10 | 2007-01-10 | 41 | 0d |  | 高级管理工作组; ISO 管理代表; 质量保证经理 | 12h |
| 44 | 4.2 | 审核质量政策 |  | 1d? | 2007-01-10 | 2007-01-10 | 41 | 0d |  | 高级管理工作组; ISO 管理代表; 质量保证经理 | 12h |
| 45 | 4.3 | 审核质量目标 |  | 1d? | 2007-01-10 | 2007-01-10 | 41 | 0d |  | 高级管理工作组; ISO 管理代表; 质量保证经理 | 12h |
| 46 | 4.4 | **将审核流程编档** |  | 1d? | 2007-01-10 | 2007-01-10 |  | 0d |  |  | 8h |
| 47 | 4.4.1 | 确定所有措施 |  | 1d? | 2007-01-10 | 2007-01-10 | 41 | 0d |  | ISO 管理代表 | 8h |
| 48 | 4.5 | 完成管理审核会议 | milestone | 0d | 2007-01-10 | 2007-01-10 | 43, 44, 45, 47 | 0d |  |  |  |

Notes:
- 42: ISO 9001 要求管理审核应包括与以下内容相关的决策和措施的书面记录: 对质量管理系统以及系统的组成流程的有效性的提高；对与客户需求有关的产品或服务的改进；以及确保与质量管理系统持续改进和运营相关的资源需求。 / 管理审核不需要在一天内完成，可能会持续数天。

| ID | WBS | Task | Type | Duration | Start | Finish | Predecessors | Total slack | Resources | Work |
| --- | --- | --- | --- | --- | --- | --- | --- | --- | --- | --- |
| 49 | 5 | **创建审核结果记录** |  | 3d? | 2007-01-11 | 2007-01-15 |  | 0d |  | 40h |
| 50 | 5.1 | 将有关改进质量管理系统的决策/措施编档 |  | 1d? | 2007-01-11 | 2007-01-11 | 48 | 0d | ISO 管理代表 | 8h |
| 51 | 5.2 | 将有关改进与客户需求相关的产品/服务器的决策/措施编档 |  | 1d? | 2007-01-11 | 2007-01-11 | 48 | 0d | ISO 管理代表 | 8h |
| 52 | 5.3 | 将有关资源需求的决策/措施编档 |  | 1d? | 2007-01-11 | 2007-01-11 | 48 | 0d | ISO 管理代表 | 8h |
| 53 | 5.4 | 确保管理审核记录符合 ISO 9001 的 4.2.2 条款 |  | 1d? | 2007-01-12 | 2007-01-12 | 50, 51, 52 | 0d | ISO 管理代表 | 8h |
| 54 | 5.5 | 保护审核记录的安全 |  | 1d? | 2007-01-15 | 2007-01-15 | 53 | 0d | ISO 管理代表 | 8h |
| 55 | 5.6 | 完成结果记录创建工作 | milestone | 0d | 2007-01-15 | 2007-01-15 | 54 | 0d |  |  |
| 56 | 6 | 完成 ISO 9001 管理审核流程 | milestone | 0d | 2007-01-15 | 2007-01-15 | 55 | 0d |  |  |

Notes:
- 49: ISO 9001 要求管理审核应包括与以下三方面的内容相关的决策和措施的书面记录: 对质量管理系统和系统的组成流程的有效性的提高；对与客户需求有关的产品或服务的改进；以及确保与质量管理系统持续改进和运营相关的资源需求。
- 53: 审核记录必须包含: 审核日期；审核人员的姓名和职务；组织目标；当前绩效的相关证据；使用的管理标准；结论；制定的决策以及采取的措施；采取措施的责任方、所需资源和期限。
