# SOX 一致性和技术选项

Schedule from MS Project, 2007-01-01 to 2007-03-13.
Sarbanes-Oxley 法案 404 条款遵循标准要求，在 2004 年 11 月 15 日之后提交财务报表的大部分公司需要准备外部审计证明，以证明他们的内部控制的有效性。某些公司为了能够满足这个期限规定，采取了未经优化的劳动力密集型控制，以满足基本的法规要求。其中许多公司正在审核所用的控制措施，并对可用的技术方法进行评估，希望以更少的人力更有效地满足此规定要求。此模板可以处理组成此流程的常规活动。该项目假定组织已经符合 SOX 标准。

## Calendars

- 标准: Mon-Fri 08:00-12:00, 13:00-17:00; Sat-Sun off.

## Resources

| Resource |
| --- |
| 外部审计公司 |
| CFO |
| 会计 |
| IT 主管/经理 |
| IT 应用工作组 |
| IT 网络和基础设施工作组 |
| 运营主管/经理 |
| SOX 一致性工作组 |
| 内部审计主管 |

## Schedule

| ID | WBS | Task | Type | Duration | Start | Finish | Predecessors | Total slack | Resources | Work |
| --- | --- | --- | --- | --- | --- | --- | --- | --- | --- | --- |
| 1 | 1 | **准备 SOX 一致性审阅** |  | 4d? | 2007-01-01 | 2007-01-04 |  | 0d |  | 56h |
| 2 | 1.1 | 外部审计公司会议 |  | 1d? | 2007-01-01 | 2007-01-01 |  | 0d | 外部审计公司 | 8h |
| 3 | 1.2 | 确定 SOX 一致性审阅角色和职责 |  | 1d? | 2007-01-02 | 2007-01-02 | 2 | 0d | 外部审计公司; CFO; 内部审计主管 | 12h |
| 4 | 1.3 | 确定 SOX 一致性审阅和决策过程 |  | 1d? | 2007-01-02 | 2007-01-02 | 3SS | 0d | 外部审计公司; CFO; 内部审计主管 | 12h |
| 5 | 1.4 | 创建 SOX 一致性审阅项目计划 |  | 1d? | 2007-01-03 | 2007-01-03 | 4 | 0d | 外部审计公司; CFO; 内部审计主管 | 12h |
| 6 | 1.5 | 举行启动会议 |  | 1d? | 2007-01-04 | 2007-01-04 | 5 | 0d | 外部审计公司; CFO; 内部审计主管 | 12h |
| 7 | 1.6 | 完成 SOX 一致性审阅准备 | milestone | 0d | 2007-01-04 | 2007-01-04 | 6 | 47.5d |  |  |
| 8 | 2 | **启动和范围** |  | 4.5d? | 2007-01-05 | 2007-01-11 |  | 0d |  | 40h |
| 9 | 2.1 | 确定范围中的系统和过程 |  | 0.5d? | 2007-01-05 | 2007-01-05 | 4, 6 | 0d | 会计; SOX 一致性工作组 | 8h |
| 10 | 2.2 | 建立项目参与者和负责人的交流计划 |  | 1d? | 2007-01-05 | 2007-01-08 | 9 | 0d | SOX 一致性工作组 | 8h |
| 11 | 2.3 | 确定项目参与者的 SOX 培训要求 |  | 1d? | 2007-01-08 | 2007-01-09 | 10 | 0d | SOX 一致性工作组 | 8h |
| 12 | 2.4 | 确定项目计划、关键里程碑、预算和关键项目参与者 |  | 1d? | 2007-01-09 | 2007-01-10 | 11 | 0d | SOX 一致性工作组 | 8h |
| 13 | 2.5 | 确定用于高级管理的项目进度报告和结构 |  | 1d? | 2007-01-10 | 2007-01-11 | 12 | 0d | SOX 一致性工作组 | 8h |
| 14 | 2.6 | 完成项目启动 | milestone | 0d | 2007-01-11 | 2007-01-11 | 13 | 0d |  |  |
| 15 | 3 | **审阅并确定改进机会** |  | 23d? | 2007-01-11 | 2007-02-13 |  | 0d |  | 365.44h |
| 16 | 3.1 | **进行风险评估** |  | 3d? | 2007-01-11 | 2007-01-16 |  | 0d |  | 24h |
| 17 | 3.1.1 | 审阅并确认风险因素 |  | 1d? | 2007-01-11 | 2007-01-12 | 14 | 0d | SOX 一致性工作组 | 8h |
| 18 | 3.1.2 | 验证风险因素的概率和影响 |  | 1d? | 2007-01-12 | 2007-01-15 | 17 | 0d | SOX 一致性工作组 | 8h |
| 19 | 3.1.3 | 估计并验证风险因素的大小和复杂性 |  | 1d? | 2007-01-15 | 2007-01-16 | 18 | 0d | SOX 一致性工作组 | 8h |
| 20 | 3.2 | **确定重要原因和内部控制** |  | 1d? | 2007-01-16 | 2007-01-17 |  | 0d |  | 8h |
| 21 | 3.2.1 | 确定并验证对启动、记录、处理和报告的应用控制 |  | 1d? | 2007-01-16 | 2007-01-17 | 19 | 0d | SOX 一致性工作组 | 8h |
| 22 | 3.3 | **确认总体 IT 控制** |  | 2d? | 2007-01-17 | 2007-01-19 |  | 0d |  | 140h |
| 23 | 3.3.1 | 审阅安全策略和过程 |  | 1d? | 2007-01-17 | 2007-01-18 | 21 | 0d | IT 网络和基础设施工作组; SOX 一致性工作组 | 16h |
| 24 | 3.3.2 | **审阅变化管理策略和过程** |  | 1d? | 2007-01-17 | 2007-01-18 |  | 0d |  | 24h |
| 25 | 3.3.2.1 | 审阅版本管理/发布管理过程 |  | 1d? | 2007-01-17 | 2007-01-18 | 23SS | 0d | IT 应用工作组; IT 网络和基础设施工作组; SOX 一致性工作组 | 12h |
| 26 | 3.3.2.2 | 审阅源代码/文档版本控制过程 |  | 1d? | 2007-01-17 | 2007-01-18 | 23SS | 0d | IT 应用工作组; IT 网络和基础设施工作组; SOX 一致性工作组 | 12h |
| 27 | 3.3.3 | 审阅灾难恢复过程 |  | 1d? | 2007-01-17 | 2007-01-18 | 23SS | 0d | IT 网络和基础设施工作组; SOX 一致性工作组 | 16h |
| 28 | 3.3.4 | 审阅备份和恢复过程 |  | 1d? | 2007-01-17 | 2007-01-18 | 23SS | 0d | IT 网络和基础设施工作组; SOX 一致性工作组 | 16h |
| 29 | 3.3.5 | 审阅服务级别协议策略 |  | 1d? | 2007-01-17 | 2007-01-18 | 23SS | 0d | IT 主管/经理; IT 应用工作组; IT 网络和基础设施工作组; SOX 一致性工作组 | 12h |
| 30 | 3.3.6 | 审阅应用开发和编码标准/审阅过程 |  | 1d? | 2007-01-17 | 2007-01-18 | 23SS | 0d | IT 应用工作组; SOX 一致性工作组 | 16h |
| 31 | 3.3.7 | 审阅测试策略和过程 |  | 1d? | 2007-01-17 | 2007-01-18 | 23SS | 0d | IT 应用工作组; SOX 一致性工作组 | 16h |
| 32 | 3.3.8 | 审阅 QA 过程 |  | 1d? | 2007-01-17 | 2007-01-18 | 23SS | 0d | IT 应用工作组; SOX 一致性工作组 | 16h |
| 33 | 3.3.9 | 总结改进机会结果 |  | 1d? | 2007-01-18 | 2007-01-19 | 23, 25, 26, 27, 28, 29, 30, 32, 31 | 0d | SOX 一致性工作组 | 8h |

Notes:
- 2: 会议主题: / 问题。 / 审计时间安排。 / 需要的日程安排和文档。
- 6: 会议主题: / 职责分配。 / 确定影响时间和日程安排。

| ID | WBS | Task | Type | Duration | Start | Finish | Predecessors | Total slack | Resources | Work |
| --- | --- | --- | --- | --- | --- | --- | --- | --- | --- | --- |
| 34 | 3.4 | **确认控制设计** |  | 3d? | 2007-01-19 | 2007-01-24 |  | 0d |  | 53.33h |
| 35 | 3.4.1 | 确定策略和过程 |  | 1d? | 2007-01-19 | 2007-01-22 | 33 | 0d | 会计; SOX 一致性工作组 | 16h |
| 36 | 3.4.2 | 审阅说明词和流程图 |  | 1d? | 2007-01-22 | 2007-01-23 | 35 | 0d | 会计; SOX 一致性工作组 | 16h |
| 37 | 3.4.3 | 审阅系统配置文档 |  | 1d? | 2007-01-22 | 2007-01-23 | 36SS | 0d | IT 应用工作组 [200%]; SOX 一致性工作组 [200%] | 21.33h |
| 38 | 3.4.4 | 验证内部控制检查点和过程 |  | 1d? | 2007-01-23 | 2007-01-24 | 37 | 0d |  |  |
| 39 | 3.5 | **评估操作效益** |  | 3d? | 2007-01-24 | 2007-01-29 |  | 0d |  | 28.11h |
| 40 | 3.5.1 | 确定/确认劳动密集型和成本低效型内部控制 |  | 1d? | 2007-01-24 | 2007-01-25 | 38 | 0d | CFO [0.9%]; 会计 [7.3%]; IT 主管/经理 [12.5%]; SOX 一致性工作组 [12.5%]; 内部审计主管 [50%] | 4.11h |
| 41 | 3.5.2 | 确定低效次序 - 持续性成本/内部控制风险/成本和效率影响 |  | 1d? | 2007-01-25 | 2007-01-26 | 40 | 0d | CFO; SOX 一致性工作组; 内部审计主管 | 12h |
| 42 | 3.5.3 | 为确定优先顺序的改进工作制定成本估算和工作内容 |  | 1d? | 2007-01-26 | 2007-01-29 | 41 | 0d | CFO; SOX 一致性工作组; 内部审计主管 | 12h |
| 43 | 3.6 | **最终确定成本/收益分析** |  | 11d? | 2007-01-29 | 2007-02-13 |  | 0d |  | 112h |
| 44 | 3.6.1 | 将改进机会组合到技术改进项目中 |  | 1d? | 2007-01-29 | 2007-01-30 | 42 | 0d | CFO; 会计; IT 主管/经理; SOX 一致性工作组; 内部审计主管 | 12h |
| 45 | 3.6.2 | 制定成本/收益分析 |  | 1d? | 2007-01-30 | 2007-01-31 | 44 | 0d | CFO; 会计; IT 主管/经理; SOX 一致性工作组; 内部审计主管 | 12h |
| 46 | 3.6.3 | 制定将来的状态方案和机会储备 |  | 1d? | 2007-01-31 | 2007-02-01 | 45 | 0d | CFO; 会计; IT 主管/经理; SOX 一致性工作组; 内部审计主管 | 12h |
| 47 | 3.6.4 | 确定差距 |  | 1d? | 2007-02-01 | 2007-02-02 | 46 | 0d | CFO; 会计; IT 主管/经理; SOX 一致性工作组; 内部审计主管 | 12h |
| 48 | 3.6.5 | 确定项目风险和不采取任何措施的影响 |  | 5d? | 2007-02-02 | 2007-02-09 | 47 | 0d | SOX 一致性工作组 | 40h |
| 49 | 3.6.6 | 确定其他关键资源和信息源 |  | 1d? | 2007-02-09 | 2007-02-12 | 48 | 0d | CFO; 会计; IT 主管/经理; SOX 一致性工作组; 内部审计主管 | 12h |
| 50 | 3.6.7 | 验证范围、参与者和工作 |  | 1d? | 2007-02-12 | 2007-02-13 | 49 | 0d | CFO; 会计; IT 主管/经理; SOX 一致性工作组; 内部审计主管 | 12h |
| 51 | 3.7 | 完成改进设计 | milestone | 0d | 2007-02-13 | 2007-02-13 | 50 | 20d |  |  |
| 52 | 4 | **控制设计** |  | 9d? | 2007-02-13 | 2007-02-26 |  | 0d |  | 176h |
| 53 | 4.1 | 项目启动会议 |  | 1d? | 2007-02-13 | 2007-02-14 | 50 | 0d | IT 应用工作组; SOX 一致性工作组 | 16h |
| 54 | 4.2 | 设计新系统以及对相关内部控制的交叉引用 |  | 1d? | 2007-02-14 | 2007-02-15 | 53 | 0d | IT 应用工作组; SOX 一致性工作组 | 16h |
| 55 | 4.3 | **确定要实施的技术** |  | 1d? | 2007-02-15 | 2007-02-16 |  | 0d |  | 48h |
| 56 | 4.3.1 | 确定数据捕获和编辑系统 |  | 1d? | 2007-02-15 | 2007-02-16 | 54 | 0d | IT 应用工作组; SOX 一致性工作组 | 16h |
| 57 | 4.3.2 | 确定日志记录和监控系统 |  | 1d? | 2007-02-15 | 2007-02-16 | 56SS | 0d | IT 应用工作组; SOX 一致性工作组 | 16h |
| 58 | 4.3.3 | 确定分析和报告系统 |  | 1d? | 2007-02-15 | 2007-02-16 | 56SS | 0d | IT 应用工作组; SOX 一致性工作组 | 16h |
| 59 | 4.4 | 设计必要的过程更改 |  | 1d? | 2007-02-16 | 2007-02-19 | 56, 57, 58 | 0d | IT 应用工作组; SOX 一致性工作组 | 16h |
| 60 | 4.5 | 创建策略、标准和过程 |  | 1d? | 2007-02-19 | 2007-02-20 | 59 | 0d | IT 应用工作组; SOX 一致性工作组 | 16h |
| 61 | 4.6 | 通知必需的更改 |  | 1d? | 2007-02-20 | 2007-02-21 | 60 | 0d | IT 应用工作组; SOX 一致性工作组 | 16h |
| 62 | 4.7 | 确定合适的控制频率 |  | 1d? | 2007-02-21 | 2007-02-22 | 61 | 0d | IT 应用工作组; SOX 一致性工作组 | 16h |
| 63 | 4.8 | 确定最终的设计 |  | 1d? | 2007-02-22 | 2007-02-23 | 62 | 0d | IT 应用工作组; SOX 一致性工作组 | 16h |
| 64 | 4.9 | 通过所需的批准(SOX 一致性/管理) |  | 1d? | 2007-02-23 | 2007-02-26 | 63 | 0d | IT 应用工作组; SOX 一致性工作组 | 16h |
| 65 | 4.10 | 完成控制设计 | milestone | 0d | 2007-02-26 | 2007-02-26 | 64 | 0d | IT 应用工作组; SOX 一致性工作组 |  |

| ID | WBS | Task | Type | Duration | Start | Finish | Predecessors | Total slack | Resources | Work |
| --- | --- | --- | --- | --- | --- | --- | --- | --- | --- | --- |
| 66 | 5 | **开发** |  | 3d? | 2007-02-26 | 2007-03-01 |  | 0d |  | 48h |
| 67 | 5.1 | 制定/实施重新设计的系统和/或控制 |  | 1d? | 2007-02-26 | 2007-02-27 | 65 | 0d | IT 应用工作组; SOX 一致性工作组 | 16h |
| 68 | 5.2 | 将所有更改重新通知所有受影响的组 |  | 1d? | 2007-02-27 | 2007-02-28 | 67 | 0d | IT 应用工作组; SOX 一致性工作组 | 16h |
| 69 | 5.3 | 验证维护和/或改进的内部控制 |  | 1d? | 2007-02-28 | 2007-03-01 | 68 | 0d | IT 应用工作组; SOX 一致性工作组 | 16h |
| 70 | 5.4 | 完成开发工作 | milestone | 0d | 2007-03-01 | 2007-03-01 | 69 | 0d |  |  |
| 71 | 6 | **测试** |  | 4d? | 2007-03-01 | 2007-03-07 |  | 0d |  | 32h |
| 72 | 6.1 | 验证控制效益 |  | 1d? | 2007-03-01 | 2007-03-02 | 70 | 0d | IT 应用工作组 | 8h |
| 73 | 6.2 | 在详细测试计划和摘要中对测试事例/结果编档 |  | 1d? | 2007-03-02 | 2007-03-05 | 72 | 0d | IT 应用工作组 | 8h |
| 74 | 6.3 | 验证完成的改进和(或)补救措施 |  | 1d? | 2007-03-05 | 2007-03-06 | 73 | 0d | IT 应用工作组 | 8h |
| 75 | 6.4 | 文档测试结果 |  | 1d? | 2007-03-06 | 2007-03-07 | 74 | 0d | IT 应用工作组 | 8h |
| 76 | 6.5 | 完成测试 | milestone | 0d | 2007-03-07 | 2007-03-07 | 75 | 0d |  |  |
| 77 | 7 | **实施** |  | 4d? | 2007-03-07 | 2007-03-13 |  | 0d |  | 48h |
| 78 | 7.1 | 更新过程和控制文档 |  | 1d? | 2007-03-07 | 2007-03-08 | 76 | 0d | 会计; IT 应用工作组; IT 网络和基础设施工作组 | 12h |
| 79 | 7.2 | 实施系统更改 |  | 1d? | 2007-03-08 | 2007-03-09 | 78 | 0d | 会计; IT 应用工作组; IT 网络和基础设施工作组 | 12h |
| 80 | 7.3 | 监控结果和改进 |  | 1d? | 2007-03-09 | 2007-03-12 | 79 | 0d | 会计; IT 应用工作组; IT 网络和基础设施工作组; SOX 一致性工作组 | 12h |
| 81 | 7.4 | 将结果编辑并向高级管理人员总结 |  | 1d? | 2007-03-12 | 2007-03-13 | 80 | 0d | 会计; IT 应用工作组; IT 网络和基础设施工作组; SOX 一致性工作组 | 12h |
| 82 | 7.5 | 完成实施 | milestone | 0d | 2007-03-13 | 2007-03-13 | 81 | 0d |  |  |
