# 产品开发规划

Schedule from MS Project, 2007-01-01 to 2007-06-11.
成功的产品指的是能满足客户需求、有创新并能向客户提供价值的产品。此模板列出了产品开发的战略方法。通过了解您的公司在市场上的位置、建立产品结构以及目标群和竞争对手的信息，此模板可创建一个开始产品开发的框架。

## Calendars

- 标准: Mon-Fri 08:00-12:00, 13:00-17:00; Sat-Sun off.

## Resources

| Resource |
| --- |
| 后勤领导组 |
| 营销领导组 |
| 赞助商 |
| 销售人员 |
| 贸易展览人员 |
| 创意人员 |
| 内容顾问 |
| 营销人员 |
| 营销研究人员 |
| 打印机 |
| Web 内容/创意人员 |
| 营销代表 |
| CMO |
| 供应商 |
| 内部公关人员 |
| 内部销售人员 |
| 营销人员 |
| 产品经理 |
| 业务部门经理 |
| 执行人员 |
| 产品营销人员 |
| 市场研究 |
| 产品研究 |
| 产品开发 |
| 产品定义工作组 |

## Schedule

| ID | WBS | Task | Type | Duration | Start | Finish | Predecessors | Total slack | Free slack | Resources | Work |
| --- | --- | --- | --- | --- | --- | --- | --- | --- | --- | --- | --- |
| 1 | 1 | **阐明产品业务定位** |  | 9d? | 2007-01-01 | 2007-01-11 |  | 21d |  |  | 192h |
| 2 | 1.1 | 审查业务市场 |  | 5d? | 2007-01-01 | 2007-01-05 |  | 25d | 4d | 产品定义工作组 | 40h |
| 3 | 1.2 | 确定当前市场定位，并确立将来发展的里程碑 |  | 2d? | 2007-01-01 | 2007-01-02 |  | 28d | 7d | 产品定义工作组 | 16h |
| 4 | 1.3 | 确立业务目标 |  | 5d? | 2007-01-01 | 2007-01-05 |  | 25d | 4d | 产品定义工作组 | 40h |
| 5 | 1.4 | 审阅销售、营销和定价的策略和计划 |  | 1d? | 2007-01-01 | 2007-01-01 |  | 28d | 0d | 产品定义工作组 | 8h |
| 6 | 1.5 | 确定产品目标和里程碑 |  | 1d? | 2007-01-02 | 2007-01-02 | 5 | 28d | 7d | 产品定义工作组 | 8h |
| 7 | 1.6 | 审查一段时间内组织、供应商和里程碑的状况 |  | 9d? | 2007-01-01 | 2007-01-11 |  | 21d | 0d | 产品定义工作组 | 72h |
| 8 | 1.7 | 建立支持开发、交付和服务活动的基础设施 |  | 1d? | 2007-01-01 | 2007-01-01 |  | 29d | 8d | 产品定义工作组 | 8h |
| 9 | 1.8 | 产品的业务定位已阐明 | milestone | 0d | 2007-01-11 | 2007-01-11 | 2, 3, 4, 6, 7, 8 | 21d |  |  |  |
| 10 | 2 | **建立支持产品规划的公司基础设施** |  | 30d? | 2007-01-01 | 2007-02-09 |  | 0d |  |  | 240h |
| 11 | 2.1 | 创建验证设想的过程 |  | 10d? | 2007-01-01 | 2007-01-12 |  | 0d |  | 执行人员 | 80h |
| 12 | 2.2 | 创建共享设想的过程 |  | 5d? | 2007-01-15 | 2007-01-19 | 11 | 0d |  | 执行人员 | 40h |
| 13 | 2.3 | 收集设想 |  | 15d? | 2007-01-22 | 2007-02-09 | 12 | 0d |  | 执行人员 | 120h |
| 14 | 2.4 | 完成产品规划的基础设施 | milestone | 0d | 2007-02-09 | 2007-02-09 | 13 | 0d |  |  |  |
| 15 | 3 | **确定产品** |  | 35d? | 2007-02-12 | 2007-03-30 |  | 0d |  |  | 400h |
| 16 | 3.1 | 确定产品/服务 |  | 10d? | 2007-02-12 | 2007-02-23 | 9, 14 | 0d |  | 产品定义工作组 | 80h |
| 17 | 3.2 | 确定产品需求 |  | 5d? | 2007-02-26 | 2007-03-02 | 16 | 0d |  | 产品定义工作组 | 40h |
| 18 | 3.3 | 确定驱动当前和将来目标需求的趋势 |  | 5d? | 2007-03-05 | 2007-03-09 | 17 | 15d |  | 产品定义工作组 | 40h |
| 19 | 3.4 | 确定产品用法和特性 |  | 20d? | 2007-03-05 | 2007-03-30 | 17 | 0d |  | 产品定义工作组 | 160h |
| 20 | 3.5 | 确定产品差异 |  | 5d? | 2007-03-05 | 2007-03-09 | 17 | 15d |  | 产品定义工作组 | 40h |
| 21 | 3.6 | 确定与市场中其他产品的对比 |  | 5d? | 2007-03-05 | 2007-03-09 | 17 | 15d |  | 产品定义工作组 | 40h |
| 22 | 3.7 | 完成产品确定 | milestone | 0d | 2007-03-30 | 2007-03-30 | 18, 19, 20, 21 | 0d |  |  |  |
| 23 | 4 | **确定客户和目标市场细分** |  | 7d? | 2007-04-02 | 2007-04-10 |  | 28d |  |  | 160h |
| 24 | 4.1 | 确定市场细分策略 |  | 2d? | 2007-04-02 | 2007-04-03 | 22 | 28d | 0d | 产品定义工作组 | 16h |
| 25 | 4.2 | 建立产品目标和市场细分 |  | 2d? | 2007-04-04 | 2007-04-05 | 24 | 31d | 3d | 产品定义工作组 | 16h |
| 26 | 4.3 | 列出业务的重要特性 |  | 2d? | 2007-04-04 | 2007-04-05 | 24 | 31d | 3d | 产品定义工作组 | 16h |
| 27 | 4.4 | 评估每个细分市场的大小 |  | 2d? | 2007-04-04 | 2007-04-05 | 24 | 31d | 3d | 产品定义工作组 | 16h |
| 28 | 4.5 | 评估一段时间内的增长和发展 |  | 5d? | 2007-04-04 | 2007-04-10 | 24 | 28d | 0d | 产品定义工作组 | 40h |
| 29 | 4.6 | 量化产品的市场潜力 |  | 2d? | 2007-04-04 | 2007-04-05 | 24 | 31d | 3d | 产品定义工作组 | 16h |
| 30 | 4.7 | 为每个细分市场的销售设置初步时间表 |  | 5d? | 2007-04-04 | 2007-04-10 | 24 | 28d | 0d | 产品定义工作组 | 40h |
| 31 | 4.8 | 客户和目标市场细分已确定 | milestone | 0d | 2007-04-10 | 2007-04-10 | 30, 25, 26, 27, 28, 29 | 28d |  |  |  |

| ID | WBS | Task | Type | Duration | Start | Finish | Predecessors | Total slack | Free slack | Resources | Work |
| --- | --- | --- | --- | --- | --- | --- | --- | --- | --- | --- | --- |
| 32 | 5 | **确定业务模式和盈利方式** |  | 19d? | 2007-04-02 | 2007-04-26 |  | 16d |  |  | 400h |
| 33 | 5.1 | 确定建议的业务模式 |  | 2d? | 2007-04-02 | 2007-04-03 | 22 | 16d | 0d | 产品定义工作组 | 16h |
| 34 | 5.2 | 确定产品盈利方式 |  | 2d? | 2007-04-04 | 2007-04-05 | 33 | 29d | 0d | 产品定义工作组 | 16h |
| 35 | 5.3 | 确定客户需要购买的产品部件 |  | 2d? | 2007-04-06 | 2007-04-09 | 34 | 29d | 13d | 产品定义工作组 | 16h |
| 36 | 5.4 | 确定内部开发策略 |  | 2d? | 2007-04-04 | 2007-04-05 | 33 | 31d | 15d | 产品定义工作组 | 16h |
| 37 | 5.5 | 确定外包开发策略 |  | 2d? | 2007-04-04 | 2007-04-05 | 33 | 23d | 0d | 产品定义工作组 | 16h |
| 38 | 5.6 | 简单列出建议的供应商 |  | 5d? | 2007-04-06 | 2007-04-12 | 37 | 23d | 0d | 产品定义工作组 | 40h |
| 39 | 5.7 | 确定所有合作机会 |  | 3d? | 2007-04-13 | 2007-04-17 | 38 | 23d | 7d | 产品定义工作组 | 24h |
| 40 | 5.8 | 确定最适合目标市场的渠道 |  | 2d? | 2007-04-04 | 2007-04-05 | 33 | 16d | 0d | 产品定义工作组 | 16h |
| 41 | 5.9 | 建立分销渠道 |  | 10d? | 2007-04-06 | 2007-04-19 | 40 | 21d | 5d | 产品定义工作组 | 80h |
| 42 | 5.10 | 通过电子商务渠道探索业务的可伸缩性 |  | 10d? | 2007-04-06 | 2007-04-19 | 40 | 16d | 0d | 产品定义工作组 | 80h |
| 43 | 5.11 | 确定对竞争优势的影响 |  | 5d? | 2007-04-20 | 2007-04-26 | 42 | 16d | 0d | 产品定义工作组 | 40h |
| 44 | 5.12 | 确定对金融措施的影响 |  | 5d? | 2007-04-20 | 2007-04-26 | 42 | 16d | 0d | 产品定义工作组 | 40h |
| 45 | 5.13 | 完成业务模式和盈利 | milestone | 0d | 2007-04-26 | 2007-04-26 | 35, 36, 39, 41, 43, 44 | 16d |  |  |  |
| 46 | 6 | **确定竞争及其目标市场细分** |  | 30d? | 2007-04-02 | 2007-05-11 |  | 5d |  |  | 240h |
| 47 | 6.1 | 确定竞争优势 |  | 10d? | 2007-04-02 | 2007-04-13 | 22 | 5d | 0d | 产品定义工作组 | 80h |
| 48 | 6.2 | 确定每个细分市场中的竞争对手 |  | 5d? | 2007-04-16 | 2007-04-20 | 47 | 5d | 0d | 产品定义工作组 | 40h |
| 49 | 6.3 | 确定目标市场中生产类似产品的公司 |  | 5d? | 2007-04-23 | 2007-04-27 | 48 | 5d | 0d | 产品定义工作组 | 40h |
| 50 | 6.4 | 确定建立可持续竞争优势的方式 |  | 10d? | 2007-04-30 | 2007-05-11 | 49 | 5d | 0d | 产品定义工作组 | 80h |
| 51 | 6.5 | 竞争和目标市场细分已确定 | milestone | 0d | 2007-05-11 | 2007-05-11 | 50 | 5d |  |  |  |
| 52 | 7 | **确定成功措施** |  | 15d? | 2007-04-02 | 2007-04-20 |  | 0d |  |  | 200h |
| 53 | 7.1 | 确定风险 |  | 5d? | 2007-04-02 | 2007-04-06 | 22 | 0d |  | 产品定义工作组 | 40h |
| 54 | 7.2 | 确定所有进入障碍 |  | 5d? | 2007-04-02 | 2007-04-06 | 22 | 0d |  | 产品定义工作组 | 40h |
| 55 | 7.3 | 确定关键成功措施 |  | 5d? | 2007-04-02 | 2007-04-06 | 22 | 5d |  | 产品定义工作组 | 40h |
| 56 | 7.4 | 确定处理风险/障碍的策略 |  | 5d? | 2007-04-09 | 2007-04-13 | 53, 54 | 0d |  | 产品定义工作组 | 40h |
| 57 | 7.5 | 确定建立可防御市场定位的策略 |  | 5d? | 2007-04-16 | 2007-04-20 | 55, 56 | 0d |  | 产品定义工作组 | 40h |
| 58 | 7.6 | 已确定成功措施 | milestone | 0d | 2007-04-20 | 2007-04-20 | 57 | 0d |  |  |  |

Notes:
- 55: 第一个产品的上市时间，确立地位的速度，预计的更强有力的竞争对手，完成产品所需的巨大投资，会带来负面影响的资源影响，建立渠道的高成本等。

| ID | WBS | Task | Type | Duration | Start | Finish | Predecessors | Total slack | Free slack | Resources | Work |
| --- | --- | --- | --- | --- | --- | --- | --- | --- | --- | --- | --- |
| 59 | 8 | **确定产品工作组** |  | 20d? | 2007-04-23 | 2007-05-18 |  | 0d |  |  | 160h |
| 60 | 8.1 | 确定成功的工作组组成要素 |  | 5d? | 2007-04-23 | 2007-04-27 | 58 | 0d |  | 产品定义工作组 | 40h |
| 61 | 8.2 | 确定对于营销、开发、生产和增长所需要的关键质量 |  | 5d? | 2007-04-30 | 2007-05-04 | 60 | 0d |  | 产品定义工作组 | 40h |
| 62 | 8.3 | 确定当前/候选工作组成员 |  | 5d? | 2007-05-07 | 2007-05-11 | 61 | 0d |  | 产品定义工作组 | 40h |
| 63 | 8.4 | 确定和避免差距 |  | 5d? | 2007-05-14 | 2007-05-18 | 62 | 0d |  | 产品定义工作组 | 40h |
| 64 | 8.5 | 已确定产品工作组 | milestone | 0d | 2007-05-18 | 2007-05-18 | 63 | 0d |  |  |  |
| 65 | 9 | **确定产品的财务需求** |  | 17d? | 2007-04-02 | 2007-04-24 |  | 18d |  |  | 312h |
| 66 | 9.1 | 确定产品的财务标准 |  | 2d? | 2007-04-02 | 2007-04-03 | 22 | 18d | 0d | 产品定义工作组 | 16h |
| 67 | 9.2 | 确定组织发展和市场开发所需的成本 |  | 5d? | 2007-04-04 | 2007-04-10 | 66 | 18d | 0d | 产品定义工作组 | 40h |
| 68 | 9.3 | 确定开发产品所需的投资 |  | 5d? | 2007-04-04 | 2007-04-10 | 66 | 18d | 0d | 产品定义工作组 | 40h |
| 69 | 9.4 | 预测时间 |  | 2d? | 2007-04-04 | 2007-04-05 | 66 | 21d | 0d | 产品定义工作组 | 16h |
| 70 | 9.5 | 预测上市日期 |  | 5d? | 2007-04-06 | 2007-04-12 | 69 | 21d | 0d | 产品定义工作组 | 40h |
| 71 | 9.6 | 预测销售和销量 |  | 5d? | 2007-04-13 | 2007-04-19 | 70 | 21d | 3d | 产品定义工作组 | 40h |
| 72 | 9.7 | 项目有利和不利现金流 |  | 5d? | 2007-04-11 | 2007-04-17 | 67, 68 | 23d | 5d | 产品定义工作组 | 40h |
| 73 | 9.8 | 确定是否需要财务支持以及需要财务支持的时间 |  | 5d? | 2007-04-11 | 2007-04-17 | 67, 68 | 18d | 0d | 产品定义工作组 | 40h |
| 74 | 9.9 | 确定(所有)初始股东结构 |  | 5d? | 2007-04-18 | 2007-04-24 | 73 | 18d | 0d | 产品定义工作组 | 40h |
| 75 | 9.10 | 产品财务需求已确定 | milestone | 0d | 2007-04-24 | 2007-04-24 | 74, 71, 72 | 18d |  |  |  |
| 76 | 10 | **决定向前推动产品定义** |  | 16d? | 2007-05-21 | 2007-06-11 |  | 0d |  |  | 272h |
| 77 | 10.1 | 归档各个产品策略和方法 |  | 5d? | 2007-05-21 | 2007-05-25 | 22, 31, 45, 51, 58, 64, 75 | 0d |  | 产品定义工作组 | 40h |
| 78 | 10.2 | 确定总体产品生命力 |  | 2d? | 2007-05-28 | 2007-05-29 | 77 | 3d |  | 产品定义工作组 | 16h |
| 79 | 10.3 | 审阅建议的产品时间表 |  | 5d? | 2007-05-28 | 2007-06-01 | 77 | 0d |  | 赞助商; 产品定义工作组 | 80h |
| 80 | 10.4 | 审阅潜在的内部影响 |  | 5d? | 2007-05-28 | 2007-06-01 | 77 | 0d |  | 赞助商; 产品定义工作组 | 80h |
| 81 | 10.5 | 做出是否生产产品的业务判断 |  | 1d? | 2007-06-04 | 2007-06-04 | 78, 79, 80 | 0d |  | 赞助商; 产品定义工作组 | 16h |
| 82 | 10.6 | 交流以确定相应的业务部门 |  | 5d? | 2007-06-05 | 2007-06-11 | 81 | 0d |  | 赞助商 | 40h |
| 83 | 10.7 | 已做出判断并已进行交流 | milestone | 0d | 2007-06-11 | 2007-06-11 | 82 | 0d |  |  |  |
| 84 | 11 | 完成产品开发规划项目 | milestone | 0d | 2007-06-11 | 2007-06-11 | 83 | 0d |  | 产品经理; 产品营销人员; 产品研究; 产品开发 |  |
