# 供应商竞标(RFP)申请

Schedule from MS Project, 2007-01-01 to 2007-02-01.

## Calendars

- 标准: Mon-Fri 08:00-12:00, 13:00-17:00; Sat-Sun off.

## Resources

| Resource |
| --- |
| 采购经理 |
| 用户工作组 |
| 评估委员会 |
| 决策管理委员会 |

## Schedule

| ID | WBS | Task | Type | Duration | Start | Finish | Predecessors | Total slack | Free slack | Resources | Work |
| --- | --- | --- | --- | --- | --- | --- | --- | --- | --- | --- | --- |
| 1 | 1 | 阅读说明此模板用途的注释 | milestone | 0d | 2007-01-01 | 2007-01-01 |  | 0d |  |  |  |
| 2 | 2 | **竞标标准** |  | 2d? | 2007-01-01 | 2007-01-02 |  | 0d |  |  | 16h |
| 3 | 2.1 | 审核标准以确定是否需要正式的竞标流程 |  | 1d? | 2007-01-01 | 2007-01-01 | 1 | 0d |  | 用户工作组 | 8h |
| 4 | 2.2 | 通知需要创建竞标的采购 |  | 1d? | 2007-01-02 | 2007-01-02 | 3 | 0d |  | 用户工作组 | 8h |
| 5 | 3 | **竞标申请流程** |  | 7.5d? | 2007-01-03 | 2007-01-12 |  | 0d |  |  | 152h |
| 6 | 3.1 | **定义要求** |  | 4d? | 2007-01-03 | 2007-01-08 |  | 0d |  |  | 24h |
| 7 | 3.1.1 | 访问用户以了解其产品和服务需求 |  | 1d? | 2007-01-03 | 2007-01-03 | 4 | 0d |  | 用户工作组 | 8h |
| 8 | 3.1.2 | 将要求编档 |  | 1d? | 2007-01-04 | 2007-01-04 | 7 | 0d |  | 用户工作组 | 8h |
| 9 | 3.1.3 | 定义评估答复的标准 |  | 1d? | 2007-01-05 | 2007-01-05 | 8 | 0.5d | 0d | 评估委员会 | 8h |
| 10 | 3.1.4 | 确定评估工作组 |  | 1d? | 2007-01-08 | 2007-01-08 | 9 | 7.5d |  |  |  |
| 11 | 3.2 | **制定标书** |  | 4.5d? | 2007-01-03 | 2007-01-09 |  | 17d |  |  | 40h |
| 12 | 3.2.1 | 从采购部门获得模板确定标书格式 |  | 1d? | 2007-01-03 | 2007-01-03 | 4 | 18d | 1d | 用户工作组 | 8h |
| 13 | 3.2.2 | 拟定标书 |  | 0.5d? | 2007-01-05 | 2007-01-05 | 12, 8 | 17d | 0d | 采购经理; 用户工作组 | 8h |
| 14 | 3.2.3 | 与采购及主题专家审核 RFP |  | 1d? | 2007-01-05 | 2007-01-08 | 13 | 17d | 0d | 评估委员会 | 8h |
| 15 | 3.2.4 | 完善标书 |  | 1d? | 2007-01-08 | 2007-01-09 | 14 | 17d | 0d | 采购经理; 用户工作组 | 16h |
| 16 | 3.2.5 | 标书内容已准备好发放 | milestone | 0d | 2007-01-09 | 2007-01-09 | 15 | 17d |  |  |  |
| 17 | 3.3 | **市场研究** |  | 3.5d? | 2007-01-05 | 2007-01-10 |  | 0d |  |  | 40h |
| 18 | 3.3.1 | 确定可提供合适产品或服务的潜在公司 |  | 1d? | 2007-01-05 | 2007-01-05 | 8 | 0d |  | 采购经理; 用户工作组 | 16h |
| 19 | 3.3.2 | 确定是否需要就意向/信息提出初步请求 |  | 0.5d? | 2007-01-08 | 2007-01-08 | 18 | 0d |  | 采购经理; 用户工作组 | 8h |
| 20 | 3.3.3 | 征寻 RFI 答复(如果需要) |  | 1d? | 2007-01-08 | 2007-01-09 | 19 | 0d |  | 采购经理 | 8h |
| 21 | 3.3.4 | 为标书确定最终目标公司 |  | 1d? | 2007-01-09 | 2007-01-10 | 20 | 0d |  | 评估委员会 | 8h |
| 22 | 3.4 | **将标书发至行业** |  | 4.5d? | 2007-01-08 | 2007-01-12 |  | 0d |  |  | 48h |
| 23 | 3.4.1 | 确定特定答复阶段的期限 |  | 1d? | 2007-01-08 | 2007-01-08 | 9 | 0.5d | 0d | 采购经理; 用户工作组 | 16h |
| 24 | 3.4.2 | 最终确定包含最终期限和联系点的标书 |  | 1d? | 2007-01-09 | 2007-01-09 | 23 | 0.5d |  | 采购经理 | 8h |
| 25 | 3.4.3 | 将标书发至目标公司 |  | 1d? | 2007-01-10 | 2007-01-11 | 24, 21 | 0d |  | 采购经理 | 8h |
| 26 | 3.4.4 | 举行竞标简介(如果需要) |  | 1d? | 2007-01-11 | 2007-01-12 | 25 | 0d |  | 采购经理; 用户工作组 | 16h |
| 27 | 3.5 | 完成竞标申请流程 | milestone | 0d | 2007-01-12 | 2007-01-12 | 26 | 0d |  |  |  |

Notes:
- 1: 此模板提供一种标准流程，用于创建、分配和评估来自潜在供应商的竞标书。该模板供要求正式按批准的流程获得供应商服务的组织使用。通常情况下，此类流程用于竞购需要参与组织大笔支出的产品和服务。该流程可确保投标人具有相同的权利和机会来竞争。
- 10: 评估委员会应包括用户团体、采购组织、法律组织以及任何其他相关组织中的成员。
- 20: 此步骤通常用于在未知可用备选供应商时确定潜在的供应商，也可用于缩小需要对申请做出答复的潜在供应商的范围。在后一种情况下，可以在此点设置一个标准来缩小备选供应商的范围。

| ID | WBS | Task | Type | Duration | Start | Finish | Predecessors | Total slack | Resources | Work |
| --- | --- | --- | --- | --- | --- | --- | --- | --- | --- | --- |
| 28 | 4 | **申请后流程** |  | 14d? | 2007-01-12 | 2007-02-01 |  | 0d |  | 128h |
| 29 | 4.1 | 收集“投标意向”答复 |  | 1d? | 2007-01-12 | 2007-01-15 | 27 | 0d | 采购经理 | 8h |
| 30 | 4.2 | **“问题与解答”流程(&A)** |  | 3d? | 2007-01-15 | 2007-01-18 |  | 0d |  | 32h |
| 31 | 4.2.1 | 收集投标公司的问题 |  | 1d? | 2007-01-15 | 2007-01-16 | 29 | 0d | 采购经理 | 8h |
| 32 | 4.2.2 | 准备对问题的正式答复 |  | 1d? | 2007-01-16 | 2007-01-17 | 31 | 0d | 采购经理; 用户工作组 | 16h |
| 33 | 4.2.3 | 对“投标意向”列表中的所有公司公布答复 |  | 1d? | 2007-01-17 | 2007-01-18 | 32 | 0d | 采购经理 | 8h |
| 34 | 4.3 | **审核报价书** |  | 4d? | 2007-01-18 | 2007-01-24 |  | 0d |  | 40h |
| 35 | 4.3.1 | 执行初步评估并澄清关注的问题 |  | 1d? | 2007-01-18 | 2007-01-19 | 33, 10 | 0d | 评估委员会 | 8h |
| 36 | 4.3.2 | 根据确立的标准评估报价书 |  | 1d? | 2007-01-19 | 2007-01-22 | 35 | 0d | 评估委员会 | 8h |
| 37 | 4.3.3 | 淘汰不符合标准的投标人 |  | 1d? | 2007-01-22 | 2007-01-23 | 36 | 0d | 评估委员会 | 8h |
| 38 | 4.3.4 | 准备与余下的投标人讨论 |  | 1d? | 2007-01-23 | 2007-01-24 | 37 | 0d | 采购经理; 用户工作组 | 16h |
| 39 | 4.4 | **面对面讨论/协商** |  | 2d? | 2007-01-24 | 2007-01-26 |  | 0d |  | 16h |
| 40 | 4.4.1 | 邀请中标者展示其解决方案 |  | 1d? | 2007-01-24 | 2007-01-25 | 38 | 0d | 采购经理 | 8h |
| 41 | 4.4.2 | 分析中标者的解决方案和演示 |  | 1d? | 2007-01-25 | 2007-01-26 | 40 | 0d | 评估委员会 | 8h |
| 42 | 4.5 | **作出选择** |  | 4d? | 2007-01-26 | 2007-02-01 |  | 0d |  | 32h |
| 43 | 4.5.1 | 分析中标报价书 |  | 1d? | 2007-01-26 | 2007-01-29 | 41 | 0d | 评估委员会 | 8h |
| 44 | 4.5.2 | 选择供应商 |  | 1d? | 2007-01-29 | 2007-01-30 | 43 | 0d | 评估委员会 | 8h |
| 45 | 4.5.3 | 签署合同 |  | 1d? | 2007-01-30 | 2007-01-31 | 44 | 0d | 采购经理 | 8h |
| 46 | 4.5.4 | 向未中标者说明情况 |  | 1d? | 2007-01-31 | 2007-02-01 | 45 | 0d | 采购经理 | 8h |
| 47 | 4.6 | 完成申请后阶段 | milestone | 0d | 2007-02-01 | 2007-02-01 | 46 | 0d |  |  |
| 48 | 5 | 完成供应商竞标申请 | milestone | 0d | 2007-02-01 | 2007-02-01 | 47 | 0d |  |  |
