# 供应商评估和合并

Schedule from MS Project, 2007-01-01 to 2007-09-10.
公司倾向于与熟悉的，并能以有竞争力的成本提供优质服务的一群供应商合作。公司将定期审核与现有供应商的关系，以确保他们能提供高效优质的服务。审核的最终结果通常是，公司精选出更少的供应商，几乎专门与他们进行业务往来。通常情况下，被选中为主要供应商的供应商都提供费用打折的服务。此模板可以处理此类供应商评估和筛选流程所包含的常规活动。

## Calendars

- 标准: Mon-Fri 08:00-12:00, 13:00-17:00; Sat-Sun off.

## Resources

| Resource |
| --- |
| 管理人员 |
| 产品工程设计人员 |
| 项目经理 |
| 营销人员 |
| 加工工程师 |
| 制造工程师 |
| 安全人员 |
| 法律人员 |
| 会计 |
| 客户 |
| 采购人员 |
| 信息系统 |

## Schedule

| ID | WBS | Task | Type | Duration | Start | Finish | Predecessors | Total slack | Resources | Work |
| --- | --- | --- | --- | --- | --- | --- | --- | --- | --- | --- |
| 1 | 1 | **进行初步调查** |  | 15d? | 2007-01-01 | 2007-01-19 |  | 0d |  | 168h |
| 2 | 1.1 | 分配进行初步调查的资源 |  | 1d? | 2007-01-01 | 2007-01-01 |  | 0d | 采购人员 | 8h |
| 3 | 1.2 | 制定初步调查计划 |  | 5d? | 2007-01-01 | 2007-01-05 | 2SS | 0d | 采购人员 | 40h |
| 4 | 1.3 | 确定分析/供应商审阅范围 |  | 10d? | 2007-01-08 | 2007-01-19 | 3 | 0d | 采购人员 | 80h |
| 5 | 1.4 | 分析供应商前景和选项 |  | 5d? | 2007-01-01 | 2007-01-05 | 3SS | 175.5d | 采购人员 | 40h |
| 6 | 1.5 | 完成初步调查 | milestone | 0d | 2007-01-19 | 2007-01-19 | 2, 3, 4 | 0d |  |  |
| 7 | 2 | **进行供应商要求分析** |  | 20d? | 2007-01-22 | 2007-02-16 |  | 0d |  | 688h |
| 8 | 2.1 | **确定要合并的供应商集合** |  | 10d? | 2007-01-22 | 2007-02-02 |  | 0d |  | 160h |
| 9 | 2.1.1 | 分析采购和来源统计信息 |  | 5d? | 2007-01-22 | 2007-01-26 | 6 | 0d | 采购人员 | 40h |
| 10 | 2.1.2 | 分析供应商折扣条件和服务领域 |  | 5d? | 2007-01-22 | 2007-01-26 | 9SS | 0d | 采购人员 | 40h |
| 11 | 2.1.3 | 确定要包含的来源领域的优先次序 |  | 5d? | 2007-01-29 | 2007-02-02 | 10 | 0d | 采购人员 | 40h |
| 12 | 2.1.4 | 汇编要审阅的供应商列表 |  | 5d? | 2007-01-29 | 2007-02-02 | 11SS | 0d | 采购人员 | 40h |
| 13 | 2.1.5 | 完成供应商集合确认 | milestone | 0d | 2007-02-02 | 2007-02-02 | 12, 11 | 0d |  |  |
| 14 | 2.2 | **制定比较标准和过程** |  | 10d? | 2007-02-05 | 2007-02-16 |  | 0d |  | 528h |
| 15 | 2.2.1 | 制定供应商选择技术规范 |  | 5d? | 2007-02-05 | 2007-02-09 | 13 | 0d | 产品工程设计人员; 制造工程师; 采购人员 | 44h |
| 16 | 2.2.2 | 制定供应商选择供应链物流性能标准 |  | 5d? | 2007-02-05 | 2007-02-09 | 15SS | 0d | 加工工程师; 制造工程师; 采购人员 | 44h |
| 17 | 2.2.3 | 制定供应商选择财务稳定性标准 |  | 5d? | 2007-02-05 | 2007-02-09 | 15SS | 0d | 会计; 采购人员 | 80h |
| 18 | 2.2.4 | 制定供应商选择质量性能标准 |  | 5d? | 2007-02-05 | 2007-02-09 | 15SS | 0d | 产品工程设计人员; 采购人员 | 80h |
| 19 | 2.2.5 | 制定供应商销售和客户服务标准 |  | 5d? | 2007-02-05 | 2007-02-09 | 15SS | 0d | 营销人员; 采购人员 | 80h |
| 20 | 2.2.6 | 制定供应商全球分布标准 |  | 5d? | 2007-02-05 | 2007-02-09 | 15SS | 0d | 制造工程师; 采购人员 | 80h |
| 21 | 2.2.7 | 确定风险评估标准 |  | 5d? | 2007-02-05 | 2007-02-09 | 15SS | 150.5d | 会计; 采购人员 | 80h |
| 22 | 2.2.8 | 制定用于比较供应商的加权和记分方法 |  | 5d? | 2007-02-12 | 2007-02-16 | 15, 16, 17, 18, 19, 20 | 0d | 采购人员 | 40h |
| 23 | 2.2.9 | 完成比较标准和过程 | milestone | 0d | 2007-02-16 | 2007-02-16 | 22 | 145.5d |  |  |
| 24 | 3 | **选择供应商** |  | 165.5d? | 2007-01-22 | 2007-09-10 |  | 0d |  | 1648h |
| 25 | 3.1 | 确定供应商选择工作组并举行启动会议 |  | 1d? | 2007-01-22 | 2007-01-22 | 6 | 19d | 采购人员 | 8h |

Notes:
- 1: 调查阶段可能涵盖供应商使用模式和需求，以及行业范围的外包趋势。
- 2: 此计划假定活动由业务分析员或财务人员启动。 / 如果某务涉及分配资源，这意味着需要选择接触过供应商并具有指定职能的一组人员。
- 4: 范围表示确定用于评估供应商的规则。例如，业务往来量的大小、过去外包的工作业绩、公司大小和稳定性、位置(以及由距离导致的所有问题)、提供的费率等。
- 5: 是否将要评估的供应商集合仅限制为现有供应商? 这些供应商之间的区别要素是什么(大/小，本地/外地，等等)。
- 11: 供应商领域示例: / 与办公室支持、材料收购、开发资源、业务过程咨询等有关的供应商集合。
- 14: 根据公司在与供应商建立关系方面的经验以及确定的目标领域，标准将会有所不同。
- 21: 潜在风险示例: 将供应商更改为不履行职责的新供应商。 / 此任务的目的在于制定确定各种风险优先次序或权衡风险的标准，以便在决策时使用。

| ID | WBS | Task | Type | Duration | Start | Finish | Predecessors | Total slack | Resources | Work |
| --- | --- | --- | --- | --- | --- | --- | --- | --- | --- | --- |
| 26 | 3.2 | **创建建议征求书(RFP)并分发** |  | 56d? | 2007-02-19 | 2007-05-07 |  | 0d |  | 528h |
| 27 | 3.2.1 | 收集信息 |  | 15d? | 2007-02-19 | 2007-03-09 | 25, 22 | 0d | 采购人员 | 120h |
| 28 | 3.2.2 | 确定并联系抽样客户群 |  | 5d? | 2007-03-12 | 2007-03-16 | 27 | 0d | 采购人员 | 40h |
| 29 | 3.2.3 | 确定目标公司 |  | 15d? | 2007-03-19 | 2007-04-06 | 28 | 0d | 采购人员 | 120h |
| 30 | 3.2.4 | 重新确定 RFP 要求 |  | 10d? | 2007-04-09 | 2007-04-20 | 29 | 0d | 采购人员 | 80h |
| 31 | 3.2.5 | 创建 RFP |  | 10d? | 2007-04-23 | 2007-05-04 | 30 | 0d | 法律人员; 采购人员 | 160h |
| 32 | 3.2.6 | 分发 RFP |  | 1d? | 2007-05-07 | 2007-05-07 | 31 | 0d | 采购人员 | 8h |
| 33 | 3.2.7 | 完成创建和分发 RFP | milestone | 0d | 2007-05-07 | 2007-05-07 | 32 | 0d |  |  |
| 34 | 3.3 | **结束 RFP 过程，收集并分析 RFP 响应** |  | 15d? | 2007-05-08 | 2007-05-28 |  | 0d |  | 96h |
| 35 | 3.3.1 | 举行供应商响应答疑会 |  | 2d? | 2007-05-08 | 2007-05-09 | 33 | 0d | 采购人员 | 16h |
| 36 | 3.3.2 | 收到所有供应商的答复 | milestone | 0d | 2007-05-14 | 2007-05-14 | 35FS+5ed | 0d |  |  |
| 37 | 3.3.3 | 评估最终的供应商响应 |  | 10d? | 2007-05-15 | 2007-05-28 | 36 | 0d | 采购人员 | 80h |
| 38 | 3.4 | **审阅供应商响应，寻求合并机会** |  | 45d? | 2007-05-29 | 2007-07-30 |  | 0d |  | 560h |
| 39 | 3.4.1 | 制定供应商合并方案 |  | 25d? | 2007-05-29 | 2007-07-02 | 37 | 0d | 管理人员; 采购人员 | 400h |
| 40 | 3.4.2 | 评估建议并确定协商领域 |  | 5d? | 2007-07-03 | 2007-07-09 | 39 | 0d | 采购人员 | 40h |
| 41 | 3.4.3 | 检查现有供应商合同中的终止条款影响 |  | 5d? | 2007-07-10 | 2007-07-16 | 40 | 0d | 采购人员 | 40h |
| 42 | 3.4.4 | 准备合并和应变方案 |  | 10d? | 2007-07-17 | 2007-07-30 | 41 | 0d | 采购人员 | 80h |
| 43 | 3.5 | **选择继续合作的供应商** |  | 29.5d? | 2007-07-31 | 2007-09-10 |  | 0d |  | 456h |
| 44 | 3.5.1 | 最终确定选择以及协商的条款与条件 |  | 10d? | 2007-07-31 | 2007-08-13 | 42 | 0d | 采购人员 | 80h |
| 45 | 3.5.2 | 最终确定合同 |  | 7.5d? | 2007-08-14 | 2007-08-23 | 44 | 0d | 客户; 采购人员 | 120h |
| 46 | 3.5.3 | 向未选中的供应商通知决定 |  | 1d? | 2007-08-23 | 2007-08-24 | 45 | 0d | 采购人员 | 8h |
| 47 | 3.5.4 | 更新信息系统 |  | 10d? | 2007-08-24 | 2007-09-07 | 46 | 0d | 产品工程设计人员; 会计; 采购人员; 信息系统 | 240h |
| 48 | 3.5.5 | 内部交流选择的供应商 |  | 1d? | 2007-09-07 | 2007-09-10 | 47 | 0d | 采购人员 | 8h |
| 49 | 3.6 | 完成选择 | milestone | 0d | 2007-09-10 | 2007-09-10 | 48 | 0d |  |  |
| 50 | 4 | 完成供应商合并 | milestone | 0d | 2007-09-10 | 2007-09-10 | 49 | 0d |  |  |

Notes:
- 26: 在这一组风险中，我们将从内部资源收集信息，以帮助制定 RFP。
- 42: 应变方案应涵盖诸如未履行预期性能标准，以及供应商稳定性问题等项目。
- 48: 确保内部交流过程及其结论，最终批准的供应商列表正确，并分发到相应人员。
