# 保险索赔处理

Schedule from MS Project, 2007-01-01 to 2007-01-30.

## Calendars

- 标准: Mon-Fri 08:00-12:00, 13:00-17:00; Sat-Sun off.

## Resources

| Resource |
| --- |
| 客户/索赔人 |
| 外部索赔人 |
| 代理 |
| 估价人 |
| 理赔人 |
| 审核员 |
| 维修人员 |
| 报废场 |
| 客户 |
| 索赔方 |

## Schedule

| ID | WBS | Task | Type | Duration | Start | Finish | Predecessors | Total slack | Free slack | Resources | Work |
| --- | --- | --- | --- | --- | --- | --- | --- | --- | --- | --- | --- |
| 1 | 1 | 阅读说明此模板用途的注释 | milestone | 0d | 2007-01-01 08:00 | 2007-01-01 08:00 |  | 0d |  |  |  |
| 2 | 2 | 登记索赔要求，或者客户通知我们可能要索赔 |  | 2h | 2007-01-01 08:00 | 2007-01-01 10:00 | 1 | 0d |  | 代理; 客户 | 4h |
| 3 | 3 | **将肇事客户索赔输入系统** |  | 0.31d | 2007-01-01 10:00 | 2007-01-01 13:30 |  | 0d |  |  | 5h |
| 4 | 3.1 | 分配事故确定人员 | milestone | 0d | 2007-01-01 10:00 | 2007-01-01 10:00 | 2 | 0d |  |  |  |
| 5 | 3.2 | 收集索赔信息 |  | 2h | 2007-01-01 10:00 | 2007-01-01 12:00 | 4 | 0d |  | 代理; 客户 | 4h |
| 6 | 3.3 | 将索赔人引导给估价人员 |  | 0.5h | 2007-01-01 13:00 | 2007-01-01 13:30 | 5 | 0d |  | 代理; 客户 | 1h |
| 7 | 4 | 分配理赔人 |  | 1d | 2007-01-01 13:30 | 2007-01-02 13:30 | 6 | 0d |  | 理赔人 | 8h |
| 8 | 5 | 理赔人检查“未修复的损坏”历史记录 |  | 1h | 2007-01-02 13:30 | 2007-01-02 14:30 | 7 | 0d |  | 理赔人 | 1h |
| 9 | 6 | 客户将汽车交付估价人员 |  | 2d | 2007-01-02 14:30 | 2007-01-04 14:30 | 8 | 0d |  | 客户 | 16h |
| 10 | 7 | 估价人员检查损坏情况 |  | 2h | 2007-01-04 14:30 | 2007-01-04 16:30 | 9 | 0d |  | 估价人 | 2h |
| 11 | 8 | 由理赔人审核/批准估价 |  | 1h | 2007-01-04 16:30 | 2007-01-05 08:30 | 10 | 0d |  |  |  |
| 12 | 9 | **如果估价未超出保险免赔额** |  | 11.75d | 2007-01-05 08:30 | 2007-01-22 15:30 |  | 0d |  |  | 174.5h |
| 13 | 9.1 | 理赔人建议可用的维修地点 |  | 0.5h | 2007-01-05 08:30 | 2007-01-05 09:00 | 11 | 0d |  | 理赔人 | 0.5h |
| 14 | 9.2 | 在“未修复的损坏”组中登记索赔信息和估价 |  | 1h | 2007-01-05 09:00 | 2007-01-05 10:00 | 13 | 0d |  | 理赔人 | 1h |
| 15 | 9.3 | **如果存在“隐藏的损坏”** |  | 1.5d | 2007-01-05 10:00 | 2007-01-08 15:00 |  | 0d |  |  | 12h |
| 16 | 9.3.1 | 维修人员通知理赔人 |  | 1d | 2007-01-05 10:00 | 2007-01-08 10:00 | 14 | 0d |  | 维修人员 | 8h |
| 17 | 9.3.2 | 理赔人确定新的估价是否超出保险免赔额 |  | 4h | 2007-01-08 10:00 | 2007-01-08 15:00 | 16 | 0d |  | 理赔人 | 4h |
| 18 | 9.4 | 进行维修(由客户支付费用) |  | 10d | 2007-01-08 15:00 | 2007-01-22 15:00 | 17 | 4.12d | 0d | 理赔人; 维修人员 | 160h |
| 19 | 9.5 | 客户通知我们维修结束(以及金额) |  | 0.5h | 2007-01-22 15:00 | 2007-01-22 15:30 | 18 | 4.12d | 0d | 代理; 客户 | 1h |
| 20 | 9.6 | 客户[维修]完成 | milestone | 0d | 2007-01-22 15:30 | 2007-01-22 15:30 | 19 | 4.12d |  |  |  |
| 21 | 10 | **如果估价超出保险免赔额** |  | 14.19d | 2007-01-08 15:00 | 2007-01-26 16:30 |  | 0d |  |  | 98h |
| 22 | 10.1 | **如果认为汽车“不可修复”** |  | 1d | 2007-01-08 15:00 | 2007-01-09 15:00 |  | 13.19d |  |  | 8h |
| 23 | 10.1.1 | 支付金额(减去保险免赔额)，减去报废收入 |  | 1d | 2007-01-08 15:00 | 2007-01-09 15:00 | 11, 17 | 13.19d | 0d | 理赔人 | 8h |
| 24 | 10.1.2 | 客户(维修)结束 | milestone | 0d | 2007-01-09 15:00 | 2007-01-09 15:00 | 23 | 13.19d |  |  |  |

Notes:
- 1: 此模板从保险公司的角度遍历整个流程。 / 该模板以汽车保险的理念体系为出发点，而此流程与房屋保险类似。 / 专业用语: / 客户 = 我们为其提供保险的人员(我们是保险公司) / 索赔人 = 财产受到我们的客户损害的人员 / (注: 可以是受损害方或他们的法定代表。) / 座席 = 投诉电话端的本地座席或代表 / 估价人员 = 可以是内部驾驶中索赔部门或车身修理厂或挡风玻璃维修专业人士 / 理赔人 = 执行估价后管理索赔的内部人员 / 审计人员 = 内部审核成员 - 执行随机检查 / 维修人员 = 进行维修的人员 / 报废场 = 不可修复的车辆的停放地
- 3: 这是客户的肇事索赔。如果事故涉及多个人员，则可能将先创建一个事件，而不是首先报告客户索赔，即便在客户不是首先报告的人员的情况下也是如此。在与客户联系上并提交索赔的时候才能采取进一步的行动。
- 5: 需要的信息示例: / 事故日期 / 事故详细信息 / 事故涉及的其他人员(如果有)的身份信息 / 警方报告(如果有记录或可用) / 事故是否涉及会对任何一方的伤害(或潜在伤害)
- 6: 索赔人员将接洽的估价人员可能是 / 公司的不停车索赔分公司 / 批准的车身修理厂 / 在挡风玻璃修理的案例中，是批准的挡风玻璃维修店
- 9: 这也可能由保险公司来支付。这可能是由两辆卡车造成的。 / 注: 许多情况下，理赔人是保险公司的估价人。车身修理厂也将有一位与理赔人协同工作的估价人员。
- 13: 维修地点仅供参考，因为客户负责所有付款。
- 14: 未维修的损坏公司通常是外部公司，他们在第一起事故维修尚未完成即发生另一起事故的情况下，跟踪现有的索赔和维修。这些公司将对信息进行协调，以确保不会对原始损坏重复支付。
- 17: 如果估价超出保险免赔额(并且经过理赔人的同意)，则将继续处理如果维修超出保险免赔额行。
- 23: 如果直接由保险公司接收报废收入，则报废场将收到拖离/购买的通知，发放的金额将不扣除销售报废车辆的收入。

| ID | WBS | Task | Type | Duration | Start | Finish | Predecessors | Total slack | Free slack | Resources | Work |
| --- | --- | --- | --- | --- | --- | --- | --- | --- | --- | --- | --- |
| 25 | 10.2 | **如果进行了维修(超出保险免赔额)** |  | 14.19d | 2007-01-08 15:00 | 2007-01-26 16:30 |  | 0d |  |  | 90h |
| 26 | 10.2.1 | 进行维修 |  | 10d | 2007-01-08 15:00 | 2007-01-22 15:00 | 11, 17 | 0d |  | 维修人员 | 80h |
| 27 | 10.2.2 | 客户对保险免赔额以内的费用开单(并付款) |  | 0.5h | 2007-01-22 15:00 | 2007-01-22 15:30 | 26 | 0d |  | 维修人员; 客户 | 1h |
| 28 | 10.2.3 | 接收维修发票(由维修人员开具) | milestone | 0d | 2007-01-25 15:30 | 2007-01-25 15:30 | 27FS+3ed | 0d |  | 理赔人 |  |
| 29 | 10.2.4 | 理赔人批准向维修人员的付款 |  | 1d | 2007-01-25 15:30 | 2007-01-26 15:30 | 28 | 0d |  | 理赔人 | 8h |
| 30 | 10.2.5 | 在“未修复的损坏”组中登记维修结束信息 |  | 1h | 2007-01-26 15:30 | 2007-01-26 16:30 | 29 | 0d |  | 理赔人 | 1h |
| 31 | 10.2.6 | 客户事故(维修)索赔结束 | milestone | 0d | 2007-01-26 16:30 | 2007-01-26 16:30 | 30 | 0d |  |  |  |
| 32 | 11 | **如果索赔涉及伤害** |  | 1d | 2007-01-01 10:00 | 2007-01-02 10:00 |  | 18.69d |  |  | 9h |
| 33 | 11.1 | 如果为“非过失”状态，或有医疗附加条款，则支付全部伤害金额 |  | 1d | 2007-01-01 10:00 | 2007-01-02 10:00 | 2 | 18.69d | 0d | 理赔人 | 8h |
| 34 | 11.2 | 如果为“过失”状态，并且客户伤害了外部索赔人员，则在收据上标记为可能会有潜在的诉讼 |  | 1h | 2007-01-01 10:00 | 2007-01-01 11:00 | 2 | 19.56d | 0.88d | 理赔人 | 1h |
| 35 | 11.3 | 客户伤害索赔结束 | milestone | 0d | 2007-01-02 10:00 | 2007-01-02 10:00 | 33, 34 | 18.69d |  |  |  |
| 36 | 12 | **针对每个索赔人(适用于多人索赔事故)** |  | 15.44d | 2007-01-02 13:30 | 2007-01-23 17:00 |  | 2.94d |  |  | 220h |
| 37 | 12.1 | 索赔人提交索赔文件 | milestone | 0d | 2007-01-02 13:30 | 2007-01-02 13:30 | 7 | 2.94d | 0d | 索赔方 |  |
| 38 | 12.2 | 理赔人检查“未修复的损坏”历史记录 |  | 1h | 2007-01-02 13:30 | 2007-01-02 14:30 | 37 | 2.94d | 0d | 理赔人 | 1h |
| 39 | 12.3 | 估价人员检查损坏情况 |  | 2h | 2007-01-02 14:30 | 2007-01-02 16:30 | 38 | 2.94d | 0d | 估价人 | 2h |
| 40 | 12.4 | 理赔人审核估价 |  | 1h | 2007-01-02 16:30 | 2007-01-03 08:30 | 39 | 2.94d | 0d | 理赔人 | 1h |
| 41 | 12.5 | 进行维修 |  | 10d | 2007-01-03 08:30 | 2007-01-17 08:30 | 40 | 2.94d | 0d | 维修人员 | 80h |
| 42 | 12.6 | 接收维修发票(由维修人员开具) | milestone | 0d | 2007-01-20 08:30 | 2007-01-20 08:30 | 41FS+3ed | 2.94d | 0d | 理赔人 |  |
| 43 | 12.7 | 向维修人员付费 |  | 1d | 2007-01-22 08:00 | 2007-01-22 17:00 | 42 | 2.94d | 0d | 理赔人 | 8h |
| 44 | 12.8 | 最终确定系统中的事故项 |  | 1d | 2007-01-23 08:00 | 2007-01-23 17:00 | 43 | 2.94d | 0d | 理赔人 | 8h |
| 45 | 12.9 | 结束本次索赔人[维修]索赔 | milestone | 0d | 2007-01-23 17:00 | 2007-01-23 17:00 | 44 | 2.94d |  |  |  |
| 46 | 12.10 | **如果索赔涉及伤害** |  | 10d | 2007-01-02 13:30 | 2007-01-16 13:30 |  | 8.38d |  |  | 120h |
| 47 | 12.10.1 | 协商伤害解决方法 |  | 5d | 2007-01-02 13:30 | 2007-01-09 13:30 | 37 | 8.38d | 0d | 理赔人; 索赔方 | 80h |
| 48 | 12.10.2 | 发放支付 |  | 5d | 2007-01-09 13:30 | 2007-01-16 13:30 | 47 | 8.38d | 0d | 理赔人 | 40h |
| 49 | 12.10.3 | 结束本次索赔人[伤害]索赔 | milestone | 0d | 2007-01-16 13:30 | 2007-01-16 13:30 | 48 | 8.38d |  |  |  |

Notes:
- 29: 如果存在隐藏的损坏(进行估价时未发现的损坏)，则需要由理赔人及维修人员协商达成协议。
- 33: 还将通知客户批准的医疗机构/ (注: 如果医疗索赔超出各州规定的个人伤害赔偿金额的上限，即使状态为无过失也可能会引发诉讼)。
- 36: 多个索赔人均可登记肇事客户事故。 / 在上一个索赔人提交完成并结束之前，此流程以及流程中的所有任务均将保持未处理状态。
- 43: 支付时间因各个保险公司业务操作而各异。
- 45: 这不会结束任何已有的伤害索赔。
- 47: 保险公司将尝试尽快解决此问题，因为拖延的时间越长，索赔人员诉诸法律的可能性就越大。 / 但是，如果超出了内部保险公司支付金额的界限，则需要得到保险公司代表医师的确认，而此流程所需时间也将延长。
- 48: 协商解决方案一经签署，即支付费用，其中包括这是一个最终解决方案的法律效果声明。
- 49: 除非同时结束维修索赔，否则伤害索赔不会结束事件。

| ID | WBS | Task | Type | Duration | Start | Finish | Predecessors | Total slack |
| --- | --- | --- | --- | --- | --- | --- | --- | --- |
| 50 | 13 | **代位求偿分析** |  | 1.5d | 2007-01-26 16:30 | 2007-01-30 11:30 |  | 0d |
| 51 | 13.1 | 检查代位求偿流程的应用案例 |  | 1d | 2007-01-26 16:30 | 2007-01-29 16:30 | 45, 49, 35, 20, 24, 31 | 0d |
| 52 | 13.2 | 如果可以应用代位求偿，则将启动代位求偿流程 |  | 4h | 2007-01-29 16:30 | 2007-01-30 11:30 | 51 | 0d |
| 53 | 14 | 事故/肇事索赔结束 | milestone | 0d | 2007-01-30 11:30 | 2007-01-30 11:30 | 52 | 0d |

Notes:
- 50: 代位求偿指的是保险公司向已经为其支付索赔的责任方(或其保险公司)寻求补偿的过程。 / 个人案例中代位求偿的适用情况取决于事件的发生环境、各州适用的法律以及政策条文等。 / 投保人有义务与保险公司在索赔过程的调查阶段中进行合作。合作内容包括帮助确定重要事实、保存证据以及任何能够加速请求赔偿的流程的行动。投保人不要采取任何可能会导致放弃请求赔偿的权利，这一点很重要。 / 另请注意，共同承担责任(称为相对过失)的情况，这指的是在不同方面涉及多个保险公司的情况。我们可以是代位求偿的发起人，同时又是代位求偿的目标对象。
- 51: 如果未投保方有过失，这还将包括获取相关方的信用报告，以确定是否有必要代位求偿。
- 52: 这是一个完整的流程。此流程已被启动，但并未结束索赔要求。 / 流程的第一部分是向过失方发送意向书，起诉其损坏行为。
