# 内部入职准备培训

Schedule from MS Project, 2007-01-01 to 2007-03-12.

## Calendars

- 标准: Mon-Fri 08:00-12:00, 13:00-17:00; Sat-Sun off.

## Resources

| Resource |
| --- |
| 培训负责人 |
| 指导设计师 |
| 主题专家(SME) |
| 内容开发人员 |
| 讲师 |
| 后勤供应商 |
| 培训经理 |

## Schedule

| ID | WBS | Task | Type | Duration | Start | Finish | Predecessors | Total slack | Free slack | Resources | Work |
| --- | --- | --- | --- | --- | --- | --- | --- | --- | --- | --- | --- |
| 1 | 1 | 阅读说明此模板用途的注释 | milestone | 0d | 2007-01-01 | 2007-01-01 |  | 0d |  |  |  |
| 2 | 2 | **组建内部销售人员入职准备工作组** |  | 2d? | 2007-01-01 | 2007-01-02 |  | 0d |  |  | 40h |
| 3 | 2.1 | 确定工作组负责人 |  | 1d? | 2007-01-01 | 2007-01-01 | 1 | 0d |  | 培训经理 | 8h |
| 4 | 2.2 | **确定来自以下组的资源** |  | 1d? | 2007-01-01 | 2007-01-01 |  | 0d |  |  | 24h |
| 5 | 2.2.1 | 人力资源组织 |  | 1d? | 2007-01-01 | 2007-01-01 |  | 49.25d |  |  |  |
| 6 | 2.2.2 | 公司营销 |  | 1d? | 2007-01-01 | 2007-01-01 | 1 | 0d |  | 培训经理 | 8h |
| 7 | 2.2.3 | 管理工作组 - 销售子公司 |  | 1d? | 2007-01-01 | 2007-01-01 | 1 | 0d |  | 培训经理 | 8h |
| 8 | 2.2.4 | 销售团队 |  | 1d? | 2007-01-01 | 2007-01-01 | 1 | 0d |  | 培训经理 | 8h |
| 9 | 2.3 | 确定角色和职责 |  | 1d? | 2007-01-02 | 2007-01-02 | 6, 7, 8, 3 | 0d |  | 培训负责人 | 8h |
| 10 | 2.4 | 完成内部销售入职准备工作组组建工作 | milestone | 0d | 2007-01-02 | 2007-01-02 | 9 | 0d |  |  |  |
| 11 | 3 | **需求评估** |  | 15.25d? | 2007-01-03 | 2007-01-24 |  | 0d |  |  | 184h |
| 12 | 3.1 | 在启动会议上推出销售人员培训项目 |  | 0.25d? | 2007-01-03 | 2007-01-03 | 10 | 0d |  | 培训负责人; 指导设计师; 主题专家(SME); 内容开发人员 | 6h |
| 13 | 3.2 | **与重要资源一起审核培训需求** |  | 10d? | 2007-01-03 | 2007-01-17 |  | 0d |  |  | 98h |
| 14 | 3.2.1 | **公司营销** |  | 0.75d? | 2007-01-03 | 2007-01-03 |  | 9.25d |  |  | 18h |
| 15 | 3.2.1.1 | 确定高层次的销售需求 |  | 0.25d? | 2007-01-03 | 2007-01-03 | 12 | 9.25d | 0d | 培训负责人; 指导设计师; 主题专家(SME); 内容开发人员 | 6h |
| 16 | 3.2.1.2 | 确定需要向销售团队传达的新消息和设想 |  | 0.25d? | 2007-01-03 | 2007-01-03 | 15 | 9.25d | 0d | 培训负责人; 指导设计师; 主题专家(SME); 内容开发人员 | 6h |
| 17 | 3.2.1.3 | 确定市场新潮流 |  | 0.25d? | 2007-01-03 | 2007-01-03 | 16 | 9.25d |  | 培训负责人; 指导设计师; 主题专家(SME); 内容开发人员 | 6h |
| 18 | 3.2.2 | **销售管理和销售资源** |  | 10d? | 2007-01-03 | 2007-01-17 |  | 0d |  |  | 80h |
| 19 | 3.2.2.1 | 确定知识缺口 |  | 1d? | 2007-01-03 | 2007-01-04 | 12 | 0d |  | 指导设计师 | 8h |
| 20 | 3.2.2.2 | 确定销售结算中的常见问题 |  | 1d? | 2007-01-04 | 2007-01-05 | 19 | 0d |  | 指导设计师 | 8h |
| 21 | 3.2.2.3 | 确定常见竞争性问题 |  | 1d? | 2007-01-05 | 2007-01-08 | 20 | 0d |  | 指导设计师 | 8h |
| 22 | 3.2.2.4 | 销售团队需要哪些培训? |  | 2d? | 2007-01-08 | 2007-01-10 | 21 | 0d |  | 指导设计师 | 16h |
| 23 | 3.2.2.5 | 确定受众细分 |  | 2d? | 2007-01-10 | 2007-01-12 | 22 | 0d |  | 指导设计师 | 16h |
| 24 | 3.2.2.6 | 确定每个受众细分所需的内容 |  | 3d? | 2007-01-12 | 2007-01-17 | 23 | 0d |  | 指导设计师 | 24h |

Notes:
- 1: 此模板提供了一个计划，用于为内部培训方案确定培训需求、开发和部署后续培训解决方案。此模板着重于以销售为目的的内部培训，但是其总体框架也可用于其他培训。
- 2: 此工作组将负责确定内部销售培训需求，并对为满足需求所做的工作进行管理。系统将确定同时代表需求区域以及受众的外部资源，并将其纳入工作组。
- 4: 所选人员的职务可能各不相同，但他们在此项目中的角色均为指导设计、内容设计以及主题专家(SME)专业技能的组合。
- 9: 工作组成员需要了解自己的预期工作内容以及工作投入程度。
- 11: 需求评估可以确定对公司最有利的培训的可能领域。收益是由工作组中出现的组织部门确定的。
- 12: 此会议必须有效传达工作组的任务、工作组成员的角色以及所要求的工作投入程度。如果不能达到工作投入程度的要求，则工作组成员必须帮助确定备选成员。

| ID | WBS | Task | Type | Duration | Start | Finish | Predecessors | Total slack | Free slack | Resources | Work |
| --- | --- | --- | --- | --- | --- | --- | --- | --- | --- | --- | --- |
| 25 | 3.3 | **培训内容审核** |  | 5d? | 2007-01-17 | 2007-01-24 |  | 0d |  |  | 40h |
| 26 | 3.3.1 | 审核当前培训材料中的缺陷 |  | 1d? | 2007-01-17 | 2007-01-18 | 17, 24 | 0d |  | 指导设计师 | 8h |
| 27 | 3.3.2 | 审核内容作者对培训材料的反馈 |  | 1d? | 2007-01-18 | 2007-01-19 | 26 | 0d |  | 指导设计师 | 8h |
| 28 | 3.3.3 | 确定当前培训材料中可重复利用的组件 |  | 2d? | 2007-01-19 | 2007-01-23 | 27 | 0d |  | 指导设计师 | 16h |
| 29 | 3.3.4 | 结果编档 |  | 1d? | 2007-01-23 | 2007-01-24 | 28 | 0d |  | 指导设计师 | 8h |
| 30 | 3.3.5 | 完成培训材料审核 | milestone | 0d | 2007-01-24 | 2007-01-24 | 29 | 0d |  |  |  |
| 31 | 3.4 | **培训提供方案审核** |  | 5d? | 2007-01-17 | 2007-01-24 |  | 0d |  |  | 40h |
| 32 | 3.4.1 | 将当前培训提供方法分类 |  | 1d? | 2007-01-17 | 2007-01-18 | 17, 24 | 0d |  | 指导设计师 | 8h |
| 33 | 3.4.2 | 确定最有效的方法 |  | 1d? | 2007-01-18 | 2007-01-19 | 32 | 0d |  | 指导设计师 | 8h |
| 34 | 3.4.3 | 审核以前培训方案开展过程中遇到的问题 |  | 1d? | 2007-01-19 | 2007-01-22 | 33 | 0d |  | 指导设计师 | 8h |
| 35 | 3.4.4 | 审核讲师对培训方案的反馈 |  | 1d? | 2007-01-22 | 2007-01-23 | 34 | 0d |  | 指导设计师 | 8h |
| 36 | 3.4.5 | 结果编档 |  | 1d? | 2007-01-23 | 2007-01-24 | 35 | 0d |  | 指导设计师 | 8h |
| 37 | 3.4.6 | 完成培训提供方案审核 | milestone | 0d | 2007-01-24 | 2007-01-24 | 36 | 0d |  |  |  |
| 38 | 4 | **内容和培训提供规划** |  | 20d? | 2007-01-24 | 2007-02-21 |  | 0d |  |  | 204h |
| 39 | 4.1 | **内容开发规划** |  | 8d? | 2007-01-24 | 2007-02-05 |  | 0d |  |  | 72h |
| 40 | 4.1.1 | 确定课程数量和课时 |  | 1d? | 2007-01-24 | 2007-01-25 | 30, 37 | 0d |  | 指导设计师 | 8h |
| 41 | 4.1.2 | 确定各个课程的主题和目标 |  | 1d? | 2007-01-25 | 2007-01-26 | 40 | 0d |  | 指导设计师 | 8h |
| 42 | 4.1.3 | 确定组成要素 - 员工内容/学习材料 |  | 1d? | 2007-01-26 | 2007-01-29 | 41 | 0d |  | 指导设计师 | 8h |
| 43 | 4.1.4 | 确定审核内容的主题专家(SME) |  | 2d? | 2007-01-29 | 2007-01-31 | 42 | 0d |  | 指导设计师 | 16h |
| 44 | 4.1.5 | 确定内容开发人员(内部人员和外部供应商) |  | 1d? | 2007-01-31 | 2007-02-01 | 43 | 0d |  | 培训负责人 | 8h |
| 45 | 4.1.6 | 拟定内容开发预算 |  | 1d? | 2007-02-01 | 2007-02-02 | 44 | 0d |  | 培训负责人 | 8h |
| 46 | 4.1.7 | 最终确定内容开发计划 |  | 1d? | 2007-02-02 | 2007-02-05 | 45 | 0d |  | 培训负责人; 内容开发人员 | 16h |
| 47 | 4.1.8 | 完成内容开发规划 | milestone | 0d | 2007-02-05 | 2007-02-05 | 46 | 0d |  |  |  |
| 48 | 4.2 | **培训提供规划** |  | 9d? | 2007-02-05 | 2007-02-16 |  | 0d |  |  | 108h |
| 49 | 4.2.1 | **培训提供后勤** |  | 4d? | 2007-02-05 | 2007-02-09 |  | 4d |  |  | 32h |
| 50 | 4.2.1.1 | 确定培训提供日程 |  | 1d? | 2007-02-05 | 2007-02-06 | 47 | 4d | 0d | 培训负责人 | 8h |
| 51 | 4.2.1.2 | 确定培训提供地点 |  | 1d? | 2007-02-06 | 2007-02-07 | 50 | 4d | 0d | 培训负责人 | 8h |
| 52 | 4.2.1.3 | 审核外包选项 - 事件后勤 |  | 1d? | 2007-02-07 | 2007-02-08 | 51 | 4d | 0d | 培训负责人 | 8h |
| 53 | 4.2.1.4 | 编制培训提供预算 |  | 1d? | 2007-02-08 | 2007-02-09 | 52 | 4d | 0d | 培训负责人 | 8h |
| 54 | 4.2.1.5 | 完成培训后勤规划 | milestone | 0d | 2007-02-09 | 2007-02-09 | 53 | 4d |  |  |  |

Notes:
- 33: 此决定应从多个角度收集反馈。 / 提供上次内容的讲师 / 以前受训学员的样本 / 为其成员提供培训的组织或团体(培训对他们是否明显有益?) / 以前的培训主办方(听取他们对以前培训的有效性的意见)

| ID | WBS | Task | Type | Duration | Start | Finish | Predecessors | Total slack | Resources | Work |
| --- | --- | --- | --- | --- | --- | --- | --- | --- | --- | --- |
| 55 | 4.2.2 | **评估讲师需求和选项** |  | 8d? | 2007-02-05 | 2007-02-15 |  | 0d |  | 64h |
| 56 | 4.2.2.1 | 确定可作为备选讲师的内部资源 |  | 1d? | 2007-02-05 | 2007-02-06 | 47 | 0d | 培训负责人 | 8h |
| 57 | 4.2.2.2 | 确定是否需要其他讲师 |  | 1d? | 2007-02-06 | 2007-02-07 | 56 | 0d | 培训负责人 | 8h |
| 58 | 4.2.2.3 | **审核外包选项 - 培训提供** |  | 6d? | 2007-02-07 | 2007-02-15 |  | 0d |  | 48h |
| 59 | 4.2.2.3.1 | 审核潜在供应商的专业技能 |  | 1d? | 2007-02-07 | 2007-02-08 | 57 | 0d | 培训负责人 | 8h |
| 60 | 4.2.2.3.2 | 审核成本 |  | 1d? | 2007-02-08 | 2007-02-09 | 59 | 0d | 培训负责人 | 8h |
| 61 | 4.2.2.3.3 | 审核服务级别 |  | 1d? | 2007-02-09 | 2007-02-12 | 60 | 0d | 培训负责人 | 8h |
| 62 | 4.2.2.3.4 | 审核客户参考信息 |  | 1d? | 2007-02-12 | 2007-02-13 | 61 | 0d | 培训负责人 | 8h |
| 63 | 4.2.2.3.5 | 确定外部讲师到位所需时间 |  | 1d? | 2007-02-13 | 2007-02-14 | 62 | 0d | 培训负责人 | 8h |
| 64 | 4.2.2.3.6 | 进行外包决策 |  | 1d? | 2007-02-14 | 2007-02-15 | 63 | 0d | 培训负责人 | 8h |
| 65 | 4.2.2.3.7 | 完成外包审核 | milestone | 0d | 2007-02-15 | 2007-02-15 | 64 | 0d |  |  |
| 66 | 4.2.2.4 | 完成讲师需求评估 | milestone | 0d | 2007-02-15 | 2007-02-15 | 65 | 0d |  |  |
| 67 | 4.2.3 | 利用内容开发和培训提供阶段的结果，创建培训计划 |  | 1d? | 2007-02-15 | 2007-02-16 | 47, 54, 66 | 0d | 培训负责人; 指导设计师; 内容开发人员 | 12h |
| 68 | 4.2.4 | 完成培训提供规划 | milestone | 0d | 2007-02-16 | 2007-02-16 | 67 | 0d |  |  |
| 69 | 4.3 | **最终确定培训规划** |  | 3d? | 2007-02-16 | 2007-02-21 |  | 0d |  | 24h |
| 70 | 4.3.1 | 拟定总体预算 |  | 1d? | 2007-02-16 | 2007-02-19 | 68 | 0d | 培训负责人 | 8h |
| 71 | 4.3.2 | 获得管理层对预算的签字认可 |  | 1d? | 2007-02-19 | 2007-02-20 | 70 | 0d | 培训负责人 | 8h |
| 72 | 4.3.3 | 获得管理层对培训计划的签字认可 |  | 1d? | 2007-02-20 | 2007-02-21 | 71 | 0d | 培训负责人 | 8h |
| 73 | 4.3.4 | 完成培训规划 | milestone | 0d | 2007-02-21 | 2007-02-21 | 72 | 0d |  |  |
| 74 | 5 | **开展培训/入职准备** |  | 13d? | 2007-02-21 | 2007-03-12 |  | 0d |  | 196h |
| 75 | 5.1 | **开发培训内容** |  | 9d? | 2007-02-21 | 2007-03-06 |  | 0d |  | 96h |
| 76 | 5.1.1 | 组建内容开发工作组 |  | 1d? | 2007-02-21 | 2007-02-22 | 73 | 0d | 培训负责人 | 8h |
| 77 | 5.1.2 | 确定角色和职责 |  | 1d? | 2007-02-22 | 2007-02-23 | 76 | 0d | 培训负责人 | 8h |
| 78 | 5.1.3 | 确定内容开发日程 |  | 1d? | 2007-02-23 | 2007-02-26 | 77 | 0d | 培训负责人; 内容开发人员 | 16h |

| ID | WBS | Task | Type | Duration | Start | Finish | Predecessors | Total slack | Free slack | Resources | Work |
| --- | --- | --- | --- | --- | --- | --- | --- | --- | --- | --- | --- |
| 79 | 5.1.4 | **确定培训内容** |  | 6d? | 2007-02-26 | 2007-03-06 |  | 0d |  |  | 64h |
| 80 | 5.1.4.1 | 开发测试版内容 |  | 1d? | 2007-02-26 | 2007-02-27 | 78 | 0d |  | 内容开发人员 | 8h |
| 81 | 5.1.4.2 | 对测试版内容起先主题专家(SME)审核 |  | 1d? | 2007-02-27 | 2007-02-28 | 80 | 0d |  | 主题专家(SME); 内容开发人员 | 16h |
| 82 | 5.1.4.3 | 修订并更新内容 |  | 1d? | 2007-02-28 | 2007-03-01 | 81 | 0d |  | 内容开发人员 | 8h |
| 83 | 5.1.4.4 | 创建其他“讲师培训”学习材料 |  | 1d? | 2007-03-01 | 2007-03-02 | 82 | 1.5d | 0d | 内容开发人员 | 8h |
| 84 | 5.1.4.5 | 确定能力考试内容 |  | 1d? | 2007-03-02 | 2007-03-05 | 83 | 1.5d | 0d | 内容开发人员 | 8h |
| 85 | 5.1.4.6 | 获得最终内容批准 |  | 1d? | 2007-03-05 | 2007-03-06 | 84 | 1.5d | 0d | 培训负责人; 内容开发人员 | 16h |
| 86 | 5.1.5 | 完成内容开发 | milestone | 0d | 2007-03-06 | 2007-03-06 | 85 | 1.5d | 0d |  |  |
| 87 | 5.2 | **开发培训提供引擎** |  | 7d? | 2007-03-01 | 2007-03-12 |  | 0d |  |  | 100h |
| 88 | 5.2.1 | **制定传播计划** |  | 5d? | 2007-03-01 | 2007-03-08 |  | 0d |  |  | 40h |
| 89 | 5.2.1.1 | 创建阐明价值主张的培训课程的大纲 |  | 1d? | 2007-03-01 | 2007-03-02 | 82 | 0d |  | 指导设计师 | 8h |
| 90 | 5.2.1.2 | 向销售团队传达培训方案 |  | 1d? | 2007-03-02 | 2007-03-05 | 89 | 0d |  | 培训负责人 | 8h |
| 91 | 5.2.1.3 | 最终确定培训日程 |  | 1d? | 2007-03-05 | 2007-03-06 | 90 | 0d |  | 培训负责人 | 8h |
| 92 | 5.2.1.4 | 确定员工注册课程的方法 |  | 1d? | 2007-03-06 | 2007-03-07 | 91 | 0d |  | 指导设计师 | 8h |
| 93 | 5.2.1.5 | 传达培训日程 |  | 1d? | 2007-03-07 | 2007-03-08 | 92 | 0d |  | 培训负责人 | 8h |
| 94 | 5.2.1.6 | 完成传播计划制定工作 | milestone | 0d | 2007-03-08 | 2007-03-08 | 93 | 0d |  |  |  |
| 95 | 5.2.2 | **准备培训提供** |  | 4d? | 2007-03-06 | 2007-03-12 |  | 0d |  |  | 60h |
| 96 | 5.2.2.1 | **完成入职准备的讲师** |  | 2.5d? | 2007-03-06 | 2007-03-08 |  | 1.5d |  |  | 28h |
| 97 | 5.2.2.1.1 | 完成入职准备的初始讲师组 |  | 1d? | 2007-03-06 | 2007-03-07 | 86 | 1.5d | 0d | 培训负责人; 指导设计师; 讲师 | 12h |
| 98 | 5.2.2.1.2 | 培训其他讲师 |  | 0.5d? | 2007-03-07 | 2007-03-07 | 97 | 1.5d | 0d | 指导设计师; 讲师 | 8h |
| 99 | 5.2.2.1.3 | 安排讲师参加能力考试 |  | 1d? | 2007-03-07 | 2007-03-08 | 98 | 1.5d | 0d | 讲师 | 8h |
| 100 | 5.2.2.1.4 | 完成讲师入职准备 | milestone | 0d | 2007-03-08 | 2007-03-08 | 99 | 1.5d |  |  |  |
| 101 | 5.2.2.2 | 约定后勤供应商 |  | 1d? | 2007-03-08 | 2007-03-09 | 94 | 0d |  | 培训负责人; 后勤供应商 | 16h |
| 102 | 5.2.2.3 | 制作员工培训材料 |  | 1d? | 2007-03-08 | 2007-03-09 | 86, 94 | 0d |  | 后勤供应商 | 8h |
| 103 | 5.2.2.4 | 准备培训场地 |  | 1d? | 2007-03-09 | 2007-03-12 | 101, 102 | 0d |  | 后勤供应商 | 8h |
| 104 | 5.2.3 | 完成培训提供引擎开发 | milestone | 0d | 2007-03-12 | 2007-03-12 | 94, 103, 100 | 0d |  |  |  |
| 105 | 5.3 | 完成培训/入职准备开展工作 | milestone | 0d | 2007-03-12 | 2007-03-12 | 104 | 0d |  |  |  |
| 106 | 6 | 完成内部入职准备方案制定工作 | milestone | 0d | 2007-03-12 | 2007-03-12 | 105 | 0d |  |  |  |
