# 制定技能需求 – 雇用计划 – 雇用前景

Schedule from MS Project, 2007-01-01 to 2007-03-05.
有远见的公司会定期对将来预计要完成的工作所需的技能，及其内部资源已经拥有的技能进行分析。公司一旦对所需技能和可用技能进行了差距分析之后，即可确定培训计划和(或)远期雇用需求，并按照时间表对这些活动进行调整。从人力资源部门的角度来说，此模板可以为以下常规活动提供一个框架: 对预测技能需求以及弥补差距所必需的潜在雇用计划和(或)培训计划进行分析。

## Calendars

- 标准: Mon-Fri 08:00-12:00, 13:00-17:00; Sat-Sun off.

## Resources

| Resource |
| --- |
| 行政管理人员 |
| 产品线管理人员 |
| 人力资源 |
| 信息服务 |

## Schedule

| ID | WBS | Task | Type | Duration | Start | Finish | Predecessors | Total slack | Free slack | Resources | Work |
| --- | --- | --- | --- | --- | --- | --- | --- | --- | --- | --- | --- |
| 1 | 1 | **技能需求评估阶段** |  | 25d? | 2007-01-01 | 2007-02-02 |  | 12d |  |  | 480h |
| 2 | 1.1 | 确定/确认工作类别 |  | 5d? | 2007-01-01 | 2007-01-05 |  | 12d | 0d | 人力资源 | 40h |
| 3 | 1.2 | 确定/确认类别中的工作层次结构 |  | 5d? | 2007-01-01 | 2007-01-05 | 2SS | 12d | 0d | 人力资源 | 40h |
| 4 | 1.3 | 制定技能分类 |  | 5d? | 2007-01-08 | 2007-01-12 | 3 | 12d | 0d | 产品线管理人员; 人力资源 | 80h |
| 5 | 1.4 | 制定技能和资格列表 |  | 10d? | 2007-01-08 | 2007-01-19 | 4SS | 12d | 0d | 产品线管理人员; 人力资源 | 160h |
| 6 | 1.5 | 将技能、技能要求和最低资格级别体现到工作中 |  | 10d? | 2007-01-22 | 2007-02-02 | 5, 4 | 12d | 0d | 产品线管理人员; 人力资源 | 160h |
| 7 | 1.6 | 完成技能需求评估阶段 | milestone | 0d | 2007-02-02 | 2007-02-02 | 6 | 12d | 0d |  |  |
| 8 | 2 | **组织需求评估阶段** |  | 34d? | 2007-01-01 | 2007-02-15 |  | 0d |  |  | 328h |
| 9 | 2.1 | **制定信息收集调查** |  | 6d? | 2007-02-05 | 2007-02-12 |  | 12d |  |  | 48h |
| 10 | 2.1.1 | 确定工作调查项目 |  | 1d? | 2007-02-05 | 2007-02-05 | 7 | 12d | 0d | 人力资源 | 8h |
| 11 | 2.1.2 | 确定技能调查对应项目 |  | 1d? | 2007-02-06 | 2007-02-06 | 10 | 12d | 0d | 人力资源 | 8h |
| 12 | 2.1.3 | 确定收集输入的形式/要求 |  | 1d? | 2007-02-07 | 2007-02-07 | 11 | 12d | 0d | 人力资源 | 8h |
| 13 | 2.1.4 | 确定收集输入的要求 |  | 1d? | 2007-02-08 | 2007-02-08 | 12 | 12d | 0d | 人力资源 | 8h |
| 14 | 2.1.5 | 确定报告要求 |  | 1d? | 2007-02-09 | 2007-02-09 | 13 | 12d | 0d | 人力资源 | 8h |
| 15 | 2.1.6 | 最终确定调查形式、收集方式以及报告方案和系统 |  | 1d? | 2007-02-12 | 2007-02-12 | 14 | 12d | 0d | 人力资源 | 8h |
| 16 | 2.2 | **收集组织层次结构信息** |  | 3d? | 2007-02-13 | 2007-02-15 |  | 12d |  |  | 96h |
| 17 | 2.2.1 | 确定和收集在收集信息和分发调查时所需的 HRIS 信息 |  | 3d? | 2007-02-13 | 2007-02-15 | 15 | 12d | 0d | 人力资源; 信息服务 | 48h |
| 18 | 2.2.2 | 制定调查分发要求和过程 |  | 3d? | 2007-02-13 | 2007-02-15 | 17SS | 12d |  | 人力资源; 信息服务 | 48h |
| 19 | 2.3 | **制定适用于管理人员的调查交流** |  | 6d? | 2007-01-01 | 2007-01-08 |  | 0d |  |  | 56h |
| 20 | 2.3.1 | 制定交付前、交付、提醒和交付后交流(例如，备忘录、电子邮件和 Web 广播) |  | 5d? | 2007-01-01 | 2007-01-05 |  | 0d |  | 人力资源 | 40h |
| 21 | 2.3.2 | 获取管理人员对于调查内容、方法和交流的批准 |  | 1d? | 2007-01-08 | 2007-01-08 | 20 | 0d |  | 行政管理人员; 人力资源 | 16h |
| 22 | 2.4 | **将调查分发给管理人员并收集结果** |  | 16d? | 2007-01-09 | 2007-01-30 |  | 0d |  |  | 128h |
| 23 | 2.4.1 | 发送调查前交流消息/说明 |  | 1d? | 2007-01-09 | 2007-01-09 | 21 | 0d |  | 人力资源 | 8h |
| 24 | 2.4.2 | 分发和收集调查 |  | 10d? | 2007-01-10 | 2007-01-23 | 23 | 0d |  | 人力资源 | 80h |
| 25 | 2.4.3 | 吸收和审计调查结果 |  | 5d? | 2007-01-24 | 2007-01-30 | 24 | 0d |  | 人力资源 | 40h |
| 26 | 2.5 | 完成组织需求评估阶段 | milestone | 0d | 2007-01-30 | 2007-01-30 | 25 | 0d |  |  |  |

Notes:
- 4: 技能类别可以为技术类、行为科学/社会科学类和/或管理类
- 5: 资格定义每项技能的熟练程度
- 6: 此映射定义执行此工作所需的最低技能级别。
- 9: 调查的目标是收集有关组织的运作区域的技能和资源需求的信息

| ID | WBS | Task | Type | Duration | Start | Finish | Predecessors | Total slack | Resources | Work |
| --- | --- | --- | --- | --- | --- | --- | --- | --- | --- | --- |
| 27 | 3 | **雇用预测、培训和实施计划阶段** |  | 24d? | 2007-01-31 | 2007-03-05 |  | 0d |  | 216h |
| 28 | 3.1 | **准备管理报告和建议)** |  | 13d? | 2007-01-31 | 2007-02-16 |  | 0d |  | 120h |
| 29 | 3.1.1 | 准备组织技能差距报告 |  | 5d? | 2007-01-31 | 2007-02-06 | 26 | 0d | 人力资源 | 40h |
| 30 | 3.1.2 | 准备培训差距报告 |  | 5d? | 2007-01-31 | 2007-02-06 | 29SS | 0d | 人力资源 | 40h |
| 31 | 3.1.3 | 准备雇用方案和技能要求预测报告 |  | 5d? | 2007-02-07 | 2007-02-13 | 29, 30 | 0d | 人力资源 | 40h |
| 32 | 3.1.4 | 准备建议 |  | 3d? | 2007-02-14 | 2007-02-16 | 31 | 0d |  |  |
| 33 | 3.2 | **管理人员演示文稿和实施规划** |  | 11d? | 2007-02-19 | 2007-03-05 |  | 0d |  | 96h |
| 34 | 3.2.1 | 制定实施方案和预算评估 |  | 3d? | 2007-02-19 | 2007-02-21 | 32 | 0d | 人力资源 | 24h |
| 35 | 3.2.2 | 制定行政管理人员演示文稿 |  | 2d? | 2007-02-22 | 2007-02-23 | 34 | 0d | 人力资源 | 16h |
| 36 | 3.2.3 | 向行政管理人员演示 |  | 1d? | 2007-02-26 | 2007-02-26 | 35 | 0d | 行政管理人员; 人力资源 | 16h |
| 37 | 3.2.4 | 最终确定培训、雇用和实施计划 |  | 5d? | 2007-02-27 | 2007-03-05 | 36 | 0d | 人力资源 | 40h |
| 38 | 3.3 | 完成雇用预测和培训计划 | milestone | 0d | 2007-03-05 | 2007-03-05 | 37 | 0d |  |  |

Notes:
- 29: 技能差距报告将需要的技能需求与员工的实际技能进行比较。差距可以通过培训现有员工和/或雇用更多员工来弥补。
