# 制造后客户服务规划

Schedule from MS Project, 2005-11-19 to 2005-12-20.

## Calendars

- 标准: Mon-Fri 08:00-12:00, 13:00-17:00; Sat-Sun off.

## Resources

| Resource |
| --- |
| 客户服务工作组 |
| 客户服务负责人 |
| 产品经理 |
| 内容开发人员 |
| 讲师 |
| 法律人员 |

## Schedule

| ID | WBS | Task | Type | Duration | Start | Finish | Predecessors | Total slack | Resources | Work |
| --- | --- | --- | --- | --- | --- | --- | --- | --- | --- | --- |
| 1 | 1 | 阅读说明此模板用途的注释 | milestone | 0d | 2005-11-19 | 2005-11-19 |  | 0d |  |  |
| 2 | 2 | **确定服务提供要求** |  | 2d? | 2005-11-21 | 2005-11-22 |  | 0d |  | 40h |
| 3 | 2.1 | 确定产品保修法律要求 |  | 0.5d? | 2005-11-21 | 2005-11-21 | 1 | 0.5d | 客户服务工作组; 法律人员 | 8h |
| 4 | 2.2 | 确定典型产品使用环境 |  | 1d? | 2005-11-21 | 2005-11-21 | 1 | 0d | 客户服务工作组 | 8h |
| 5 | 2.3 | 确定预期产品问题点 |  | 1d? | 2005-11-21 | 2005-11-21 | 1 | 0d | 客户服务工作组 | 8h |
| 6 | 2.4 | 确定客户服务联系方案 |  | 1d? | 2005-11-21 | 2005-11-21 | 1 | 0d | 客户服务工作组 | 8h |
| 7 | 2.5 | 结果编档 |  | 1d? | 2005-11-22 | 2005-11-22 | 3, 4, 5, 6 | 0d | 客户服务工作组 | 8h |
| 8 | 2.6 | 完成服务提供审核 | milestone | 0d | 2005-11-22 | 2005-11-22 | 7 | 0d |  |  |
| 9 | 3 | **业绩规划** |  | 1.5d? | 2005-11-23 | 2005-11-24 |  | 0d |  | 24h |
| 10 | 3.1 | 确定支持服务的业务目标 |  | 0.5d? | 2005-11-23 | 2005-11-23 | 8 | 0d | 客户服务负责人; 产品经理 | 8h |
| 11 | 3.2 | 确定成功标准 |  | 0.5d? | 2005-11-23 | 2005-11-23 | 10 | 0d | 客户服务工作组; 产品经理 | 8h |
| 12 | 3.3 | 确定成本效率标准 |  | 0.5d? | 2005-11-24 | 2005-11-24 | 11 | 0d | 客户服务负责人; 产品经理 | 8h |
| 13 | 3.4 | 完成业绩规划 | milestone | 0d | 2005-11-24 | 2005-11-24 | 12 | 0d |  |  |
| 14 | 4 | **建立持续改进流程(CIP)** |  | 3d? | 2005-11-24 | 2005-11-29 |  | 0d |  | 24h |
| 15 | 4.1 | 确定常见问题跟踪方法和解决方案 |  | 1d? | 2005-11-24 | 2005-11-25 | 13 | 0d | 客户服务工作组 | 8h |
| 16 | 4.2 | 确定支持问题与产品方面的跟踪方法 |  | 1d? | 2005-11-25 | 2005-11-28 | 15 | 0d | 客户服务工作组 | 8h |
| 17 | 4.3 | 确定向所有支持资源分发常用解决方案的方法 |  | 1d? | 2005-11-28 | 2005-11-29 | 16 | 0d | 客户服务工作组 | 8h |
| 18 | 4.4 | 完成 CIP 准备工作 | milestone | 0d | 2005-11-29 | 2005-11-29 | 17 | 0d |  |  |
| 19 | 5 | **内部支持服务规划(如果由制造商提供支持)** |  | 9d? | 2005-11-24 | 2005-12-07 |  | 1d |  | 104h |
| 20 | 5.1 | **资源需求** |  | 3d? | 2005-11-29 | 2005-12-02 |  | 0d |  | 24h |
| 21 | 5.1.1 | 评估客户支持需求 |  | 1d? | 2005-11-29 | 2005-11-30 | 18 | 0d | 客户服务负责人 | 8h |
| 22 | 5.1.2 | 估计资源需求 |  | 1d? | 2005-11-30 | 2005-12-01 | 21 | 0d | 客户服务负责人 | 8h |
| 23 | 5.1.3 | 估计雇用新员工的工作 |  | 1d? | 2005-12-01 | 2005-12-02 | 22 | 0d | 客户服务负责人 | 8h |
| 24 | 5.1.4 | 完成资源规划 | milestone | 0d | 2005-12-02 | 2005-12-02 | 23 | 0d |  |  |
| 25 | 5.1.5 | 完成服务提供规划 | milestone | 0d | 2005-12-02 | 2005-12-02 | 24 | 0d |  |  |

Notes:
- 1: 此模板可用于确定建立对新消费类包装商品的支持所需的工作。消费类包装商品(CPG)是可消耗的商品，如食品和饮料、鞋类和服装、烟草以及清洁用品。通常情况下，与人们一般长期使用的产品(如汽车和家具)相比，CPG 是易耗品，需要经常更换。 / 不管是哪种产品，都必须考虑提供的保修类型，以及为消费者提供服务的方法。制造后服务可以完全由制造公司来管理，可以外包给第三方维修公司，可以由零售组织管理，也可以是以上方式的组合。通常情况下，所有产品都保证产品在一般意义上适用。CPG 的利润通常很低，因此制造商和零售商都尽可能将服务成本降至最低限度。此模板应提供建立制造后服务所需的基本步骤。
- 2: 服务通常可分为两类: 针对产品的使用和安装的培训服务以及保修和替换。服务的规模和范围取决于产品类型。 / 就第一种类别而言，要求掌握产品(例如个人电脑)的使用技术知识。制造商应考虑其是否提供此项服务，也可能会要求零售商或第三方来提供此项服务。大多数情况下，这些服务由零售商或第三方服务公司作为额外的竞争性产品服务项目来提供，而通常不会由制造商来提供。 / 但是人们期望 - 并且通常是要求 - 制造商能够提供保修服务。在这种情况下，制造商可以直接提供此项服务，也可以与零售商或第三方签订合同，为其提供产品服务。

| ID | WBS | Task | Type | Duration | Start | Finish | Predecessors | Total slack | Free slack | Resources | Work |
| --- | --- | --- | --- | --- | --- | --- | --- | --- | --- | --- | --- |
| 26 | 5.2 | **设计支持服务** |  | 3d? | 2005-12-02 | 2005-12-07 |  | 0d |  |  | 40h |
| 27 | 5.2.1 | **如果有保修服务** |  | 3d? | 2005-12-02 | 2005-12-07 |  | 0d |  |  | 24h |
| 28 | 5.2.1.1 | 制定退货/维修政策和程序(根据服务目标) |  | 1d? | 2005-12-02 | 2005-12-05 | 25 | 0d |  | 客户服务工作组 | 8h |
| 29 | 5.2.1.2 | 设计客户保修材料 |  | 1d? | 2005-12-05 | 2005-12-06 | 28 | 0d |  | 产品经理 | 8h |
| 30 | 5.2.1.3 | 确定并制定保修人员培训方案 |  | 1d? | 2005-12-06 | 2005-12-07 | 29 | 0d |  | 内容开发人员 | 8h |
| 31 | 5.2.2 | **如果是服务台服务** |  | 2d? | 2005-12-02 | 2005-12-06 |  | 1d |  |  | 16h |
| 32 | 5.2.2.1 | 确定各种支持选项所需的技能集 |  | 1d? | 2005-12-02 | 2005-12-05 | 25 | 1d | 0d | 客户服务工作组 | 8h |
| 33 | 5.2.2.2 | 确定并制定服务台培训方案 |  | 1d? | 2005-12-05 | 2005-12-06 | 32 | 1d |  | 内容开发人员 | 8h |
| 34 | 5.2.3 | 完成支持服务设计工作 | milestone | 0d | 2005-12-07 | 2005-12-07 | 30, 33 | 0d |  |  |  |
| 35 | 5.3 | 完成支持服务规划和设计 | milestone | 0d | 2005-12-07 | 2005-12-07 | 34 | 0d |  |  |  |
| 36 | 5.4 | **制定内部支持服务方案** |  | 4d? | 2005-11-24 | 2005-11-30 |  | 6d |  |  | 40h |
| 37 | 5.4.1 | 建立客户服务方案 |  | 1d? | 2005-11-24 | 2005-11-25 | 13 | 6d | 0d | 客户服务工作组 | 8h |
| 38 | 5.4.2 | 执行主题专家审核 |  | 1d? | 2005-11-25 | 2005-11-28 | 37 | 6d | 0d | 客户服务工作组 | 8h |
| 39 | 5.4.3 | 与客户一起进行用户验收测试 |  | 0.5d? | 2005-11-28 | 2005-11-28 | 38 | 6d | 0d | 客户服务工作组; 产品经理 | 8h |
| 40 | 5.4.4 | 修订方案和相关流程 |  | 1d? | 2005-11-29 | 2005-11-29 | 39 | 6d | 0d | 客户服务工作组 | 8h |
| 41 | 5.4.5 | 获得管理层签字认可 |  | 0.5d? | 2005-11-30 | 2005-11-30 | 40 | 6d | 0d | 客户服务负责人; 产品经理 | 8h |
| 42 | 5.4.6 | 完成内部客户服务方案制定工作 | milestone | 0d | 2005-11-30 | 2005-11-30 | 41 | 6d |  |  |  |
| 43 | 6 | **服务规划(如果由零售商提供支持)** |  | 1d? | 2005-12-07 | 2005-12-08 |  | 0d |  |  | 16h |
| 44 | 6.1 | 与零售商协商支持方案 |  | 1d? | 2005-12-07 | 2005-12-08 | 35 | 0d |  | 产品经理; 法律人员 | 16h |
| 45 | 7 | **服务规划(如果由第三方服务公司提供支持)** |  | 1d? | 2005-12-07 | 2005-12-08 |  | 0d |  |  | 16h |
| 46 | 7.1 | 与第三方服务公司协商支持方案 |  | 1d? | 2005-12-07 | 2005-12-08 | 35 | 0d |  | 产品经理; 法律人员 | 16h |
| 47 | 8 | **产品上市后** |  | 8.5d? | 2005-12-08 | 2005-12-20 |  | 0d |  |  | 72h |
| 48 | 8.1 | **部署方案** |  | 4d? | 2005-12-08 | 2005-12-14 |  | 0d |  |  | 32h |
| 49 | 8.1.1 | 部署新客户服务方案 |  | 1d? | 2005-12-08 | 2005-12-09 | 46, 44, 42 | 0d |  | 客户服务负责人 | 8h |

Notes:
- 30: 这是一个预备性任务，用于确定培训所需的其他工作。制定培训方案很复杂并且很重要，因此要求制定单独的计划。制定培训方案时可使用单独的模板。
- 33: 这是一项预备性任务，可用于确认培训所需的其他工作。制定培训方案很复杂，并且很重要，因此要求制定单独的计划。制定培训方案时可使用单独的模板。
- 43: 零售商(尤其是大型零售商)经常向客户提供退货方案和服务内容，以确立相对于竞争公司的特色。这些方案经常会超出制造商的保修要求，由零售商来支持和管理。 / 如果零售商的退货方案未超出制造商规定的范围，则制造商可以选择与零售商协商，让零售商代表他们来提供服务。
- 44: 这是一项预备性任务，可能需要单独的项目日程。根据支持的消费类商品的类型不同，任务也会有所不同。
- 45: 对于某些特定类型的消费类包装商品(主要是电器以及此类高端商品)而言，制造商与服务供应商协商服务合同，使服务供应商成为制造商的授权维修中心，这种方式最为有效。如果选择使用此种模式，则制造商还将希望创建一个服务级别协议，以确保第三方供应商遵循制造商的标准和要求。
- 46: 这是一项预备性任务，可能需要单独的项目日程。根据支持的消费类商品的类型不同，任务也会有所不同。

| ID | WBS | Task | Type | Duration | Start | Finish | Predecessors | Total slack | Resources | Work |
| --- | --- | --- | --- | --- | --- | --- | --- | --- | --- | --- |
| 50 | 8.1.2 | **员工入职准备** |  | 3d? | 2005-12-09 | 2005-12-14 |  | 0d |  | 24h |
| 51 | 8.1.2.1 | 雇用新员工 |  | 1d? | 2005-12-09 | 2005-12-12 | 49 | 0d | 客户服务负责人 | 8h |
| 52 | 8.1.2.2 | 培训新员工 |  | 1d? | 2005-12-12 | 2005-12-13 | 51 | 0d | 讲师 | 8h |
| 53 | 8.1.2.3 | 新员工合格测试 |  | 1d? | 2005-12-13 | 2005-12-14 | 52 | 0d | 客户服务负责人 | 8h |
| 54 | 8.1.2.4 | 完成员工入职准备培训 | milestone | 0d | 2005-12-14 | 2005-12-14 | 53 | 0d |  |  |
| 55 | 8.1.3 | 完成方案部署 | milestone | 0d | 2005-12-14 | 2005-12-14 | 54 | 0d |  |  |
| 56 | 8.2 | **监控** |  | 4.5d? | 2005-12-14 | 2005-12-20 |  | 0d |  | 40h |
| 57 | 8.2.1 | 监控客户支持问题 - 查找常见问题 |  | 1d? | 2005-12-14 | 2005-12-15 | 55 | 0d | 客户服务工作组 | 8h |
| 58 | 8.2.2 | 汇集最佳做法(解决方案) - 分发给支持服务部门 |  | 1d? | 2005-12-15 | 2005-12-16 | 57 | 0d | 客户服务工作组 | 8h |
| 59 | 8.2.3 | 审核支持数据，确定引发支持事件最多的产品方面 |  | 0.5d? | 2005-12-16 | 2005-12-16 | 58 | 0d | 客户服务工作组; 产品经理 | 8h |
| 60 | 8.2.4 | 审核资源表现，确定最有效的资源 |  | 1d? | 2005-12-19 | 2005-12-19 | 59 | 0d | 客户服务工作组 | 8h |
| 61 | 8.2.5 | 根据从客户服务方案收集到的数据修订培训材料 |  | 1d? | 2005-12-20 | 2005-12-20 | 60 | 0d | 内容开发人员 | 8h |
| 62 | 8.3 | 完成产品上市后活动 | milestone | 0d | 2005-12-20 | 2005-12-20 | 61 | 0d |  |  |
| 63 | 9 | 完成客户服务方案制定工作 | milestone | 0d | 2005-12-20 | 2005-12-20 | 62 | 0d |  |  |
