# 外部技术入职培训

Schedule from MS Project, 2007-01-01 to 2007-02-28.

## Calendars

- 标准: Mon-Fri 08:00-12:00, 13:00-17:00; Sat-Sun off.

## Resources

| Resource |
| --- |
| 培训负责人 |
| 指导设计师 |
| 主题专家(SME) |
| 内容开发人员 |
| 讲师 |
| 后勤供应商 |

## Schedule

| ID | WBS | Task | Type | Duration | Start | Finish | Predecessors | Total slack | Free slack | Resources | Work |
| --- | --- | --- | --- | --- | --- | --- | --- | --- | --- | --- | --- |
| 1 | 1 | 阅读说明此模板用途的注释 | milestone | 0d | 2007-01-01 | 2007-01-01 |  | 0d |  |  |  |
| 2 | 2 | 组建进行分析和课程设计及生产的工作组 |  | 1d? | 2007-01-01 | 2007-01-01 | 1 | 0d |  | 培训负责人 | 8h |
| 3 | 3 | **需求评估** |  | 18d? | 2007-01-02 | 2007-01-25 |  | 0d |  |  | 272h |
| 4 | 3.1 | **产品审核** |  | 2d? | 2007-01-02 | 2007-01-03 |  | 4d |  |  | 56h |
| 5 | 3.1.1 | 确定需要培训内容的产品方面和功能 |  | 1d? | 2007-01-02 | 2007-01-02 | 2 | 4d | 0d | 指导设计师; 主题专家(SME) | 16h |
| 6 | 3.1.2 | 确定典型产品使用环境 |  | 1d? | 2007-01-02 | 2007-01-02 | 2 | 4d | 0d | 指导设计师; 主题专家(SME) | 16h |
| 7 | 3.1.3 | 审核测试版测试中遇到的常见问题 |  | 1d? | 2007-01-02 | 2007-01-02 | 2 | 4d | 0d | 指导设计师; 主题专家(SME) | 16h |
| 8 | 3.1.4 | 结果编档: 创建需要培训内容的主题列表 |  | 1d? | 2007-01-03 | 2007-01-03 | 5, 6, 7 | 4d | 0d | 指导设计师 | 8h |
| 9 | 3.1.5 | 完成产品审核 | milestone | 0d | 2007-01-03 | 2007-01-03 | 8 | 4d |  |  |  |
| 10 | 3.2 | **培训内容审核** |  | 6d? | 2007-01-02 | 2007-01-09 |  | 0d |  |  | 48h |
| 11 | 3.2.1 | 确定缺少培训材料的产品功能和方面 |  | 1d? | 2007-01-02 | 2007-01-02 | 2 | 0d |  | 指导设计师 | 8h |
| 12 | 3.2.2 | 确定需要大量支持的产品领域 |  | 1d? | 2007-01-03 | 2007-01-03 | 11 | 0d |  | 指导设计师 | 8h |
| 13 | 3.2.3 | 审核当前培训材料中的缺陷 |  | 1d? | 2007-01-04 | 2007-01-04 | 12 | 0d |  | 指导设计师 | 8h |
| 14 | 3.2.4 | 审核内容作者对培训材料的反馈 |  | 1d? | 2007-01-05 | 2007-01-05 | 13 | 0d |  | 指导设计师 | 8h |
| 15 | 3.2.5 | 确定可用于新培训的现有培训材料 |  | 1d? | 2007-01-08 | 2007-01-08 | 14 | 0d |  | 指导设计师 | 8h |
| 16 | 3.2.6 | 结果编档: 创建需求缺口和现有可用材料列表 |  | 1d? | 2007-01-09 | 2007-01-09 | 15 | 0d |  | 指导设计师 | 8h |
| 17 | 3.2.7 | 完成培训材料审核 | milestone | 0d | 2007-01-09 | 2007-01-09 | 16 | 0d |  |  |  |
| 18 | 3.3 | **现有培训提供方案审核** |  | 5d? | 2007-01-02 | 2007-01-08 |  | 1d |  |  | 40h |
| 19 | 3.3.1 | 审核现有培训提供方法 |  | 1d? | 2007-01-02 | 2007-01-02 | 2 | 1d | 0d | 指导设计师 | 8h |
| 20 | 3.3.2 | 确定最有效的方法 |  | 1d? | 2007-01-03 | 2007-01-03 | 19 | 1d | 0d | 指导设计师 | 8h |
| 21 | 3.3.3 | 审核以前培训方案开展过程中遇到的问题 |  | 1d? | 2007-01-04 | 2007-01-04 | 20 | 1d | 0d | 指导设计师 | 8h |
| 22 | 3.3.4 | 审核讲师对培训方案的反馈 |  | 1d? | 2007-01-05 | 2007-01-05 | 21 | 1d | 0d | 指导设计师 | 8h |
| 23 | 3.3.5 | 培训方案审核结果编档 |  | 1d? | 2007-01-08 | 2007-01-08 | 22 | 1d | 0d | 指导设计师 | 8h |
| 24 | 3.3.6 | 完成培训提供方案审核 | milestone | 0d | 2007-01-08 | 2007-01-08 | 23 | 1d |  |  |  |

Notes:
- 1: 此模板的用途是涵盖部署外部培训方案时的计划，其中包含评估需求、制作材料和内容、生成需求以及执行活动。
- 2: 此工作组应包含指导设计师和主题专家。请为该工作组确定角色和职责。
- 4: 审核产品以了解其功能和概念，并将这些内容输入培训内容审核。
- 5: 如果此产品版本适用于现有产品，请确保识别与早期版本的不同之处，并在培训中重点讲解这些更改。
- 10: 审核了产品后，了解培训材料的缺口，以及现有材料中可用于制作新培训材料的内容。
- 18: 审核当前培训提供方案和方法，确保在新培训中考虑以往的经验教训和更新后的方法。

| ID | WBS | Task | Type | Duration | Start | Finish | Predecessors | Total slack | Resources | Work |
| --- | --- | --- | --- | --- | --- | --- | --- | --- | --- | --- |
| 25 | 3.4 | **市场分析** |  | 8d? | 2007-01-10 | 2007-01-19 |  | 0d |  | 64h |
| 26 | 3.4.1 | 分析目标客户受众 |  | 1d? | 2007-01-10 | 2007-01-10 | 17, 24, 9 | 0d | 指导设计师 | 8h |
| 27 | 3.4.2 | 将客户要求的培训类型编档 |  | 1d? | 2007-01-11 | 2007-01-11 | 26 | 0d | 指导设计师 | 8h |
| 28 | 3.4.3 | 审核客户对当前培训材料的投诉 |  | 1d? | 2007-01-12 | 2007-01-12 | 27 | 0d | 指导设计师 | 8h |
| 29 | 3.4.4 | 审核客户对培训提供方案的反馈 |  | 1d? | 2007-01-15 | 2007-01-15 | 28 | 0d | 指导设计师 | 8h |
| 30 | 3.4.5 | 评估培训方案需求 |  | 1d? | 2007-01-16 | 2007-01-16 | 29 | 0d | 指导设计师 | 8h |
| 31 | 3.4.6 | 确定对目标受众最有效的培训方法 |  | 1d? | 2007-01-17 | 2007-01-17 | 30 | 0d | 指导设计师 | 8h |
| 32 | 3.4.7 | 确定对目标客户最有效的课程 |  | 1d? | 2007-01-18 | 2007-01-18 | 31 | 0d | 指导设计师 | 8h |
| 33 | 3.4.8 | 结果编档: 客户需要什么样的培训? |  | 1d? | 2007-01-19 | 2007-01-19 | 32 | 0d | 指导设计师 | 8h |
| 34 | 3.4.9 | 完成市场分析 | milestone | 0d | 2007-01-19 | 2007-01-19 | 33 | 0d |  |  |
| 35 | 3.5 | **提供培训需求建议** |  | 12d? | 2007-01-10 | 2007-01-25 |  | 0d |  | 64h |
| 36 | 3.5.1 | 采访产品经理，了解入职培训所需的关键必备知识 |  | 1d? | 2007-01-10 | 2007-01-10 | 17 | 7d | 指导设计师 | 8h |
| 37 | 3.5.2 | 审核以前的评估活动的结果 |  | 1d? | 2007-01-22 | 2007-01-22 | 34, 36 | 0d | 指导设计师 | 8h |
| 38 | 3.5.3 | 确定外部入职准备方案的业务目标 |  | 0.5d? | 2007-01-23 | 2007-01-23 | 37, 36 | 0d | 培训负责人; 指导设计师 | 8h |
| 39 | 3.5.4 | 获得对培训目标的批准 |  | 0.5d? | 2007-01-23 | 2007-01-23 | 38 | 0d | 培训负责人; 指导设计师 | 8h |
| 40 | 3.5.5 | 将培训目标、课程、内容及方法编档并进行展示 |  | 1d? | 2007-01-24 | 2007-01-24 | 39 | 0d | 培训负责人; 指导设计师 | 16h |
| 41 | 3.5.6 | 获得对建议的批准 |  | 1d? | 2007-01-25 | 2007-01-25 | 40 | 0d | 培训负责人; 指导设计师 | 16h |
| 42 | 3.5.7 | 完成培训提供建议 | milestone | 0d | 2007-01-25 | 2007-01-25 | 41 | 0d |  |  |
| 43 | 3.6 | 完成需求评估 | milestone | 0d | 2007-01-25 | 2007-01-25 | 42 | 0d |  |  |
| 44 | 4 | **内容和培训提供规划** |  | 13d? | 2007-01-26 | 2007-02-13 |  | 0d |  | 144h |
| 45 | 4.1 | **课程编制规划** |  | 6d? | 2007-01-26 | 2007-02-02 |  | 0d |  | 56h |
| 46 | 4.1.1 | 确定培训课程 |  | 1d? | 2007-01-26 | 2007-01-26 | 43 | 0d | 指导设计师 | 8h |
| 47 | 4.1.2 | 确定组成要素 - 学员内容/学习材料 |  | 1d? | 2007-01-29 | 2007-01-29 | 46 | 0d | 指导设计师 | 8h |
| 48 | 4.1.3 | 确定免费材料与付费材料 - 范围/大小 |  | 1d? | 2007-01-30 | 2007-01-30 | 47 | 0d | 指导设计师 | 8h |
| 49 | 4.1.4 | 确定内容开发人员(内部人员和外部供应商) |  | 1d? | 2007-01-31 | 2007-01-31 | 48 | 0d | 指导设计师 | 8h |
| 50 | 4.1.5 | 拟定内容开发预算 |  | 1d? | 2007-02-01 | 2007-02-01 | 49 | 0d | 指导设计师 | 8h |
| 51 | 4.1.6 | 最终确定内容开发计划 |  | 1d? | 2007-02-02 | 2007-02-02 | 50 | 0d | 培训负责人; 指导设计师 | 16h |
| 52 | 4.1.7 | 完成内容开发规划 | milestone | 0d | 2007-02-02 | 2007-02-02 | 51 | 0d |  |  |

Notes:
- 25: 确保将培训重点放在正确的市场，并了解该市场领域的培训问题和需求。审核该市场领域以前的培训，确保将客户反馈考虑在内。
- 31: 审核方法包括现场会议、演讲、基于 Web 且自定进度的审核、实践审核，以及以上各种方法的组合。
- 35: 完成了分析后，完成针对外部入职准备培训的推荐工作。
- 46: 包括班级和每个班级的简介、目标、课程目标、目标受众以及课时。

| ID | WBS | Task | Type | Duration | Start | Finish | Predecessors | Total slack | Free slack | Resources | Work |
| --- | --- | --- | --- | --- | --- | --- | --- | --- | --- | --- | --- |
| 53 | 4.2 | **培训提供规划** |  | 4d? | 2007-02-05 | 2007-02-08 |  | 0d |  |  | 64h |
| 54 | 4.2.1 | **培训提供后勤** |  | 3d? | 2007-02-05 | 2007-02-07 |  | 0d |  |  | 24h |
| 55 | 4.2.1.1 | 确定培训提供日程 |  | 1d? | 2007-02-05 | 2007-02-05 | 52 | 0d |  | 培训负责人 | 8h |
| 56 | 4.2.1.2 | 确定培训提供后勤 |  | 1d? | 2007-02-06 | 2007-02-06 | 55 | 0d |  | 培训负责人 | 8h |
| 57 | 4.2.1.3 | 编制培训提供预算 |  | 1d? | 2007-02-07 | 2007-02-07 | 56 | 0d |  | 培训负责人 | 8h |
| 58 | 4.2.1.4 | 完成培训后勤规划 | milestone | 0d | 2007-02-07 | 2007-02-07 | 57 | 0d |  |  |  |
| 59 | 4.2.2 | **评估讲师需求** |  | 3d? | 2007-02-05 | 2007-02-07 |  | 0d |  |  | 24h |
| 60 | 4.2.2.1 | 确定讲师必须具备的技能集 |  | 1d? | 2007-02-05 | 2007-02-05 | 52 | 0d |  | 指导设计师 | 8h |
| 61 | 4.2.2.2 | 确定讲师来源及选项 |  | 1d? | 2007-02-06 | 2007-02-06 | 60 | 0d |  | 培训负责人 | 8h |
| 62 | 4.2.2.3 | 确定讲师 |  | 1d? | 2007-02-07 | 2007-02-07 | 61 | 0d |  | 培训负责人 | 8h |
| 63 | 4.2.2.4 | 完成讲师需求评估 | milestone | 0d | 2007-02-07 | 2007-02-07 | 62 | 0d |  |  |  |
| 64 | 4.2.3 | 根据内容开发和培训提供阶段的结果，制定培训计划 |  | 1d? | 2007-02-08 | 2007-02-08 | 63, 58 | 0d |  | 培训负责人; 指导设计师 | 16h |
| 65 | 4.2.4 | 完成培训提供规划 | milestone | 0d | 2007-02-08 | 2007-02-08 | 64 | 0d |  |  |  |
| 66 | 4.3 | **最终确定培训规划** |  | 3d? | 2007-02-09 | 2007-02-13 |  | 0d |  |  | 24h |
| 67 | 4.3.1 | 拟定总体预算 |  | 1d? | 2007-02-09 | 2007-02-09 | 51, 65 | 0d |  | 培训负责人 | 8h |
| 68 | 4.3.2 | 获得管理层对预算的签字认可 |  | 1d? | 2007-02-12 | 2007-02-12 | 67 | 0d |  | 培训负责人 | 8h |
| 69 | 4.3.3 | 获得管理层对培训计划的签字认可 |  | 1d? | 2007-02-13 | 2007-02-13 | 68 | 0d |  | 培训负责人 | 8h |
| 70 | 4.3.4 | 完成培训规划 | milestone | 0d | 2007-02-13 | 2007-02-13 | 69 | 0d |  |  |  |
| 71 | 5 | **开展培训/入职准备** |  | 11d? | 2007-02-14 | 2007-02-28 |  | 0d |  |  | 184h |
| 72 | 5.1 | **开发培训内容** |  | 7d? | 2007-02-14 | 2007-02-22 |  | 2d |  |  | 68h |
| 73 | 5.1.1 | 确定内容开发日程 |  | 1d? | 2007-02-14 | 2007-02-14 | 70 | 2d | 0d | 培训负责人 | 8h |
| 74 | 5.1.2 | 开发测试版内容 |  | 1d? | 2007-02-15 | 2007-02-15 | 73 | 2d | 0d | 内容开发人员 | 8h |
| 75 | 5.1.3 | 执行测试版内容审核 |  | 1d? | 2007-02-16 | 2007-02-16 | 74 | 2d | 0d | 指导设计师; 主题专家(SME); 内容开发人员 | 12h |
| 76 | 5.1.4 | 修订并更新内容 |  | 1d? | 2007-02-19 | 2007-02-19 | 75 | 2d | 0d | 内容开发人员 | 8h |
| 77 | 5.1.5 | 创建其他“讲师培训”学习材料 |  | 1d? | 2007-02-20 | 2007-02-20 | 76 | 2d | 0d | 指导设计师; 内容开发人员 | 16h |
| 78 | 5.1.6 | 确定能力考试内容 |  | 1d? | 2007-02-21 | 2007-02-21 | 77 | 2d | 0d | 指导设计师 | 8h |
| 79 | 5.1.7 | 获得最终内容批准 |  | 1d? | 2007-02-22 | 2007-02-22 | 78 | 2d | 0d | 内容开发人员 | 8h |
| 80 | 5.1.8 | 完成内容开发 | milestone | 0d | 2007-02-22 | 2007-02-22 | 79 | 2d |  |  |  |

Notes:
- 56: 根据所选的课程培训方法，可能包含外包选项。
- 61: 这可能包括内部或外部讲师。对于外包项目，需要审核专家、成本、服务级别、客户参考资料以及外部讲师入职准备时间。

| ID | WBS | Task | Type | Duration | Start | Finish | Predecessors | Total slack | Free slack | Resources | Work |
| --- | --- | --- | --- | --- | --- | --- | --- | --- | --- | --- | --- |
| 81 | 5.2 | **开发培训提供引擎** |  | 11d? | 2007-02-14 | 2007-02-28 |  | 0d |  |  | 116h |
| 82 | 5.2.1 | **制定传播计划** |  | 9d? | 2007-02-14 | 2007-02-26 |  | 0d |  |  | 72h |
| 83 | 5.2.1.1 | 创建阐明价值主张的培训课程的大纲 |  | 1d? | 2007-02-14 | 2007-02-14 | 70 | 0d |  | 指导设计师 | 8h |
| 84 | 5.2.1.2 | 创建定位演示文稿 |  | 1d? | 2007-02-15 | 2007-02-15 | 83 | 0d |  | 培训负责人; 指导设计师 | 16h |
| 85 | 5.2.1.3 | 培训方案的内部资源简介 |  | 1d? | 2007-02-16 | 2007-02-16 | 84 | 0d |  | 培训负责人 | 8h |
| 86 | 5.2.1.4 | 培训方案外部成员和潜在学员简介 |  | 1d? | 2007-02-19 | 2007-02-19 | 85 | 0d |  | 培训负责人 | 8h |
| 87 | 5.2.1.5 | 向外部团队和内部团队传达培训方案 |  | 1d? | 2007-02-20 | 2007-02-20 | 86 | 0d |  | 培训负责人 | 8h |
| 88 | 5.2.1.6 | 最终确定培训日程 |  | 1d? | 2007-02-21 | 2007-02-21 | 87 | 0d |  | 培训负责人 | 8h |
| 89 | 5.2.1.7 | 确定学员注册课程的方法 |  | 1d? | 2007-02-22 | 2007-02-22 | 88 | 0d |  | 培训负责人 | 8h |
| 90 | 5.2.1.8 | 传达培训日程 |  | 1d? | 2007-02-23 | 2007-02-23 | 89 | 0d |  | 培训负责人 | 8h |
| 91 | 5.2.1.9 | 完成传播计划制定工作 |  | 1d? | 2007-02-26 | 2007-02-26 | 90 | 0d |  |  |  |
| 92 | 5.2.2 | **准备培训提供** |  | 3d? | 2007-02-26 | 2007-02-28 |  | 0d |  |  | 44h |
| 93 | 5.2.2.1 | 培训讲师 |  | 1d? | 2007-02-27 | 2007-02-27 | 80, 77, 91 | 0d |  | 培训负责人; 指导设计师; 讲师 | 12h |
| 94 | 5.2.2.2 | 安排讲师参加能力考试 |  | 1d? | 2007-02-28 | 2007-02-28 | 93 | 0d |  | 讲师 | 8h |
| 95 | 5.2.2.3 | 完成讲师入职准备 | milestone | 0d | 2007-02-28 | 2007-02-28 | 94 | 0d |  |  |  |
| 96 | 5.2.2.4 | 约定后勤供应商 |  | 1d? | 2007-02-26 | 2007-02-26 | 90 | 1d | 0d | 培训负责人 | 8h |
| 97 | 5.2.2.5 | 制作学员培训材料 |  | 1d? | 2007-02-27 | 2007-02-27 | 96, 80 | 1d |  | 培训负责人 | 8h |
| 98 | 5.2.2.6 | 准备培训场地或环境 |  | 1d? | 2007-02-27 | 2007-02-27 | 96 | 1d |  | 后勤供应商 | 8h |
| 99 | 5.2.3 | 完成培训提供引擎开发 | milestone | 0d | 2007-02-28 | 2007-02-28 | 98, 95 | 0d |  |  |  |
| 100 | 5.3 | 完成培训/入职准备开展工作 | milestone | 0d | 2007-02-28 | 2007-02-28 | 99 | 0d |  |  |  |
| 101 | 6 | 完成外部入职准备方案创建工作 | milestone | 0d | 2007-02-28 | 2007-02-28 | 100 | 0d |  |  |  |

Notes:
- 84: 包括销售培训方案价值主张这一用途。
