# 安全性基础架构改进计划

Schedule from MS Project, 2007-01-01 to 2007-01-19.

## Calendars

- 标准: Mon-Fri 08:00-12:00, 13:00-17:00; Sat-Sun off.

## Resources

| Resource |
| --- |
| 执行主持方 |
| IT 主持方 |

## Schedule

| ID | WBS | Task | Type | Duration | Start | Finish | Predecessors | Total slack | Free slack |
| --- | --- | --- | --- | --- | --- | --- | --- | --- | --- |
| 1 | 1 | 阅读说明此模板用途的注释 | milestone | 0d | 2007-01-01 | 2007-01-01 |  | 0d |  |
| 2 | 2 | 确定需求评估工作组 |  | 1d? | 2007-01-01 | 2007-01-01 | 1 | 0d |  |
| 3 | 3 | **执行需求评估** |  | 3d? | 2007-01-02 | 2007-01-04 |  | 0d |  |
| 4 | 3.1 | 执行以 IT 为中心的需求评估 |  | 1d? | 2007-01-02 | 2007-01-02 | 2 | 0d |  |
| 5 | 3.2 | 执行业务需求评估 |  | 1d? | 2007-01-02 | 2007-01-02 | 2 | 0d |  |
| 6 | 3.3 | 协调 IT 为中心的需求与业务需求 |  | 1d? | 2007-01-03 | 2007-01-03 | 4, 5 | 0d |  |
| 7 | 3.4 | 将协调后的需求和期限编档 |  | 1d? | 2007-01-04 | 2007-01-04 | 6 | 0d |  |
| 8 | 3.5 | 完成需求评估 | milestone | 0d | 2007-01-04 | 2007-01-04 | 7 | 11d |  |
| 9 | 4 | **执行解决方案领域评估** |  | 4d? | 2007-01-05 | 2007-01-10 |  | 0d |  |
| 10 | 4.1 | 评估当前的可用技术 |  | 1d? | 2007-01-05 | 2007-01-05 | 7 | 10d |  |
| 11 | 4.2 | **对于每项确定的技术…** |  | 2d? | 2007-01-05 | 2007-01-08 |  | 0d |  |
| 12 | 4.2.1 | 评估技术与当前基础设施的可集成度 |  | 1d? | 2007-01-05 | 2007-01-05 | 7 | 0d |  |
| 13 | 4.2.2 | 评估技术与当前企业战略的适应情况 |  | 1d? | 2007-01-08 | 2007-01-08 | 12 | 2d | 0d |
| 14 | 4.2.3 | 评估技术维护的复杂性 |  | 1d? | 2007-01-08 | 2007-01-08 | 12 | 2d | 0d |
| 15 | 4.2.4 | 评估技术灵活性 |  | 1d? | 2007-01-08 | 2007-01-08 | 12 | 2d | 0d |
| 16 | 4.2.5 | 评估与此技术相关的风险 |  | 1d? | 2007-01-08 | 2007-01-08 | 12 | 2d | 0d |
| 17 | 4.2.6 | 评估此技术所需的技能集 |  | 1d? | 2007-01-08 | 2007-01-08 | 12 | 2d | 0d |
| 18 | 4.2.7 | 评估此技术提供的价格点或价值 |  | 1d? | 2007-01-08 | 2007-01-08 | 12 | 2d | 0d |
| 19 | 4.2.8 | 评估在解决方案中实施此技术所需的时间 |  | 1d? | 2007-01-08 | 2007-01-08 | 12 | 2d | 0d |
| 20 | 4.3 | 时效性“技术”研究 | milestone | 0d | 2007-01-08 | 2007-01-08 | 12, 13, 14, 15, 16, 17, 18, 19 | 2d |  |
| 21 | 4.4 | **解决方案可能性(技术组合)** |  | 3d? | 2007-01-08 | 2007-01-10 |  | 0d |  |
| 22 | 4.4.1 | 评估解决方案与当前基础设施的可集成性 |  | 1d? | 2007-01-08 | 2007-01-08 | 12 | 0d |  |
| 23 | 4.4.2 | 评估解决方案与当前企业战略的适应情况 |  | 1d? | 2007-01-09 | 2007-01-09 | 22 | 0d |  |
| 24 | 4.4.3 | 评估解决方案维护的复杂性 |  | 1d? | 2007-01-09 | 2007-01-09 | 22 | 0d |  |
| 25 | 4.4.4 | 评估解决方案的灵活性 |  | 1d? | 2007-01-09 | 2007-01-09 | 22 | 0d |  |
| 26 | 4.4.5 | 评估与解决方案相关的风险 |  | 1d? | 2007-01-09 | 2007-01-09 | 22 | 0d |  |
| 27 | 4.4.6 | 评估每种解决方案所需的技能集 |  | 1d? | 2007-01-09 | 2007-01-09 | 22 | 0d |  |
| 28 | 4.4.7 | 评估每种解决方案提供的价格点或价值 |  | 1d? | 2007-01-09 | 2007-01-09 | 22 | 0d |  |
| 29 | 4.4.8 | 评估实施每种解决方案所需的时间 |  | 1d? | 2007-01-09 | 2007-01-09 | 22 | 8d |  |
| 30 | 4.4.9 | 评估解决方案分阶段和技术部署路线图 |  | 1d? | 2007-01-10 | 2007-01-10 | 22, 23, 24, 25, 26, 27, 28 | 0d |  |
| 31 | 4.5 | 时效性“解决方案部署” | milestone | 0d | 2007-01-10 | 2007-01-10 | 30 | 0d |  |

Notes:
- 1: 此模板提供了一种方法，用于确定、计划和执行基础架构改进措施。所选的一般主题是安全性基础架构，因为安全性涉及安全性需求与保持开展商业活动能力之间的平衡。但是，此方法可用于多种基础架构。 / 关于此计划的资源补充的说明: 我们有意不在计划中提及资源问题，因为根据基础架构活动的不同，资源与资源类型组合的情况也会有所不同。我们认为在每种活动中都配备IT 人员未必会有用。
- 3: 从以下角度完成需求评估: / 1) 原始安全性需求 / 2) 业务影响 / 必须随时牢记以上两点。如果将大量资金用于实施严密的安全性需求，但结果却严重阻碍人员完成工作(和获得收入)，那么这就没有任何意义了。必须根据综合需求确定一个平衡点。
- 4: 以下是收集原始安全性需求的工作 / 请回答如下问题: / 客户要求我提供什么级别安全性 / 我拥有哪些信息? 这些信息对公司的敏感程度如何? / 信息的用户是谁? 若要满足用户访问需求和信息敏感程度级别的要求，实施的安全性模式必须要有哪种复杂程度? / 安全性应考虑到的方面包括(高层次): 身份验证、加密、访问权、完整性和隐私。 / 上述问题还可以细分为必须要考虑的一组核心问题和措施: 禁用资源，管理内容，隔离数据、资源或访问权，软件更新和安全措施，人员角色，更改和配置管理，入侵检测以及漏洞分析。
- 5: 我们可以在此处确认驱动安全性需求的业务需求。 / 但是，我们还可以确认性能、使用情况以及部署期限要求。 / 以上需求都会在下一项活动中协调。
- 6: 我们可以在此处协调安全性需求与业务持续需求。我们可以实施大量的安全措施，但是如果业务因为无法有效地使用实施的安全措施而归于失败，则公司为实施安全措施所做的努力将付之东流。
- 12: 例如: 现有系统是否可以轻松地升级到此技术，还是需要对大部分基础架构进行批量替换?
- 13: 企业战略可以影响多个方面，例如: / 如果企业战略是分散数据中心或聚集数据中心，该技术是否提供支持? / 如果公司的战略是将此项技术的维护工作外包，则我们需要确保该技术/组件可以提供足够的衡量标准，以便使我们可以定义严格的服务级别协议(SLA)，这样在性能出现问题时，就不能因为是可争议的根本原因而对涉及性能的 SLA 起争议，从而可以轻松确认责任。
- 14: 此技术是否尚未成形? 是否稳定可靠? / 此技术的维修层是组件、卡还是单元? / 临界点与失败平均时之间的最低需求是什么? / 技术或组件是否提供积极监控以及早期压力指示? / 技术或组件是否易于绑定至系统监控工具?
- 15: 该技术支持变化中的需求和方向的能力如何，等等?
- 16: 确定与此特定技术(或技术组件)关联的风险，例如: / 该技术是众所周知还是知者寥寥? / 该技术是否基于尚未出现的标准、基于尚未被普遍采用的最新标准或已被证明可靠的标准? / 该技术是否由多个公司提供? 如果不是，其提供者的稳定情况如何? / 该技术是否为新技术? 发现问题时，处理问题的速度如何?
- 17: 我们内部是否拥有掌握此技能的人员? 是否容易找到掌握该技能的人员? 该技能是否容易学习? 找到掌握此技能的人员或学习此技能的费用是多少?
- 18: 例如: 如果我们比较一下长期存储技术，每个 GB 存储的成本是多少? 如果存储材料随着时间的推移而老化，则存储必须刷新或重写的间隔是多久?
- 19: 例如，某些技术可以快速实施，这更适合于短期危机管理。
- 20: 限制分析技术耗费的时间很重要。技术更新的速度非常快，永无尽头，因此应为技术调查设置一个合理的时间限制。此限制通常根据企业需求来设置。如果企业因为当前基础设施问题而将要遇到重大的性能问题(在一年之内)，则技术和解决方案研究必须尽早结束，以便在危机点到来之前制定解决方案、进行测试并完成部署。 / 此里程碑的目的是提供此部分研究的终结点。请根据需要设置。
- 21: 尽管正在研究不同的技术，这些技术也更容易理解，我们仍将开始根据多种技术构建完整的解决方案可能性。可以考虑将这些解决方案可能性部署在技术阶段中。定义解决方案时，分段的用途和顺序将作为进行解决方案比较时的附加考虑因素。 / 注: 请在开始关注技术时即进行解决方案的开发。解决方案可能不会一时完全成形，但规划师需要立刻开始考虑解决方案。
- 30: 请查看解决方案可能性中的注释。
- 31: 限制构建解决方案耗费的时间很重要。技术更新的速度非常快，永无尽头，因此应当为解决方案的制定设置一个合理的时间限制。此限制通常根据企业需求来设置。如果企业因为当前基础设施问题而将要遇到重大的性能问题(在一年之内)，则技术和解决方案研究必须尽早结束，以便在危机点到来之前制定解决方案、进行测试并完成部署。 / 此里程碑的目的是提供此部分研究的终结点。请按需要设置。

| ID | WBS | Task | Type | Duration | Start | Finish | Predecessors | Total slack |
| --- | --- | --- | --- | --- | --- | --- | --- | --- |
| 32 | 5 | **选择解决方案** |  | 1d? | 2007-01-11 | 2007-01-11 |  | 0d |
| 33 | 5.1 | 比较和选择解决方案 |  | 1d? | 2007-01-11 | 2007-01-11 | 20, 31 | 0d |
| 34 | 5.2 | 完成解决方案的选择工作 | milestone | 0d | 2007-01-11 | 2007-01-11 | 33 | 6d |
| 35 | 6 | **规划解决方案** |  | 2d? | 2007-01-12 | 2007-01-15 |  | 0d |
| 36 | 6.1 | 准备解决方案开发和部署日程 |  | 1d? | 2007-01-12 | 2007-01-12 | 33 | 0d |
| 37 | 6.2 | 准备解决方案培训、支持和维护计划 |  | 1d? | 2007-01-15 | 2007-01-15 | 36 | 0d |
| 38 | 6.3 | 准备解决方案部署/迁移计划 |  | 1d? | 2007-01-15 | 2007-01-15 | 36 | 0d |
| 39 | 7 | **执行解决方案实施** |  | 3d? | 2007-01-15 | 2007-01-17 |  | 0d |
| 40 | 7.1 | 实施解决方案 |  | 1d? | 2007-01-15 | 2007-01-15 | 36 | 0d |
| 41 | 7.2 | 测试解决方案 |  | 1d? | 2007-01-16 | 2007-01-16 | 37, 40, 38 | 0d |
| 42 | 7.3 | 解决方案生产迁移审批 |  | 1d? | 2007-01-17 | 2007-01-17 | 41 | 0d |
| 43 | 8 | **部署解决方案** |  | 2d? | 2007-01-18 | 2007-01-19 |  | 0d |
| 44 | 8.1 | 迁移至解决方案 |  | 1d? | 2007-01-18 | 2007-01-18 | 38, 42 | 0d |
| 45 | 8.2 | 验收解决方案 |  | 1d? | 2007-01-19 | 2007-01-19 | 44 | 0d |
| 46 | 9 | 解决方案部署并验收完毕 | milestone | 0d | 2007-01-19 | 2007-01-19 | 45 | 0d |

Notes:
- 33: 此阶段通常很快，因为公司已掌握了此前的所有工作，熟悉每种解决方案的优缺点。 / 特定解决方案可能会在早期就脱颖而出，成为明显的实际胜出者，因此，未必一定要使用时间界限里程碑。
- 36: 这可以包括对任意或所有区域的内部处理或外包处理: 建立架构、原型制作、可伸缩性测试、维护规划以和备份、服务台等。
- 44: 将产品移植至已部署的解决方案的方式有多种。 / 通常情况下，可使用分段方法类型或直接转换类型。根据所选方法不同，测试和验证可能会有所不同。
