# 实施人力资源信息系统

Schedule from MS Project, 2007-01-01 to 2007-04-02.
此模板从人力资源部门角度，并在很高层次上，列出了实施 HRIS 所需步骤的框架。该模板并不特定于任何商业软件系统。

## Calendars

- 标准: Mon-Fri 08:00-12:00, 13:00-17:00; Sat-Sun off.

## Resources

| Resource |
| --- |
| 行政管理人员 |
| 信息系统 |
| 人力资源 |
| 采购 |

## Schedule

| ID | WBS | Task | Type | Duration | Start | Finish | Predecessors | Total slack | Free slack | Resources | Work |
| --- | --- | --- | --- | --- | --- | --- | --- | --- | --- | --- | --- |
| 1 | 1 | 用于由行政管理人员批准的 HRIS 实施的业务案例 | milestone | 0d | 2007-01-01 | 2007-01-01 |  | 0d |  |  |  |
| 2 | 2 | **分析和要求** |  | 3d? | 2007-01-01 | 2007-01-03 |  | 0d |  |  | 40h |
| 3 | 2.1 | **人力资源数据要求** |  | 3d? | 2007-01-01 | 2007-01-03 |  | 0d |  |  | 24h |
| 4 | 2.1.1 | 审阅现有材料 |  | 1d? | 2007-01-01 | 2007-01-01 | 1 | 0d |  | 人力资源 | 8h |
| 5 | 2.1.2 | 举行用户基本要求会议 |  | 1d? | 2007-01-02 | 2007-01-02 | 4 | 0d |  | 人力资源 | 8h |
| 6 | 2.1.3 | 制定用户需要评估并完成人力资源业务流程 |  | 1d? | 2007-01-03 | 2007-01-03 | 5 | 0d |  | 人力资源 | 8h |
| 7 | 2.1.4 | 完成人力资源数据要求评估 | milestone | 0d | 2007-01-03 | 2007-01-03 | 6 | 62.5d |  |  |  |
| 8 | 2.2 | **技术基础设施要求** |  | 2d? | 2007-01-01 | 2007-01-02 |  | 1d |  |  | 16h |
| 9 | 2.2.1 | 审查当前的基础设施 |  | 1d? | 2007-01-01 | 2007-01-01 | 1 | 1d | 0d | 信息系统 | 8h |
| 10 | 2.2.2 | 项目未来需求 |  | 1d? | 2007-01-02 | 2007-01-02 | 9 | 1d | 0d | 信息系统 | 8h |
| 11 | 2.2.3 | 完成技术基础设施要求评估 | milestone | 0d | 2007-01-02 | 2007-01-02 | 10 | 63.5d |  |  |  |
| 12 | 2.3 | 完成分析和要求 | milestone | 0d | 2007-01-03 | 2007-01-03 | 6, 10 | 0d |  |  |  |
| 13 | 3 | **评估 HRIS 解决方案** |  | 7d? | 2007-01-04 | 2007-01-12 |  | 0d |  |  | 104h |
| 14 | 3.1 | 制定 RFP |  | 1d? | 2007-01-04 | 2007-01-04 | 12 | 0d |  | 信息系统; 人力资源 | 16h |
| 15 | 3.2 | 确定赋予答复的权重 |  | 1d? | 2007-01-05 | 2007-01-05 | 14 | 0d |  | 信息系统; 人力资源 | 16h |
| 16 | 3.3 | 发布 RFP |  | 1d? | 2007-01-08 | 2007-01-08 | 15 | 0d |  | 采购 | 8h |
| 17 | 3.4 | 评估响应 |  | 1d? | 2007-01-09 | 2007-01-09 | 16 | 0d |  | 信息系统; 人力资源 | 16h |
| 18 | 3.5 | 进行供应商响应/要求差距分析 |  | 1d? | 2007-01-10 | 2007-01-10 | 17 | 0d |  | 信息系统; 人力资源 | 16h |
| 19 | 3.6 | 邀请前几位候选者进行演示 |  | 1d? | 2007-01-11 | 2007-01-11 | 18 | 0d |  | 人力资源; 采购 | 16h |
| 20 | 3.7 | 选择最合适的 HRIS 供应商解决方案 |  | 1d? | 2007-01-12 | 2007-01-12 | 19 | 0d |  | 信息系统; 人力资源 | 16h |
| 21 | 3.8 | 完成评估 HRIS 解决方案 | milestone | 0d | 2007-01-12 | 2007-01-12 | 20 | 0d |  |  |  |
| 22 | 4 | 采购 HRIS 解决方案 |  | 1d? | 2007-01-15 | 2007-01-15 | 21 | 0d |  |  |  |
| 23 | 5 | **设计 HRIS 解决方案** |  | 13d? | 2007-01-16 | 2007-02-01 |  | 0d |  |  | 185.33h |
| 24 | 5.1 | **迭代计划** |  | 3d? | 2007-01-16 | 2007-01-18 |  | 0d |  |  | 32h |
| 25 | 5.1.1 | 进行用户和工作组培训 |  | 1d? | 2007-01-16 | 2007-01-16 | 22 | 0d |  | 信息系统 | 8h |
| 26 | 5.1.2 | 确定迭代 |  | 1d? | 2007-01-17 | 2007-01-17 | 25 | 0d |  | 信息系统 | 8h |
| 27 | 5.1.3 | 确定测试方法 |  | 1d? | 2007-01-17 | 2007-01-17 | 25 | 0d |  | 信息系统 | 8h |
| 28 | 5.1.4 | 审阅迭代计划和确定迭代计划基准 |  | 1d? | 2007-01-18 | 2007-01-18 | 27, 26 | 0d |  | 信息系统 | 8h |
| 29 | 5.1.5 | 完成迭代计划 | milestone | 0d | 2007-01-18 | 2007-01-18 | 28 | 0d |  |  |  |

Notes:
- 4: 审阅人力资源业务流程中的优先工作、要求和当前正在进行中的技术步骤。
- 5: 与人力资源管理人员进行会谈。目的是确认现有人力资源数据要求，确定新的要求，了解当前业务流程，并确定问题和弥补差距的建议策略。
- 13: 对满足早前发现的核心职能要求的市场，进行可用的 HRIS 解决方案初步评估。

| ID | WBS | Task | Type | Duration | Start | Finish | Predecessors | Total slack | Free slack | Resources | Work |
| --- | --- | --- | --- | --- | --- | --- | --- | --- | --- | --- | --- |
| 30 | 5.2 | **实施原型制作** |  | 4d? | 2007-01-17 | 2007-01-22 |  | 47.5d |  |  | 48h |
| 31 | 5.2.1 | 制定方案 |  | 1d? | 2007-01-17 | 2007-01-17 | 25 | 47.5d | 0d | 信息系统 | 8h |
| 32 | 5.2.2 | 将方案体现到程序包事务 |  | 1d? | 2007-01-18 | 2007-01-18 | 31 | 51.5d |  | 信息系统 | 8h |
| 33 | 5.2.3 | 确定方案步骤 |  | 1d? | 2007-01-18 | 2007-01-18 | 31 | 50.5d | 0d | 信息系统 | 8h |
| 34 | 5.2.4 | 指定报告和制作报告原型 |  | 1d? | 2007-01-19 | 2007-01-19 | 33 | 50.5d |  | 信息系统 | 8h |
| 35 | 5.2.5 | 指定外部接口 |  | 1d? | 2007-01-18 | 2007-01-18 | 31 | 47.5d | 0d | 信息系统 | 8h |
| 36 | 5.2.6 | 生成程序包原型 |  | 1d? | 2007-01-19 | 2007-01-19 | 35 | 47.5d | 0d | 信息系统 | 8h |
| 37 | 5.2.7 | 实行/审阅程序包原型 |  | 1d? | 2007-01-22 | 2007-01-22 | 36 | 47.5d | 0d |  |  |
| 38 | 5.2.8 | 完成实施原型制作 | milestone | 0d | 2007-01-22 | 2007-01-22 | 37 | 47.5d | 0d |  |  |
| 39 | 5.3 | **迭代合并** |  | 2d? | 2007-01-23 | 2007-01-24 |  | 47.5d |  |  | 10.67h |
| 40 | 5.3.1 | 设计系统和整体测试事例 |  | 1d? | 2007-01-23 | 2007-01-23 | 38 | 47.5d | 0d | 信息系统 [50%]; 人力资源 [50%] | 5.33h |
| 41 | 5.3.2 | 确认将来迭代的范围 |  | 1d? | 2007-01-24 | 2007-01-24 | 40 | 47.5d | 0d | 信息系统 [50%]; 人力资源 [50%] | 5.33h |
| 42 | 5.3.3 | 完成迭代合并 | milestone | 0d | 2007-01-24 | 2007-01-24 | 41 | 47.5d |  |  |  |
| 43 | 5.4 | **数据迁移设计** |  | 6d? | 2007-01-19 | 2007-01-26 |  | 0d |  |  | 61.33h |
| 44 | 5.4.1 | 审阅数据采集策略 |  | 1d? | 2007-01-19 | 2007-01-19 | 29 | 0d |  | 信息系统 | 8h |
| 45 | 5.4.2 | 确定数据迁移源 |  | 1d? | 2007-01-22 | 2007-01-22 | 44 | 0d |  | 信息系统 | 8h |
| 46 | 5.4.3 | 确定数据迁移规则和逻辑 |  | 1d? | 2007-01-23 | 2007-01-23 | 45 | 0d |  | 信息系统 | 8h |
| 47 | 5.4.4 | 进行数据清理 |  | 1d? | 2007-01-23 | 2007-01-23 | 45 | 48.5d |  | 信息系统 | 8h |
| 48 | 5.4.5 | 设计数据迁移事务 |  | 1d? | 2007-01-24 | 2007-01-24 | 46, 45 | 47.5d |  | 信息系统 | 8h |
| 49 | 5.4.6 | 确定数据迁移过程和控制 |  | 1d? | 2007-01-24 | 2007-01-24 | 46 | 0d |  | 信息系统 | 8h |
| 50 | 5.4.7 | 审阅转换设计和确定转换设计基准 |  | 1d? | 2007-01-25 | 2007-01-25 | 49 | 0d |  | 信息系统 | 8h |
| 51 | 5.4.8 | 获取对转换设计的签字认可 |  | 1d? | 2007-01-26 | 2007-01-26 | 50 | 0d |  | 信息系统 [50%]; 人力资源 [50%] | 5.33h |
| 52 | 5.4.9 | 完成数据迁移设计 | milestone | 0d | 2007-01-26 | 2007-01-26 | 51 | 0d |  |  |  |
| 53 | 5.5 | **最终确定集成设计阶段** |  | 4d? | 2007-01-29 | 2007-02-01 |  | 0d |  |  | 33.33h |
| 54 | 5.5.1 | 制定要求可跟踪性模式 |  | 1d? | 2007-01-29 | 2007-01-29 | 52 | 0d |  | 信息系统 | 8h |
| 55 | 5.5.2 | 确定项目/可交付结果的基准 |  | 1d? | 2007-01-30 | 2007-01-30 | 54 | 0d |  | 信息系统 | 8h |
| 56 | 5.5.3 | 制定下一个阶段的日程 |  | 1d? | 2007-01-31 | 2007-01-31 | 55 | 0d |  | 信息系统 [50%]; 人力资源 [50%] | 5.33h |
| 57 | 5.5.4 | 与项目管理委员会一起审阅项目状态 |  | 1d? | 2007-02-01 | 2007-02-01 | 56 | 0d |  | 行政管理人员; 信息系统; 人力资源 | 12h |
| 58 | 5.5.5 | 完成最终确定集成设计阶段 | milestone | 0d | 2007-02-01 | 2007-02-01 | 57 | 0d |  |  |  |
| 59 | 5.6 | 完成集成设计 | milestone | 0d | 2007-02-01 | 2007-02-01 | 58 | 0d |  |  |  |

| ID | WBS | Task | Type | Duration | Start | Finish | Predecessors | Total slack | Resources | Work |
| --- | --- | --- | --- | --- | --- | --- | --- | --- | --- | --- |
| 60 | 6 | **集成、生成、测试** |  | 24.5d? | 2007-02-02 | 2007-03-08 |  | 0d |  | 320h |
| 61 | 6.1 | **生成迭代计划** |  | 3d? | 2007-02-02 | 2007-02-06 |  | 0d |  | 32h |
| 62 | 6.1.1 | 确认技术体系结构 |  | 1d? | 2007-02-02 | 2007-02-02 | 59 | 0d | 信息系统 | 8h |
| 63 | 6.1.2 | 确定迭代和生成次数 |  | 1d? | 2007-02-05 | 2007-02-05 | 62 | 0d | 信息系统 | 8h |
| 64 | 6.1.3 | 修改测试事例 |  | 1d? | 2007-02-06 | 2007-02-06 | 63 | 0d | 信息系统; 人力资源 | 16h |
| 65 | 6.1.4 | 完成生成迭代计划 | milestone | 0d | 2007-02-06 | 2007-02-06 | 64 | 0d |  |  |
| 66 | 6.2 | **生成集成** |  | 4.5d? | 2007-02-07 | 2007-02-13 |  | 0d |  | 56h |
| 67 | 6.2.1 | 生成报告 |  | 1d? | 2007-02-07 | 2007-02-07 | 65 | 0d | 信息系统 | 8h |
| 68 | 6.2.2 | 设计和生成迁移组件 |  | 1d? | 2007-02-08 | 2007-02-08 | 67 | 0d | 信息系统 | 8h |
| 69 | 6.2.3 | 设计和生成外部接口 |  | 1d? | 2007-02-09 | 2007-02-09 | 68 | 35.5d | 信息系统 | 8h |
| 70 | 6.2.4 | 优化性能 |  | 1d? | 2007-02-09 | 2007-02-09 | 68 | 35.5d | 信息系统 | 8h |
| 71 | 6.2.5 | 完成单元/整体测试 |  | 1d? | 2007-02-08 | 2007-02-09 | 68SS+5% | 0d | 信息系统 | 8h |
| 72 | 6.2.6 | 审阅和确定内部版本基准 |  | 1d? | 2007-02-09 | 2007-02-12 | 71 | 0d | 信息系统 | 8h |
| 73 | 6.2.7 | 交付内部测试版本 |  | 1d? | 2007-02-12 | 2007-02-13 | 72 | 0d | 信息系统 | 8h |
| 74 | 6.2.8 | 完成生成集成 | milestone | 0d | 2007-02-13 | 2007-02-13 | 73 | 0d |  |  |
| 75 | 6.3 | **系统测试设计和开发** |  | 2d? | 2007-02-13 | 2007-02-15 |  | 0d |  | 32h |
| 76 | 6.3.1 | 确定测试脚本 |  | 1d? | 2007-02-13 | 2007-02-14 | 74 | 0d | 信息系统 | 8h |
| 77 | 6.3.2 | 审阅测试事例/要求范围 |  | 1d? | 2007-02-14 | 2007-02-15 | 76 | 32d | 信息系统 | 8h |
| 78 | 6.3.3 | 开发自动执行的脚本 |  | 1d? | 2007-02-13 | 2007-02-14 | 76SS | 33d | 信息系统 | 8h |
| 79 | 6.3.4 | 建立外部测试数据集 |  | 1d? | 2007-02-14 | 2007-02-15 | 76 | 0d | 信息系统 | 8h |
| 80 | 6.3.5 | 完成系统测试设计和开发 | milestone | 0d | 2007-02-15 | 2007-02-15 | 79 | 0d |  |  |
| 81 | 6.4 | **系统测试执行** |  | 3d? | 2007-02-15 | 2007-02-20 |  | 0d |  | 24h |
| 82 | 6.4.1 | 执行测试并记录结果 |  | 1d? | 2007-02-15 | 2007-02-16 | 80 | 0d | 信息系统 | 8h |
| 83 | 6.4.2 | 研究意外结果 |  | 1d? | 2007-02-16 | 2007-02-19 | 82 | 0d | 信息系统 | 8h |
| 84 | 6.4.3 | 评估、区分优先次序和计划测试更改 |  | 1d? | 2007-02-19 | 2007-02-20 | 83 | 0d | 信息系统 | 8h |
| 85 | 6.4.4 | 完成系统测试执行 | milestone | 0d | 2007-02-20 | 2007-02-20 | 84 | 0d |  |  |

| ID | WBS | Task | Type | Duration | Start | Finish | Predecessors | Total slack | Resources | Work |
| --- | --- | --- | --- | --- | --- | --- | --- | --- | --- | --- |
| 86 | 6.5 | **迭代审阅** |  | 2d? | 2007-02-20 | 2007-02-22 |  | 0d |  | 32h |
| 87 | 6.5.1 | 审阅当前迭代的系统测试结果 |  | 1d? | 2007-02-20 | 2007-02-21 | 85 | 0d | 信息系统; 人力资源 | 16h |
| 88 | 6.5.2 | 确认将来迭代的范围 |  | 1d? | 2007-02-21 | 2007-02-22 | 87 | 0d | 信息系统; 人力资源 | 16h |
| 89 | 6.5.3 | 完成迭代审阅 | milestone | 0d | 2007-02-22 | 2007-02-22 | 88 | 0d |  |  |
| 90 | 6.6 | **验收测试** |  | 6d? | 2007-02-22 | 2007-03-02 |  | 0d |  | 88h |
| 91 | 6.6.1 | 设置验收测试环境 |  | 1d? | 2007-02-22 | 2007-02-23 | 89 | 0d | 信息系统 | 8h |
| 92 | 6.6.2 | 创建验收测试脚本 |  | 1d? | 2007-02-23 | 2007-02-26 | 91 | 0d | 信息系统; 人力资源 | 16h |
| 93 | 6.6.3 | 执行验收测试并记录结果 |  | 1d? | 2007-02-26 | 2007-02-27 | 92 | 0d | 信息系统; 人力资源 | 16h |
| 94 | 6.6.4 | 根据验收测试结果更新系统 |  | 1d? | 2007-02-27 | 2007-02-28 | 93 | 0d | 信息系统; 人力资源 | 16h |
| 95 | 6.6.5 | 重新执行验收测试并记录结果 |  | 1d? | 2007-02-28 | 2007-03-01 | 94 | 0d | 信息系统; 人力资源 | 16h |
| 96 | 6.6.6 | 获取对系统的签字认可 |  | 1d? | 2007-03-01 | 2007-03-02 | 95 | 0d | 信息系统; 人力资源 | 16h |
| 97 | 6.6.7 | 完成验收测试 | milestone | 0d | 2007-03-02 | 2007-03-02 | 96 | 21d |  |  |
| 98 | 6.7 | 完成程序包实施 | milestone | 0d | 2007-03-02 | 2007-03-02 | 96 | 0d |  |  |
| 99 | 6.8 | **最终确定集成阶段** |  | 4d? | 2007-03-02 | 2007-03-08 |  | 0d |  | 56h |
| 100 | 6.8.1 | 制定要求可跟踪性模式 |  | 1d? | 2007-03-02 | 2007-03-05 | 98 | 0d | 信息系统; 人力资源 | 16h |
| 101 | 6.8.2 | 确定项目/可交付结果的基准 |  | 1d? | 2007-03-05 | 2007-03-06 | 100 | 0d | 信息系统; 人力资源 | 16h |
| 102 | 6.8.3 | 制定下一个阶段的日程 |  | 1d? | 2007-03-06 | 2007-03-07 | 101 | 0d | 信息系统; 人力资源 | 16h |
| 103 | 6.8.4 | 与项目管理委员会一起审阅项目状态 |  | 1d? | 2007-03-07 | 2007-03-08 | 102 | 0d | 人力资源 | 8h |
| 104 | 6.8.5 | 完成最终确定集成阶段 | milestone | 0d | 2007-03-08 | 2007-03-08 | 103 | 0d |  |  |
| 105 | 7 | **部署** |  | 17d? | 2007-03-08 | 2007-04-02 |  | 0d |  | 176h |
| 106 | 7.1 | **教育开发** |  | 4d? | 2007-03-08 | 2007-03-14 |  | 0d |  | 56h |
| 107 | 7.1.1 | 设置培训环境 |  | 1d? | 2007-03-08 | 2007-03-09 | 104 | 0d | 信息系统 | 8h |
| 108 | 7.1.2 | 创建应用程序用户手册 |  | 1d? | 2007-03-09 | 2007-03-12 | 107 | 0d | 信息系统; 人力资源 | 16h |
| 109 | 7.1.3 | 创建管理员手册 |  | 1d? | 2007-03-12 | 2007-03-13 | 108 | 0d | 信息系统; 人力资源 | 16h |
| 110 | 7.1.4 | 编写培训材料 |  | 1d? | 2007-03-13 | 2007-03-14 | 109 | 0d | 信息系统; 人力资源 | 16h |
| 111 | 7.1.5 | 完成教育开发 | milestone | 0d | 2007-03-14 | 2007-03-14 | 110 | 0d |  |  |

| ID | WBS | Task | Type | Duration | Start | Finish | Predecessors | Total slack | Resources | Work |
| --- | --- | --- | --- | --- | --- | --- | --- | --- | --- | --- |
| 112 | 7.2 | **准备部署** |  | 6d? | 2007-03-14 | 2007-03-22 |  | 0d |  | 48h |
| 113 | 7.2.1 | 制定后台日程安排过程 |  | 1d? | 2007-03-14 | 2007-03-15 | 111 | 0d | 信息系统 | 8h |
| 114 | 7.2.2 | 创建生产测试脚本 |  | 1d? | 2007-03-15 | 2007-03-16 | 113 | 0d | 信息系统 | 8h |
| 115 | 7.2.3 | 审阅和编制技术实施计划 |  | 1d? | 2007-03-16 | 2007-03-19 | 113, 114 | 0d | 信息系统 | 8h |
| 116 | 7.2.4 | 建立技术环境 |  | 1d? | 2007-03-19 | 2007-03-20 | 115 | 0d | 信息系统 | 8h |
| 117 | 7.2.5 | 进行部署简介 |  | 1d? | 2007-03-20 | 2007-03-21 | 116 | 0d | 信息系统 | 8h |
| 118 | 7.2.6 | 进行培训 |  | 1d? | 2007-03-21 | 2007-03-22 | 117 | 7d | 人力资源 | 8h |
| 119 | 7.2.7 | 完成过程审阅 |  | 1d? | 2007-03-21 | 2007-03-22 | 117 | 0d |  |  |
| 120 | 7.2.8 | 完成部署准备 | milestone | 0d | 2007-03-22 | 2007-03-22 | 119 | 0d |  |  |
| 121 | 7.3 | **安装和移交** |  | 5d? | 2007-03-22 | 2007-03-29 |  | 0d |  | 40h |
| 122 | 7.3.1 | 安装应用软件 |  | 1d? | 2007-03-22 | 2007-03-23 | 120 | 0d | 信息系统 | 8h |
| 123 | 7.3.2 | 转换静态数据并获取新数据 |  | 1d? | 2007-03-23 | 2007-03-26 | 122 | 0d | 信息系统 | 8h |
| 124 | 7.3.3 | 转换动态数据 |  | 1d? | 2007-03-23 | 2007-03-26 | 122 | 0d | 信息系统 | 8h |
| 125 | 7.3.4 | 进行生产测试 |  | 1d? | 2007-03-26 | 2007-03-27 | 123, 124 | 0d | 信息系统 | 8h |
| 126 | 7.3.5 | 转换到新应用程序 |  | 1d? | 2007-03-27 | 2007-03-28 | 125 | 0d | 信息系统 | 8h |
| 127 | 7.3.6 | 创建维护手册 |  | 1d? | 2007-03-28 | 2007-03-29 | 126 | 0d |  |  |
| 128 | 7.3.7 | 完成安装和移交 | milestone | 0d | 2007-03-29 | 2007-03-29 | 127 | 0d |  |  |
| 129 | 7.4 | **最终确定部署阶段** |  | 2d? | 2007-03-29 | 2007-04-02 |  | 0d |  | 32h |
| 130 | 7.4.1 | 举行经验教训会议 |  | 1d? | 2007-03-29 | 2007-03-30 | 128 | 0d | 信息系统; 人力资源 | 16h |
| 131 | 7.4.2 | 关闭项目文件 |  | 1d? | 2007-03-30 | 2007-04-02 | 130 | 0d | 信息系统; 人力资源 | 16h |
| 132 | 7.4.3 | 完成最终确定部署阶段 | milestone | 0d | 2007-04-02 | 2007-04-02 | 131 | 0d |  |  |
| 133 | 7.5 | 完成部署工作 | milestone | 0d | 2007-04-02 | 2007-04-02 | 131 | 0d |  |  |
| 134 | 8 | 完成 HRIS 实施 | milestone | 0d | 2007-04-02 | 2007-04-02 | 133 | 0d |  |  |
