# 实施财务和会计系统

Schedule from MS Project, 2007-01-01 to 2007-04-11.
此模板列出了实施财务会计系统所需的步骤框架。它假定新系统将替换现有系统或流程，同时还假定已经选择了新的应用软件系统。

## Calendars

- 标准: Mon-Fri 08:00-12:00, 13:00-17:00; Sat-Sun off.

## Resources

| Resource |
| --- |
| 行政管理人员 |
| 信息系统 |
| 会计 |
| 法律人员 |
| 采购人员 |

## Schedule

| ID | WBS | Task | Type | Duration | Start | Finish | Predecessors | Total slack | Free slack | Resources | Work |
| --- | --- | --- | --- | --- | --- | --- | --- | --- | --- | --- | --- |
| 1 | 1 | 已选择新的财务和会计系统 | milestone | 0d | 2007-01-01 | 2007-01-01 |  | 0d |  |  |  |
| 2 | 2 | **实施要求** |  | 18.33d? | 2007-01-01 | 2007-01-25 |  | 0d |  |  | 234.64h |
| 3 | 2.1 | **程序包体系结构验证** |  | 5d? | 2007-01-01 | 2007-01-05 |  | 0d |  |  | 56h |
| 4 | 2.1.1 | 审阅技术体系结构 |  | 1d? | 2007-01-01 | 2007-01-01 | 1 | 0d |  | 信息系统 | 8h |
| 5 | 2.1.2 | 确定程序包实施环境 |  | 1d? | 2007-01-02 | 2007-01-02 | 4 | 0d |  | 信息系统 | 8h |
| 6 | 2.1.3 | 提供初步培训 |  | 1d? | 2007-01-02 | 2007-01-02 | 4 | 70.83d |  | 信息系统 | 8h |
| 7 | 2.1.4 | 安装程序包 |  | 1d? | 2007-01-03 | 2007-01-03 | 5 | 0d |  | 信息系统 | 8h |
| 8 | 2.1.5 | 估计使用数量和缩放选项 |  | 1d? | 2007-01-04 | 2007-01-04 | 7 | 68.83d |  | 信息系统 | 8h |
| 9 | 2.1.6 | 确保构建具有高可用性的安装 |  | 1d? | 2007-01-04 | 2007-01-04 | 7 | 67.83d | 0d | 信息系统 | 8h |
| 10 | 2.1.7 | 审阅技术体系结构模型和确定技术体系结构模型基准 |  | 1d? | 2007-01-05 | 2007-01-05 | 9 | 67.83d | 0d | 信息系统 | 8h |
| 11 | 2.1.8 | 完成程序包体系结构验证 | milestone | 0d | 2007-01-05 | 2007-01-05 | 10 | 67.83d |  |  |  |
| 12 | 2.2 | **程序包和要求审阅** |  | 2d? | 2007-01-04 | 2007-01-05 |  | 0d |  |  | 32h |
| 13 | 2.2.1 | 浏览程序包 |  | 0.5d? | 2007-01-04 | 2007-01-04 | 7 | 0d |  | 信息系统; 会计 | 8h |
| 14 | 2.2.2 | 验证业务要求模型 |  | 0.5d? | 2007-01-04 | 2007-01-04 | 13 | 0d |  | 信息系统; 会计 | 8h |
| 15 | 2.2.3 | 将业务要求体现到程序包 |  | 0.5d? | 2007-01-05 | 2007-01-05 | 14 | 0d |  | 信息系统; 会计 | 8h |
| 16 | 2.2.4 | 编制程序包差距文档并确定差距解决方案 |  | 0.5d? | 2007-01-05 | 2007-01-05 | 15 | 0d |  | 信息系统; 会计 | 8h |
| 17 | 2.2.5 | 完成程序包和要求审阅 | milestone | 0d | 2007-01-05 | 2007-01-05 | 16 | 0d |  |  |  |
| 18 | 2.3 | **实施选项** |  | 5d? | 2007-01-08 | 2007-01-12 |  | 0d |  |  | 76h |
| 19 | 2.3.1 | 确定业务流程选项 |  | 0.5d? | 2007-01-08 | 2007-01-08 | 17 | 0d |  | 信息系统; 会计 | 8h |
| 20 | 2.3.2 | 评估数据迁移策略 |  | 1d? | 2007-01-08 | 2007-01-09 | 19 | 0d |  | 信息系统 | 8h |
| 21 | 2.3.3 | 评估部署方法 |  | 1d? | 2007-01-08 | 2007-01-09 | 19 | 0d |  | 信息系统 | 8h |
| 22 | 2.3.4 | 评估系统界面 |  | 1d? | 2007-01-08 | 2007-01-09 | 19 | 0d |  | 信息系统 | 8h |
| 23 | 2.3.5 | 评估交付增加选项 |  | 1d? | 2007-01-08 | 2007-01-09 | 19 | 0d |  | 信息系统 | 8h |
| 24 | 2.3.6 | 编档实施选项 |  | 1d? | 2007-01-09 | 2007-01-10 | 19, 20, 21, 22, 23 | 0d |  | 信息系统 | 8h |
| 25 | 2.3.7 | 选择实施选项 |  | 1d? | 2007-01-10 | 2007-01-11 | 24 | 0d |  | 信息系统 | 8h |
| 26 | 2.3.8 | 制定测试和用户接受计划 |  | 0.5d? | 2007-01-11 | 2007-01-11 | 25 | 0d |  | 信息系统; 会计 | 8h |
| 27 | 2.3.9 | 获取对业务流程选项建议的认可 |  | 1d? | 2007-01-12 | 2007-01-12 | 26 | 0d |  | 行政管理人员; 信息系统; 会计 | 12h |
| 28 | 2.3.10 | 完成实施选项 | milestone | 0d | 2007-01-12 | 2007-01-12 | 27 | 0d |  |  |  |

| ID | WBS | Task | Type | Duration | Start | Finish | Predecessors | Total slack | Free slack | Resources | Work |
| --- | --- | --- | --- | --- | --- | --- | --- | --- | --- | --- | --- |
| 29 | 2.4 | **程序包业务增量设计** |  | 5d? | 2007-01-15 | 2007-01-19 |  | 0d |  |  | 40h |
| 30 | 2.4.1 | 确定实施增量 |  | 1d? | 2007-01-15 | 2007-01-15 | 28 | 0d |  | 信息系统 | 8h |
| 31 | 2.4.2 | 确定增量接受标准 |  | 1d? | 2007-01-16 | 2007-01-16 | 30 | 0d |  | 信息系统 | 8h |
| 32 | 2.4.3 | 确定培训方法和计划 |  | 1d? | 2007-01-17 | 2007-01-17 | 31 | 0d |  | 信息系统 | 8h |
| 33 | 2.4.4 | 编制交付增量计划 |  | 1d? | 2007-01-18 | 2007-01-18 | 32 | 0d |  | 信息系统 | 8h |
| 34 | 2.4.5 | 审阅交付增量计划 |  | 1d? | 2007-01-19 | 2007-01-19 | 33 | 0d |  | 会计 | 8h |
| 35 | 2.4.6 | 完成业务实施设计 | milestone | 0d | 2007-01-19 | 2007-01-19 | 34 | 0d |  |  |  |
| 36 | 2.5 | **最终确定要求阶段** |  | 3.33d? | 2007-01-22 | 2007-01-25 |  | 0d |  |  | 30.64h |
| 37 | 2.5.1 | 制定要求可跟踪性模式 |  | 1d? | 2007-01-22 | 2007-01-22 | 35 | 0d |  | 信息系统 | 8h |
| 38 | 2.5.2 | 确定项目/可交付结果的基准 |  | 1d? | 2007-01-23 | 2007-01-23 | 37 | 0d |  | 信息系统 | 8h |
| 39 | 2.5.3 | 制定下一个阶段的日程 |  | 1d? | 2007-01-24 | 2007-01-24 | 38 | 0d |  | 信息系统 | 8h |
| 40 | 2.5.4 | 与项目管理委员会一起审阅项目状态 |  | 0.33d? | 2007-01-25 | 2007-01-25 | 39 | 0d |  | 行政管理人员; 信息系统; 会计 | 6.64h |
| 41 | 2.6 | 完成要求阶段 | milestone | 0d | 2007-01-25 | 2007-01-25 | 40 | 0d |  |  |  |
| 42 | 3 | **程序包集成设计** |  | 13d? | 2007-01-25 | 2007-02-13 |  | 0d |  |  | 190.67h |
| 43 | 3.1 | **程序包迭代规划** |  | 3d? | 2007-01-25 | 2007-01-30 |  | 0d |  |  | 32h |
| 44 | 3.1.1 | 进行用户和工作组培训 |  | 1d? | 2007-01-25 | 2007-01-26 | 41 | 0d |  | 信息系统 | 8h |
| 45 | 3.1.2 | 确定迭代 |  | 1d? | 2007-01-26 | 2007-01-29 | 44 | 0d |  | 信息系统 | 8h |
| 46 | 3.1.3 | 确定测试方法 |  | 1d? | 2007-01-25 | 2007-01-26 | 44SS | 1d |  | 信息系统 | 8h |
| 47 | 3.1.4 | 审阅迭代计划和确定迭代计划基准 |  | 1d? | 2007-01-29 | 2007-01-30 | 46, 45 | 0d |  | 信息系统 | 8h |
| 48 | 3.2 | **程序包实施原型** |  | 3.5d? | 2007-01-26 | 2007-01-31 |  | 49d |  |  | 48h |
| 49 | 3.2.1 | 制定方案 |  | 1d? | 2007-01-26 | 2007-01-29 | 44 | 49d | 0d | 信息系统 | 8h |
| 50 | 3.2.2 | 将方案体现到程序包事务 |  | 1d? | 2007-01-26 | 2007-01-29 | 49SS+5% | 52d |  | 信息系统 | 8h |
| 51 | 3.2.3 | 确定方案步骤 |  | 1d? | 2007-01-26 | 2007-01-29 | 49SS+5% | 51.25d | 0d | 信息系统 | 8h |
| 52 | 3.2.4 | 指定报告和建立报告原型 |  | 1d? | 2007-01-29 | 2007-01-30 | 51SS+7.5% | 51.25d |  | 信息系统 | 8h |
| 53 | 3.2.5 | 指定外部接口 |  | 1d? | 2007-01-26 | 2007-01-29 | 49SS+5% | 49d | 0d | 信息系统 | 8h |
| 54 | 3.2.6 | 生成程序包原型 |  | 1d? | 2007-01-29 | 2007-01-30 | 53 | 49d | 0d | 信息系统 | 8h |
| 55 | 3.2.7 | 实行/审阅程序包原型 |  | 1d? | 2007-01-30 | 2007-01-31 | 54 | 49d | 0d |  |  |

Notes:
- 30: 这可能需要多个代表不同区域(可能以不同的增量实施)的工作组。
- 33: 编制由(潜在)不同工作组制定的计划

| ID | WBS | Task | Type | Duration | Start | Finish | Predecessors | Total slack | Free slack | Resources | Work |
| --- | --- | --- | --- | --- | --- | --- | --- | --- | --- | --- | --- |
| 56 | 3.3 | **程序包迭代合并** |  | 1d? | 2007-01-31 | 2007-02-01 |  | 49d |  |  | 16h |
| 57 | 3.3.1 | 设计系统和整体测试事例 |  | 0.5d? | 2007-01-31 | 2007-02-01 | 55 | 49d | 0d | 信息系统; 会计 | 8h |
| 58 | 3.3.2 | 确认将来迭代的范围 |  | 0.5d? | 2007-02-01 | 2007-02-01 | 57 | 49d |  | 信息系统; 会计 | 8h |
| 59 | 3.4 | **数据迁移设计** |  | 6d? | 2007-01-30 | 2007-02-07 |  | 0d |  |  | 61.33h |
| 60 | 3.4.1 | 审阅数据采集策略 |  | 1d? | 2007-01-30 | 2007-01-31 | 47 | 0d |  | 信息系统 | 8h |
| 61 | 3.4.2 | 确定数据迁移源 |  | 1d? | 2007-01-31 | 2007-02-01 | 60 | 0d |  | 信息系统 | 8h |
| 62 | 3.4.3 | 确定数据迁移规则和逻辑 |  | 1d? | 2007-02-01 | 2007-02-02 | 61 | 0d |  | 信息系统 | 8h |
| 63 | 3.4.4 | 进行数据清理 |  | 1d? | 2007-02-01 | 2007-02-02 | 61 | 48.5d |  | 信息系统 | 8h |
| 64 | 3.4.5 | 设计数据迁移事务 |  | 1d? | 2007-02-02 | 2007-02-05 | 62, 61 | 47.5d |  | 信息系统 | 8h |
| 65 | 3.4.6 | 确定数据迁移过程和控制 |  | 1d? | 2007-02-02 | 2007-02-05 | 62 | 0d |  | 信息系统 | 8h |
| 66 | 3.4.7 | 审阅转换设计和确定转换设计基准 |  | 1d? | 2007-02-05 | 2007-02-06 | 65 | 0d |  | 信息系统 | 8h |
| 67 | 3.4.8 | 获取对转换设计的签字认可 |  | 1d? | 2007-02-06 | 2007-02-07 | 66 | 0d |  | 信息系统 [50%]; 会计 [50%] | 5.33h |
| 68 | 3.5 | **最终确定集成设计阶段** |  | 4d? | 2007-02-07 | 2007-02-13 |  | 0d |  |  | 33.33h |
| 69 | 3.5.1 | 制定要求可跟踪性模式 |  | 1d? | 2007-02-07 | 2007-02-08 | 67 | 0d |  | 信息系统 | 8h |
| 70 | 3.5.2 | 确定项目/可交付结果的基准 |  | 1d? | 2007-02-08 | 2007-02-09 | 69 | 0d |  | 信息系统 | 8h |
| 71 | 3.5.3 | 制定下一个阶段的日程 |  | 1d? | 2007-02-09 | 2007-02-12 | 70 | 0d |  | 信息系统 [50%]; 会计 [50%] | 5.33h |
| 72 | 3.5.4 | 与项目管理委员会一起审阅项目状态 |  | 1d? | 2007-02-12 | 2007-02-13 | 71 | 0d |  | 行政管理人员; 信息系统; 会计 | 12h |
| 73 | 3.6 | 完成程序包集成设计 | milestone | 0d | 2007-02-13 | 2007-02-13 | 72 | 0d |  |  |  |
| 74 | 4 | **程序包集成** |  | 24.5d? | 2007-02-13 | 2007-03-19 |  | 0d |  |  | 312h |
| 75 | 4.1 | **生成迭代计划** |  | 3d? | 2007-02-13 | 2007-02-16 |  | 0d |  |  | 32h |
| 76 | 4.1.1 | 确认技术体系结构 |  | 1d? | 2007-02-13 | 2007-02-14 | 73 | 0d |  | 信息系统 | 8h |
| 77 | 4.1.2 | 确定迭代和内部版本 |  | 1d? | 2007-02-14 | 2007-02-15 | 76 | 0d |  | 信息系统 | 8h |
| 78 | 4.1.3 | 修改测试事例 |  | 1d? | 2007-02-15 | 2007-02-16 | 77 | 0d |  | 信息系统; 会计 | 16h |
| 79 | 4.2 | **集成生成** |  | 4.5d? | 2007-02-16 | 2007-02-22 |  | 0d |  |  | 56h |
| 80 | 4.2.1 | 生成报告 |  | 1d? | 2007-02-16 | 2007-02-19 | 78 | 0d |  | 信息系统 | 8h |
| 81 | 4.2.2 | 设计和生成迁移组件 |  | 1d? | 2007-02-19 | 2007-02-20 | 80 | 0d |  | 信息系统 | 8h |
| 82 | 4.2.3 | 设计和生成外部接口 |  | 1d? | 2007-02-20 | 2007-02-21 | 81 | 35.5d |  | 信息系统 | 8h |
| 83 | 4.2.4 | 优化性能 |  | 1d? | 2007-02-20 | 2007-02-21 | 81 | 35.5d |  | 信息系统 | 8h |
| 84 | 4.2.5 | 完成单元/整体测试 |  | 1d? | 2007-02-19 | 2007-02-20 | 81SS+5% | 0d |  | 信息系统 | 8h |
| 85 | 4.2.6 | 审阅和确定内部版本基准 |  | 1d? | 2007-02-20 | 2007-02-21 | 84 | 0d |  | 信息系统 | 8h |
| 86 | 4.2.7 | 交付内部测试版本 |  | 1d? | 2007-02-21 | 2007-02-22 | 85 | 0d |  | 信息系统 | 8h |

| ID | WBS | Task | Type | Duration | Start | Finish | Predecessors | Total slack | Resources | Work |
| --- | --- | --- | --- | --- | --- | --- | --- | --- | --- | --- |
| 87 | 4.3 | **系统测试设计和开发** |  | 2d? | 2007-02-22 | 2007-02-26 |  | 0d |  | 32h |
| 88 | 4.3.1 | 确定测试脚本 |  | 1d? | 2007-02-22 | 2007-02-23 | 86 | 0d | 信息系统 | 8h |
| 89 | 4.3.2 | 审阅测试事例/要求范围 |  | 1d? | 2007-02-23 | 2007-02-26 | 88 | 32d | 信息系统 | 8h |
| 90 | 4.3.3 | 开发自动执行的脚本 |  | 1d? | 2007-02-22 | 2007-02-23 | 88SS | 33d | 信息系统 | 8h |
| 91 | 4.3.4 | 建立外部测试数据集 |  | 1d? | 2007-02-23 | 2007-02-26 | 88 | 0d | 信息系统 | 8h |
| 92 | 4.4 | **系统测试执行** |  | 3d? | 2007-02-26 | 2007-03-01 |  | 0d |  | 24h |
| 93 | 4.4.1 | 执行测试并记录结果 |  | 1d? | 2007-02-26 | 2007-02-27 | 91 | 0d | 信息系统 | 8h |
| 94 | 4.4.2 | 研究意外结果 |  | 1d? | 2007-02-27 | 2007-02-28 | 93 | 0d | 信息系统 | 8h |
| 95 | 4.4.3 | 评估、区分优先次序和计划测试更改 |  | 1d? | 2007-02-28 | 2007-03-01 | 94 | 0d | 信息系统 | 8h |
| 96 | 4.5 | **迭代审阅** |  | 2d? | 2007-03-01 | 2007-03-05 |  | 0d |  | 32h |
| 97 | 4.5.1 | 审阅当前迭代的系统测试结果 |  | 1d? | 2007-03-01 | 2007-03-02 | 95 | 0d | 信息系统; 会计 | 16h |
| 98 | 4.5.2 | 确认将来迭代的范围 |  | 1d? | 2007-03-02 | 2007-03-05 | 97 | 0d | 信息系统; 会计 | 16h |
| 99 | 4.6 | **验收测试** |  | 6d? | 2007-03-05 | 2007-03-13 |  | 0d |  | 88h |
| 100 | 4.6.1 | 设置验收测试环境 |  | 1d? | 2007-03-05 | 2007-03-06 | 98 | 0d | 信息系统 | 8h |
| 101 | 4.6.2 | 创建验收测试脚本 |  | 1d? | 2007-03-06 | 2007-03-07 | 100 | 0d | 信息系统; 会计 | 16h |
| 102 | 4.6.3 | 执行验收测试并记录结果 |  | 1d? | 2007-03-07 | 2007-03-08 | 101 | 0d | 信息系统; 会计 | 16h |
| 103 | 4.6.4 | 根据验收测试结果更新系统 |  | 1d? | 2007-03-08 | 2007-03-09 | 102 | 0d | 信息系统; 会计 | 16h |
| 104 | 4.6.5 | 重新执行验收测试并记录结果 |  | 1d? | 2007-03-09 | 2007-03-12 | 103 | 0d | 信息系统; 会计 | 16h |
| 105 | 4.6.6 | 获取对系统的签字认可 |  | 1d? | 2007-03-12 | 2007-03-13 | 104 | 0d | 信息系统; 会计 | 16h |
| 106 | 4.7 | 完成程序包实施 | milestone | 0d | 2007-03-13 | 2007-03-13 | 105 | 0d |  |  |
| 107 | 4.8 | **最终确定程序包集成阶段** |  | 4d? | 2007-03-13 | 2007-03-19 |  | 0d |  | 48h |
| 108 | 4.8.1 | 制定要求可跟踪性模式 |  | 1d? | 2007-03-13 | 2007-03-14 | 106 | 0d | 信息系统; 会计 | 16h |
| 109 | 4.8.2 | 确定项目/可交付结果的基准 |  | 1d? | 2007-03-14 | 2007-03-15 | 108 | 0d | 信息系统; 会计 | 16h |
| 110 | 4.8.3 | 制定下一个阶段的日程 |  | 1d? | 2007-03-15 | 2007-03-16 | 109 | 0d | 信息系统; 会计 | 16h |
| 111 | 4.8.4 | 与项目管理委员会一起审阅项目状态 |  | 1d? | 2007-03-16 | 2007-03-19 | 110 | 0d |  |  |

| ID | WBS | Task | Type | Duration | Start | Finish | Predecessors | Total slack | Resources | Work |
| --- | --- | --- | --- | --- | --- | --- | --- | --- | --- | --- |
| 112 | 5 | **程序包部署** |  | 17d? | 2007-03-19 | 2007-04-11 |  | 0d |  | 176h |
| 113 | 5.1 | **教育开发** |  | 4d? | 2007-03-19 | 2007-03-23 |  | 0d |  | 56h |
| 114 | 5.1.1 | 设置培训环境 |  | 1d? | 2007-03-19 | 2007-03-20 | 111 | 0d | 信息系统 | 8h |
| 115 | 5.1.2 | 创建应用程序用户手册 |  | 1d? | 2007-03-20 | 2007-03-21 | 114 | 0d | 信息系统; 会计 | 16h |
| 116 | 5.1.3 | 创建管理员手册 |  | 1d? | 2007-03-21 | 2007-03-22 | 115 | 0d | 信息系统; 会计 | 16h |
| 117 | 5.1.4 | 编写培训材料 |  | 1d? | 2007-03-22 | 2007-03-23 | 116 | 0d | 信息系统; 会计 | 16h |
| 118 | 5.2 | **准备程序包部署** |  | 6d? | 2007-03-23 | 2007-04-02 |  | 0d |  | 48h |
| 119 | 5.2.1 | 制定后台日程安排过程 |  | 1d? | 2007-03-23 | 2007-03-26 | 117 | 0d | 信息系统 | 8h |
| 120 | 5.2.2 | 创建生产测试脚本 |  | 1d? | 2007-03-26 | 2007-03-27 | 119 | 0d | 信息系统 | 8h |
| 121 | 5.2.3 | 审阅和编制技术实施计划 |  | 1d? | 2007-03-27 | 2007-03-28 | 119, 120 | 0d | 信息系统 | 8h |
| 122 | 5.2.4 | 建立技术环境 |  | 1d? | 2007-03-28 | 2007-03-29 | 121 | 0d | 信息系统 | 8h |
| 123 | 5.2.5 | 进行部署简介 |  | 1d? | 2007-03-29 | 2007-03-30 | 122 | 0d | 信息系统 | 8h |
| 124 | 5.2.6 | 进行培训 |  | 1d? | 2007-03-30 | 2007-04-02 | 123 | 7d | 会计 | 8h |
| 125 | 5.2.7 | 完成过程审阅 |  | 1d? | 2007-03-30 | 2007-04-02 | 123 | 0d |  |  |
| 126 | 5.3 | **安装和移交** |  | 5d? | 2007-04-02 | 2007-04-09 |  | 0d |  | 40h |
| 127 | 5.3.1 | 安装应用软件 |  | 1d? | 2007-04-02 | 2007-04-03 | 125 | 0d | 信息系统 | 8h |
| 128 | 5.3.2 | 转换静态数据并获取新数据 |  | 1d? | 2007-04-03 | 2007-04-04 | 127 | 0d | 信息系统 | 8h |
| 129 | 5.3.3 | 转换动态数据 |  | 1d? | 2007-04-03 | 2007-04-04 | 127 | 0d | 信息系统 | 8h |
| 130 | 5.3.4 | 进行生产测试 |  | 1d? | 2007-04-04 | 2007-04-05 | 128, 129 | 0d | 信息系统 | 8h |
| 131 | 5.3.5 | 转换到新应用程序 |  | 1d? | 2007-04-05 | 2007-04-06 | 130 | 0d | 信息系统 | 8h |
| 132 | 5.3.6 | 创建维护手册 |  | 1d? | 2007-04-06 | 2007-04-09 | 131 | 0d |  |  |
| 133 | 5.4 | **最终确定部署阶段** |  | 2d? | 2007-04-09 | 2007-04-11 |  | 0d |  | 32h |
| 134 | 5.4.1 | 举行经验教训会议 |  | 1d? | 2007-04-09 | 2007-04-10 | 132 | 0d | 信息系统; 会计 | 16h |
| 135 | 5.4.2 | 关闭项目文件 |  | 1d? | 2007-04-10 | 2007-04-11 | 134 | 0d | 信息系统; 会计 | 16h |
| 136 | 5.5 | 完成程序包部署 | milestone | 0d | 2007-04-11 | 2007-04-11 | 135 | 0d |  |  |
| 137 | 6 | 完成项目 | milestone | 0d | 2007-04-11 | 2007-04-11 | 136 | 0d |  |  |
