# 客户反馈监控

Schedule from MS Project, 2007-01-01 to 2007-01-25.

## Calendars

- 标准: Mon-Fri 08:00-12:00, 13:00-17:00; Sat-Sun off.

## Resources

| Resource |
| --- |
| 产品经理 |
| 数据分析人员 |
| 客户代表 |
| 客户服务经理 |

## Schedule

| ID | WBS | Task | Type | Duration | Start | Finish | Predecessors | Total slack | Free slack | Resources | Work |
| --- | --- | --- | --- | --- | --- | --- | --- | --- | --- | --- | --- |
| 1 | 1 | 阅读说明此模板用途的注释 |  | 1d? | 2007-01-01 | 2007-01-01 |  | 0d |  |  |  |
| 2 | 2 | **开发客户反馈收集流程** |  | 5d? | 2007-01-02 | 2007-01-08 |  | 3d |  |  | 120h |
| 3 | 2.1 | **定义客户反馈来源** |  | 1d? | 2007-01-02 | 2007-01-02 |  | 3d |  |  | 48h |
| 4 | 2.1.1 | 确定客户自发反馈来源 |  | 1d? | 2007-01-02 | 2007-01-02 | 1 | 3d | 0d | 产品经理; 数据分析人员 | 16h |
| 5 | 2.1.2 | 确定受邀客户反馈来源 |  | 1d? | 2007-01-02 | 2007-01-02 | 1 | 3d | 0d | 产品经理; 数据分析人员 | 16h |
| 6 | 2.1.3 | 确定客户反馈的内部和竞争性来源 |  | 1d? | 2007-01-02 | 2007-01-02 | 1 | 3d | 0d | 产品经理; 数据分析人员 | 16h |
| 7 | 2.2 | 确定数据收集方法 |  | 1d? | 2007-01-03 | 2007-01-03 | 4, 5, 6 | 3d | 0d | 数据分析人员 | 8h |
| 8 | 2.3 | **确定数据分析方法** |  | 3d? | 2007-01-04 | 2007-01-08 |  | 3d |  | 数据分析人员 | 24h |
| 9 | 2.3.1 | 确定合适的数据分析方法 |  | 1d? | 2007-01-04 | 2007-01-04 | 7 | 3d | 0d |  |  |
| 10 | 2.3.2 | 制定执行分析的计划和日程表 |  | 1d? | 2007-01-05 | 2007-01-05 | 9 | 3d | 0d |  |  |
| 11 | 2.3.3 | 将制定的分析日程表纳入此日程表 |  | 1d? | 2007-01-08 | 2007-01-08 | 10 | 3d | 0d |  |  |
| 12 | 2.4 | 完成对反馈的收集和分析流程的设计 | milestone | 0d | 2007-01-08 | 2007-01-08 | 11 | 3d |  |  |  |
| 13 | 2.5 | **设计客户问题响应流程** |  | 5d? | 2007-01-02 | 2007-01-08 |  | 3d |  |  | 40h |
| 14 | 2.5.1 | 设计客户问题跟进方法 |  | 1d? | 2007-01-02 | 2007-01-02 | 1 | 3d | 0d | 客户服务经理 | 8h |
| 15 | 2.5.2 | 确定负责处理不满客户的资源 |  | 1d? | 2007-01-03 | 2007-01-03 | 14 | 3d | 0d | 客户服务经理 | 8h |
| 16 | 2.5.3 | 定义问题解决流程 |  | 1d? | 2007-01-04 | 2007-01-04 | 15 | 3d | 0d | 客户服务经理 | 8h |
| 17 | 2.5.4 | 指定负责解决客户问题的资源 |  | 1d? | 2007-01-05 | 2007-01-05 | 16 | 3d | 0d | 客户服务经理 | 8h |
| 18 | 2.5.5 | 定义客户跟进流程 |  | 1d? | 2007-01-08 | 2007-01-08 | 17 | 3d | 0d | 客户服务经理 | 8h |
| 19 | 2.5.6 | 完成客户问题响应流程设计 | milestone | 0d | 2007-01-08 | 2007-01-08 | 18 | 3d |  |  |  |
| 20 | 3 | **设计客户反馈监控流程** |  | 8d? | 2007-01-02 | 2007-01-11 |  | 0d |  |  | 64h |
| 21 | 3.1 | 获取客户满意度目标 |  | 1d? | 2007-01-02 | 2007-01-02 | 1 | 0d |  | 产品经理 | 8h |
| 22 | 3.2 | 获取产品销售目标 |  | 1d? | 2007-01-02 | 2007-01-02 | 1 | 0d |  | 产品经理 | 8h |
| 23 | 3.3 | 研究评估客户满意度和销售目标的备用方法 |  | 1d? | 2007-01-03 | 2007-01-03 | 21, 22 | 0d |  | 产品经理; 数据分析人员 | 16h |
| 24 | 3.4 | 对每种备用方法进行财务分析 |  | 1d? | 2007-01-04 | 2007-01-04 | 23 | 0d |  | 产品经理 | 8h |
| 25 | 3.5 | 拟定总体预算 |  | 1d? | 2007-01-05 | 2007-01-05 | 24 | 0d |  |  |  |
| 26 | 3.6 | 向管理层提交建议 |  | 1d? | 2007-01-08 | 2007-01-08 | 25 | 0d |  | 产品经理 | 8h |
| 27 | 3.7 | 确定反馈收集方案和载体 |  | 1d? | 2007-01-09 | 2007-01-09 | 26 | 0d |  | 数据分析人员 | 8h |
| 28 | 3.8 | 制定反馈结果内部交流计划 |  | 1d? | 2007-01-10 | 2007-01-10 | 27 | 0d |  | 产品经理 | 8h |
| 29 | 3.9 | 获得管理层对计划和预算的签字认可 |  | 1d? | 2007-01-11 | 2007-01-11 | 28 | 0d |  |  |  |
| 30 | 3.10 | 完成客户反馈方案设计 | milestone | 0d | 2007-01-11 | 2007-01-11 | 29 | 0d |  |  |  |

Notes:
- 1: 此模板的用途是在流程开发中对用户进行指导，以便持续地改进对客户反馈的监控工作。此模板的重点放在对收集的反馈的监控流程，而对数据收集的指导则很有限。 / 根据产品或服务类型以及销售方式的不同，客户反馈的收集方式也有所不同。除传统方式的调查、意见卡以及重点小组外，获取客户需求信息的方式还有多种。也可以考虑使用以下方法: 询问员工(他们常与客户交谈，因此知道客户所需)；关注竞争对手(推测他们销售的产品以及人们喜欢他们产品的哪些方面)；编档(分析内部数据，查看哪些产品畅销，哪些产品滞销，并查看所收到的投诉或请求)。
- 2: 此部分仅包含了有限的数据收集方法指导。您可查阅与此主题相关的完整方法。
- 4: 与员工交谈以听取客户意见；建立收集信函，以及将用户发来的电子邮件或电话交谈编档。
- 5: 考虑使用传统的调查、意见卡以及重点小组
- 6: 获取客户需求信息的方法有多种。还应该考虑以下方法: 询问员工(他们常与客户交谈，因此知道客户所需)；关注竞争对手(推测他们销售的产品以及人们喜欢他们产品的哪些方面)；审核内部衡量标准(分析内部数据，查看哪些产品畅销，哪些产品滞销，并查看所收到的投诉或请求)。
- 8: 此模板的目换是收集公司内部使用的反馈。 / 如果要直接用在营销活动中收集反馈，则可能需要调整所用的收集和分析方法。本部分将考虑这些调整要求，并将其纳入计划。
- 9: 数据类型和收集方式不同，数据分析方式也会有所不同。可以参考六西格玛以及 TQM 等方法，找出在统计学意义上合适有效的方法。
- 10: 所选方法不同，计划和日程可能会大相径庭。
- 11: 确定必要的时间安排和里程碑，以便将分析计划纳入此日程，并进行添加，以便可以管理总体日程影响。
- 21: 产品的客户满意度和销售目标都是客户反馈成效的衡量标准，认识到这一点很重要。
- 22: 产品的客户满意度和销售目标都是客户反馈成效的衡量标准，认识到这一点很重要。

| ID | WBS | Task | Type | Duration | Start | Finish | Predecessors | Total slack | Resources | Work |
| --- | --- | --- | --- | --- | --- | --- | --- | --- | --- | --- |
| 31 | 4 | **部署反馈方案** |  | 3d? | 2007-01-12 | 2007-01-16 |  | 0d |  | 24h |
| 32 | 4.1 | 为所有反馈来源实施数据收集方法 |  | 1d? | 2007-01-12 | 2007-01-12 | 12, 19, 30 | 0d | 客户服务经理 | 8h |
| 33 | 4.2 | 实施客户响应流程 |  | 1d? | 2007-01-15 | 2007-01-15 | 32 | 0d | 客户服务经理 | 8h |
| 34 | 4.3 | 实施监控流程 |  | 1d? | 2007-01-16 | 2007-01-16 | 33 | 0d | 客户服务经理 | 8h |
| 35 | 4.4 | 完成部署工作 | milestone | 0d | 2007-01-16 | 2007-01-16 | 34 | 0d |  |  |
| 36 | 5 | **监控客户反馈** |  | 7d? | 2007-01-17 | 2007-01-25 |  | 0d |  | 104h |
| 37 | 5.1 | 从所有来源收集数据 |  | 0.5d? | 2007-01-17 | 2007-01-17 | 35 | 0.5d | 数据分析人员; 客户代表 | 8h |
| 38 | 5.2 | 监控支持能力 |  | 1d? | 2007-01-17 | 2007-01-17 | 35 | 0d | 客户服务经理 | 8h |
| 39 | 5.3 | 分析客户反馈: 查找模式和问题区域 |  | 1d? | 2007-01-18 | 2007-01-18 | 37, 38 | 0d | 产品经理; 数据分析人员 | 16h |
| 40 | 5.4 | 评估方案实施期间的客户满意度水平 |  | 1d? | 2007-01-19 | 2007-01-19 | 39 | 0d | 产品经理; 数据分析人员 | 16h |
| 41 | 5.5 | 审核客户跟进: 评估成功率和客户响应率 |  | 1d? | 2007-01-22 | 2007-01-22 | 40 | 0d | 产品经理; 数据分析人员 | 16h |
| 42 | 5.6 | 审核客户问题解决情况 |  | 1d? | 2007-01-23 | 2007-01-23 | 41 | 0d | 产品经理; 客户服务经理 | 16h |
| 43 | 5.7 | 向产品工作组提交反馈 |  | 1d? | 2007-01-24 | 2007-01-24 | 42 | 0d | 产品经理 | 8h |
| 44 | 5.8 | 确立方案的持续改进周期 |  | 1d? | 2007-01-25 | 2007-01-25 | 43 | 0d | 产品经理; 客户服务经理 | 16h |
| 45 | 6 | 完成客户反馈监控方案 | milestone | 0d | 2007-01-25 | 2007-01-25 | 42, 44 | 0d |  |  |
