# 客户服务改进

Schedule from MS Project, 2007-01-01 to 2007-04-05.

## Calendars

- 标准: Mon-Fri 08:00-12:00, 13:00-17:00; Sat-Sun off.

## Resources

| Resource |
| --- |
| 客户服务工作组 |
| 客户服务负责人 |
| 技术负责人 |
| 内容开发人员 |
| 讲师 |
| 后勤人员 |

## Schedule

| ID | WBS | Task | Type | Duration | Start | Finish | Predecessors | Total slack | Resources | Work |
| --- | --- | --- | --- | --- | --- | --- | --- | --- | --- | --- |
| 1 | 1 | 阅读对此模板用途进行说明的注释 | milestone | 0d | 2007-01-01 | 2007-01-01 |  | 0d |  |  |
| 2 | 2 | **初始评估** |  | 5d? | 2007-01-01 | 2007-01-05 |  | 0d |  | 40h |
| 3 | 2.1 | **执行产品审核** |  | 5d? | 2007-01-01 | 2007-01-05 |  | 0d |  | 40h |
| 4 | 2.1.1 | 确定典型产品使用环境 |  | 1d? | 2007-01-01 | 2007-01-01 | 1 | 0d | 客户服务工作组 | 8h |
| 5 | 2.1.2 | 确定典型客户类型 |  | 1d? | 2007-01-02 | 2007-01-02 | 4 | 0d | 客户服务工作组 | 8h |
| 6 | 2.1.3 | 确定预期产品问题点 |  | 1d? | 2007-01-03 | 2007-01-03 | 5 | 0d | 客户服务工作组 | 8h |
| 7 | 2.1.4 | 确定产品点解决方案 |  | 1d? | 2007-01-04 | 2007-01-04 | 6 | 0d | 客户服务工作组 | 8h |
| 8 | 2.1.5 | 将产品审查结果编档 |  | 1d? | 2007-01-05 | 2007-01-05 | 7 | 0d | 客户服务工作组 | 8h |
| 9 | 2.1.6 | 完成产品审核 | milestone | 0d | 2007-01-05 | 2007-01-05 | 8 | 0d |  |  |
| 10 | 3 | **服务规划** |  | 5d? | 2007-01-08 | 2007-01-12 |  | 0d |  | 48h |
| 11 | 3.1 | **设计支持服务** |  | 4d? | 2007-01-08 | 2007-01-11 |  | 0d |  | 48h |
| 12 | 3.1.1 | **设计客户服务联系人方案** |  | 1d? | 2007-01-08 | 2007-01-08 |  | 0d |  | 24h |
| 13 | 3.1.1.1 | 联机支持 |  | 1d? | 2007-01-08 | 2007-01-08 | 9 | 0d | 客户服务工作组 | 8h |
| 14 | 3.1.1.2 | 电话支持 |  | 1d? | 2007-01-08 | 2007-01-08 | 9 | 0d | 客户服务工作组 | 8h |
| 15 | 3.1.1.3 | 现场支持 |  | 1d? | 2007-01-08 | 2007-01-08 | 9 | 0d | 客户服务工作组 | 8h |
| 16 | 3.1.1.4 | 完成客户服务联系人方案设计 | milestone | 0d | 2007-01-08 | 2007-01-08 | 15, 13, 14 | 0d |  |  |
| 17 | 3.1.2 | **制定客户服务级别(免费服务和有偿服务)** |  | 3d? | 2007-01-09 | 2007-01-11 |  | 0d |  | 24h |
| 18 | 3.1.2.1 | 确定要解决的问题类型 |  | 1d? | 2007-01-09 | 2007-01-09 | 16 | 0d | 客户服务工作组 | 8h |
| 19 | 3.1.2.2 | 确定服务提供选项 |  | 1d? | 2007-01-10 | 2007-01-10 | 18 | 0d | 客户服务工作组 | 8h |
| 20 | 3.1.2.3 | 确定各种支持选项所需的技能集 |  | 1d? | 2007-01-11 | 2007-01-11 | 19 | 0d | 客户服务工作组 | 8h |
| 21 | 3.1.2.4 | 完成客户服务级别设计 | milestone | 0d | 2007-01-11 | 2007-01-11 | 20 | 0d |  |  |
| 22 | 3.1.3 | 完成支持服务设计工作 | milestone | 0d | 2007-01-11 | 2007-01-11 | 21 | 0d |  |  |
| 23 | 3.2 | 完成服务规划和设计 |  | 1d? | 2007-01-12 | 2007-01-12 | 22 | 0d |  |  |
| 24 | 4 | **制定服务提供基础架构规划** |  | 34.5d? | 2007-01-08 | 2007-02-23 |  | 5d |  | 256h |
| 25 | 4.1 | **资源需求** |  | 3d? | 2007-01-15 | 2007-01-17 |  | 0d |  | 24h |
| 26 | 4.1.1 | 估计客户支持需求(所有选项) |  | 1d? | 2007-01-15 | 2007-01-15 | 23 | 0d | 客户服务负责人 | 8h |
| 27 | 4.1.2 | 估计资源需求 |  | 1d? | 2007-01-16 | 2007-01-16 | 26 | 0d | 客户服务负责人 | 8h |
| 28 | 4.1.3 | 估计雇用新员工的工作 |  | 1d? | 2007-01-17 | 2007-01-17 | 27 | 0d | 客户服务负责人 | 8h |
| 29 | 4.1.4 | 完成资源规划 | milestone | 0d | 2007-01-17 | 2007-01-17 | 28 | 0d |  |  |

Notes:
- 1: 此模板用于在建立新产品支持时，对客户服务组织提供支持。这个主题比较复杂，可能要求创建多个日程以涵盖所有组成部分。为简化起见，某些区域仅标记为一项任务，需要在独立的计划中加以详尽说明。技术基础架构即为其中一例。我们建议您为技术开发创建独立的日程，以便支持新产品的引进。有多个技术模板示例可用于此目的。

| ID | WBS | Task | Type | Duration | Start | Finish | Predecessors | Total slack | Resources | Work |
| --- | --- | --- | --- | --- | --- | --- | --- | --- | --- | --- |
| 30 | 4.2 | **培训与入职准备** |  | 34.5d? | 2007-01-08 | 2007-02-23 |  | 0d |  | 216h |
| 31 | 4.2.1 | **培训需求评估** |  | 9.5d? | 2007-01-08 | 2007-01-19 |  | 0d |  | 24h |
| 32 | 4.2.1.1 | 审核产品审核阶段的产量 |  | 1d? | 2007-01-08 | 2007-01-08 | 9 | 8d | 内容开发人员 | 8h |
| 33 | 4.2.1.2 | 审核支持资源的预计技能集 |  | 1d? | 2007-01-18 | 2007-01-18 | 29 | 0d | 内容开发人员 | 8h |
| 34 | 4.2.1.3 | 确定特定于产品的培训需求 |  | 0.5d? | 2007-01-19 | 2007-01-19 | 33, 32 | 0d | 客户服务负责人; 内容开发人员 | 8h |
| 35 | 4.2.1.4 | 完成培训需求评估工作 | milestone | 0d | 2007-01-19 | 2007-01-19 | 34 | 0d |  |  |
| 36 | 4.2.2 | **培训规划** |  | 25d? | 2007-01-19 | 2007-02-23 |  | 0d |  | 192h |
| 37 | 4.2.2.1 | **内容开发规划** |  | 8d? | 2007-01-19 | 2007-01-31 |  | 0d |  | 64h |
| 38 | 4.2.2.1.1 | 确定培训的提供方法 |  | 1d? | 2007-01-19 | 2007-01-22 | 35 | 0d | 内容开发人员 | 8h |
| 39 | 4.2.2.1.2 | 确定培训内容的组成要素 |  | 1d? | 2007-01-22 | 2007-01-23 | 38 | 0d | 内容开发人员 | 8h |
| 40 | 4.2.2.1.3 | 确定可审核培训材料的内部资源 |  | 1d? | 2007-01-23 | 2007-01-24 | 39 | 0d | 客户服务负责人 | 8h |
| 41 | 4.2.2.1.4 | 确定培训课程主题 |  | 1d? | 2007-01-24 | 2007-01-25 | 40 | 0d | 内容开发人员 | 8h |
| 42 | 4.2.2.1.5 | 确定培训课程数量 |  | 1d? | 2007-01-25 | 2007-01-26 | 41 | 0d | 内容开发人员 | 8h |
| 43 | 4.2.2.1.6 | 设计学员材料 |  | 1d? | 2007-01-26 | 2007-01-29 | 42 | 0d | 内容开发人员 | 8h |
| 44 | 4.2.2.1.7 | 拟定培训方案/课程说明 |  | 1d? | 2007-01-29 | 2007-01-30 | 43 | 0d | 内容开发人员 | 8h |
| 45 | 4.2.2.1.8 | 拟定内容开发预算 |  | 1d? | 2007-01-30 | 2007-01-31 | 44 | 0d | 内容开发人员 | 8h |
| 46 | 4.2.2.1.9 | 完成内容开发规划 | milestone | 0d | 2007-01-31 | 2007-01-31 | 45 | 0d |  |  |
| 47 | 4.2.2.2 | **培训提供规划** |  | 14d? | 2007-01-31 | 2007-02-20 |  | 0d |  | 104h |
| 48 | 4.2.2.2.1 | **评估讲师需求和选项** |  | 8d? | 2007-01-31 | 2007-02-12 |  | 0d |  | 64h |
| 49 | 4.2.2.2.1.1 | 确定可作为备选讲师的内部资源 |  | 1d? | 2007-01-31 | 2007-02-01 | 46 | 0d | 客户服务负责人 | 8h |
| 50 | 4.2.2.2.1.2 | 确定是否需要其他讲师 |  | 1d? | 2007-02-01 | 2007-02-02 | 49 | 0d | 客户服务负责人 | 8h |
| 51 | 4.2.2.2.1.3 | **审核外包选项 - 培训提供** |  | 6d? | 2007-02-02 | 2007-02-12 |  | 0d |  | 48h |
| 52 | 4.2.2.2.1.3.1 | 审核潜在供应商的专业技能 |  | 1d? | 2007-02-02 | 2007-02-05 | 50 | 0d | 客户服务负责人 | 8h |
| 53 | 4.2.2.2.1.3.2 | 审核成本 |  | 1d? | 2007-02-05 | 2007-02-06 | 52 | 0d | 客户服务负责人 | 8h |
| 54 | 4.2.2.2.1.3.3 | 审核服务级别 |  | 1d? | 2007-02-06 | 2007-02-07 | 53 | 0d | 客户服务负责人 | 8h |
| 55 | 4.2.2.2.1.3.4 | 审核客户参考信息 |  | 1d? | 2007-02-07 | 2007-02-08 | 54 | 0d | 客户服务负责人 | 8h |
| 56 | 4.2.2.2.1.3.5 | 确定外部讲师到位所需时间 |  | 1d? | 2007-02-08 | 2007-02-09 | 55 | 0d | 客户服务负责人 | 8h |
| 57 | 4.2.2.2.1.3.6 | 进行外包决策 |  | 1d? | 2007-02-09 | 2007-02-12 | 56 | 0d | 客户服务负责人 | 8h |
| 58 | 4.2.2.2.1.3.7 | 完成外包审核 | milestone | 0d | 2007-02-12 | 2007-02-12 | 57 | 0d |  |  |
| 59 | 4.2.2.2.1.4 | 完成讲师需求评估 | milestone | 0d | 2007-02-12 | 2007-02-12 | 58 | 0d |  |  |

| ID | WBS | Task | Type | Duration | Start | Finish | Predecessors | Total slack | Free slack | Resources | Work |
| --- | --- | --- | --- | --- | --- | --- | --- | --- | --- | --- | --- |
| 60 | 4.2.2.2.2 | **培训提供后勤** |  | 5d? | 2007-02-12 | 2007-02-19 |  | 0d |  |  | 32h |
| 61 | 4.2.2.2.2.1 | 确定培训提供日程 |  | 1d? | 2007-02-12 | 2007-02-13 | 59 | 0d |  | 客户服务负责人 | 8h |
| 62 | 4.2.2.2.2.2 | 确定培训提供地点 |  | 1d? | 2007-02-13 | 2007-02-14 | 61 | 0d |  | 客户服务负责人 | 8h |
| 63 | 4.2.2.2.2.3 | 审核外包选项 - 事件后勤 |  | 1d? | 2007-02-14 | 2007-02-15 | 62 | 0d |  | 客户服务负责人 | 8h |
| 64 | 4.2.2.2.2.4 | 编制培训提供预算 |  | 1d? | 2007-02-15 | 2007-02-16 | 63 | 0d |  | 客户服务负责人 | 8h |
| 65 | 4.2.2.2.2.5 | 完成培训提供后勤工作 |  | 1d? | 2007-02-16 | 2007-02-19 | 64 | 0d |  |  |  |
| 66 | 4.2.2.2.3 | 根据内容开发和培训提供阶段的结果，制定培训计划 |  | 1d? | 2007-02-19 | 2007-02-20 | 65 | 0d |  | 客户服务负责人 | 8h |
| 67 | 4.2.2.2.4 | 完成培训提供规划 | milestone | 0d | 2007-02-20 | 2007-02-20 | 66 | 0d |  |  |  |
| 68 | 4.2.2.3 | **最终确定培训规划** |  | 3d? | 2007-02-20 | 2007-02-23 |  | 0d |  |  | 24h |
| 69 | 4.2.2.3.1 | 拟定总体预算 |  | 1d? | 2007-02-20 | 2007-02-21 | 67 | 0d |  | 客户服务负责人 | 8h |
| 70 | 4.2.2.3.2 | 获得管理层对预算的签字认可 |  | 1d? | 2007-02-21 | 2007-02-22 | 69 | 0d |  | 客户服务负责人 | 8h |
| 71 | 4.2.2.3.3 | 获得管理层对培训计划的签字认可 |  | 1d? | 2007-02-22 | 2007-02-23 | 70 | 0d |  | 客户服务负责人 | 8h |
| 72 | 4.2.2.4 | 完成培训规划 | milestone | 0d | 2007-02-23 | 2007-02-23 | 71 | 0d |  |  |  |
| 73 | 4.3 | **技术基础架构** |  | 2d? | 2007-01-15 | 2007-01-16 |  | 43.5d |  |  | 16h |
| 74 | 4.3.1 | 制定技术基础架构计划(需要独立的项目计划) |  | 1d? | 2007-01-15 | 2007-01-15 | 23 | 43.5d | 0d | 技术负责人 | 8h |
| 75 | 4.3.2 | 确定技术预算 |  | 1d? | 2007-01-16 | 2007-01-16 | 74 | 43.5d | 0d | 技术负责人 | 8h |
| 76 | 4.3.3 | 完成技术基础架构规划 | milestone | 0d | 2007-01-16 | 2007-01-16 | 75 | 43.5d | 0d |  |  |
| 77 | 4.4 | 完成服务提供规划 | milestone | 0d | 2007-01-16 | 2007-01-16 | 76 | 56.5d |  |  |  |
| 78 | 5 | **业绩规划** |  | 3d? | 2007-01-12 | 2007-01-16 |  | 51.5d |  |  | 24h |
| 79 | 5.1 | 确定支持服务的业务目标 |  | 1d? | 2007-01-12 | 2007-01-12 | 22 | 51.5d | 0d | 客户服务负责人 | 8h |
| 80 | 5.2 | 确定成功标准 |  | 1d? | 2007-01-15 | 2007-01-15 | 79 | 51.5d | 0d | 客户服务工作组 | 8h |
| 81 | 5.3 | 确定成本效率标准 |  | 1d? | 2007-01-16 | 2007-01-16 | 80 | 51.5d | 0d | 客户服务工作组 | 8h |
| 82 | 5.4 | 完成业绩规划 | milestone | 0d | 2007-01-16 | 2007-01-16 | 81 | 51.5d | 0d |  |  |
| 83 | 6 | **制定客户服务方案** |  | 43.5d? | 2007-01-17 | 2007-03-19 |  | 13d |  |  | 188h |
| 84 | 6.1 | **开展培训/入职准备** |  | 16d? | 2007-02-23 | 2007-03-19 |  | 0d |  |  | 128h |
| 85 | 6.1.1 | **开发培训内容** |  | 9d? | 2007-02-23 | 2007-03-08 |  | 0d |  |  | 72h |
| 86 | 6.1.1.1 | 组建内容开发工作组 |  | 1d? | 2007-02-23 | 2007-02-26 | 72 | 0d |  | 客户服务负责人 | 8h |
| 87 | 6.1.1.2 | 确定角色和职责 |  | 1d? | 2007-02-26 | 2007-02-27 | 86 | 0d |  | 客户服务负责人 | 8h |
| 88 | 6.1.1.3 | 确定内容开发日程 |  | 1d? | 2007-02-27 | 2007-02-28 | 87 | 0d |  | 客户服务负责人 | 8h |

| ID | WBS | Task | Type | Duration | Start | Finish | Predecessors | Total slack | Free slack | Resources | Work |
| --- | --- | --- | --- | --- | --- | --- | --- | --- | --- | --- | --- |
| 89 | 6.1.1.4 | **确定培训内容** |  | 6d? | 2007-02-28 | 2007-03-08 |  | 0d |  |  | 48h |
| 90 | 6.1.1.4.1 | 审核现有知识产权 |  | 1d? | 2007-02-28 | 2007-03-01 | 88 | 0d |  | 内容开发人员 | 8h |
| 91 | 6.1.1.4.2 | 开发测试版内容 |  | 1d? | 2007-03-01 | 2007-03-02 | 90 | 0d |  | 内容开发人员 | 8h |
| 92 | 6.1.1.4.3 | 对培训内容执行主题专家审核 |  | 1d? | 2007-03-02 | 2007-03-05 | 91 | 0d |  | 内容开发人员 | 8h |
| 93 | 6.1.1.4.4 | 修订并更新内容 |  | 1d? | 2007-03-05 | 2007-03-06 | 92 | 0d |  | 内容开发人员 | 8h |
| 94 | 6.1.1.4.5 | 创建用于客户支持的“速查表”和其他学习资源 |  | 1d? | 2007-03-06 | 2007-03-07 | 93 | 0d |  | 内容开发人员 | 8h |
| 95 | 6.1.1.4.6 | 获得最终内容批准 |  | 1d? | 2007-03-07 | 2007-03-08 | 94 | 0d |  | 客户服务负责人 | 8h |
| 96 | 6.1.1.5 | 完成内容开发 | milestone | 0d | 2007-03-08 | 2007-03-08 | 95 | 0d |  |  |  |
| 97 | 6.1.2 | **开发培训提供引擎** |  | 7d? | 2007-03-08 | 2007-03-19 |  | 0d |  |  | 56h |
| 98 | 6.1.2.1 | 创建其他“讲师培训”学习材料 |  | 1d? | 2007-03-08 | 2007-03-09 | 96 | 0d |  | 内容开发人员 | 8h |
| 99 | 6.1.2.2 | 确定能力考试内容 |  | 1d? | 2007-03-09 | 2007-03-12 | 98 | 0d |  | 内容开发人员 | 8h |
| 100 | 6.1.2.3 | 培训其他讲师 |  | 1d? | 2007-03-12 | 2007-03-13 | 99 | 0d |  | 讲师 | 8h |
| 101 | 6.1.2.4 | 准备培训场地 |  | 1d? | 2007-03-13 | 2007-03-14 | 100 | 0d |  | 后勤人员 | 8h |
| 102 | 6.1.2.5 | 创建交流计划 |  | 1d? | 2007-03-14 | 2007-03-15 | 101 | 0d |  | 客户服务负责人 | 8h |
| 103 | 6.1.2.6 | 根据培训方案中的信息提供新雇用人员 |  | 1d? | 2007-03-15 | 2007-03-16 | 102 | 0d |  | 客户服务负责人 | 8h |
| 104 | 6.1.2.7 | 将新培训计划传达给现有支持资源 |  | 1d? | 2007-03-16 | 2007-03-19 | 103 | 0d |  | 客户服务负责人 | 8h |
| 105 | 6.1.2.8 | 完成培训提供引擎开发 | milestone | 0d | 2007-03-19 | 2007-03-19 | 104 | 0d |  |  |  |
| 106 | 6.1.3 | 完成培训/入职准备开展工作 | milestone | 0d | 2007-03-19 | 2007-03-19 | 105 | 13d |  |  |  |
| 107 | 6.2 | **建立技术基础架构** |  | 2d? | 2007-01-17 | 2007-01-18 |  | 43.5d |  |  | 20h |
| 108 | 6.2.1 | 设计和开发技术解决方案(需要单独的日程) |  | 1d? | 2007-01-17 | 2007-01-17 | 76 | 43.5d | 0d | 技术负责人 | 8h |
| 109 | 6.2.2 | 测试技术基础架构 |  | 1d? | 2007-01-18 | 2007-01-18 | 108 | 43.5d | 0d | 客户服务工作组; 技术负责人; 内容开发人员 | 12h |
| 110 | 6.2.3 | 完成技术基础架构开发 | milestone | 0d | 2007-01-18 | 2007-01-18 | 109 | 54.5d |  |  |  |
| 111 | 6.3 | **制定客户服务方案** |  | 5d? | 2007-01-17 | 2007-01-23 |  | 51.5d |  |  | 40h |
| 112 | 6.3.1 | 建立客户服务方案 |  | 1d? | 2007-01-17 | 2007-01-17 | 82 | 51.5d | 0d | 客户服务工作组 | 8h |
| 113 | 6.3.2 | 执行主题专家审核 |  | 1d? | 2007-01-18 | 2007-01-18 | 112 | 51.5d | 0d | 客户服务工作组 | 8h |
| 114 | 6.3.3 | 与客户一起进行用户验收测试 |  | 1d? | 2007-01-19 | 2007-01-19 | 113 | 51.5d | 0d | 客户服务工作组 | 8h |
| 115 | 6.3.4 | 修订方案和相关流程 |  | 1d? | 2007-01-22 | 2007-01-22 | 114 | 51.5d | 0d | 客户服务工作组 | 8h |
| 116 | 6.3.5 | 获得管理层签字认可 |  | 1d? | 2007-01-23 | 2007-01-23 | 115 | 51.5d | 0d | 客户服务负责人 | 8h |
| 117 | 6.3.6 | 完成客户服务方案制定工作 | milestone | 0d | 2007-01-23 | 2007-01-23 | 116 | 51.5d |  |  |  |

| ID | WBS | Task | Type | Duration | Start | Finish | Predecessors | Total slack | Resources | Work |
| --- | --- | --- | --- | --- | --- | --- | --- | --- | --- | --- |
| 118 | 7 | **部署方案** |  | 45.5d? | 2007-01-19 | 2007-03-23 |  | 9d |  | 40h |
| 119 | 7.1 | **员工入职准备** |  | 3d? | 2007-03-19 | 2007-03-22 |  | 0d |  | 24h |
| 120 | 7.1.1 | 雇用新员工 |  | 1d? | 2007-03-19 | 2007-03-20 | 95, 105 | 0d | 客户服务负责人 | 8h |
| 121 | 7.1.2 | 培训新员工 |  | 1d? | 2007-03-20 | 2007-03-21 | 120 | 0d | 讲师 | 8h |
| 122 | 7.1.3 | 新员工合格测试 |  | 1d? | 2007-03-21 | 2007-03-22 | 121 | 0d | 客户服务负责人 | 8h |
| 123 | 7.1.4 | 完成员工入职准备培训 | milestone | 0d | 2007-03-22 | 2007-03-22 | 122 | 10d |  |  |
| 124 | 7.2 | 部署技术基础架构 |  | 1d? | 2007-01-19 | 2007-01-19 | 109 | 43.5d | 技术负责人 | 8h |
| 125 | 7.3 | 部署新客户服务方案 |  | 1d? | 2007-03-22 | 2007-03-23 | 124, 122 | 0d | 客户服务负责人 | 8h |
| 126 | 7.4 | 完成方案部署 | milestone | 0d | 2007-03-23 | 2007-03-23 | 125 | 0d |  |  |
| 127 | 8 | **产品上市后** |  | 9d? | 2007-03-23 | 2007-04-05 |  | 0d |  | 72h |
| 128 | 8.1 | **开始产品上市后准备工作** |  | 4d? | 2007-03-23 | 2007-03-29 |  | 0d |  | 32h |
| 129 | 8.1.1 | 确定成功标准 |  | 1d? | 2007-03-23 | 2007-03-26 | 126 | 0d | 客户服务工作组 | 8h |
| 130 | 8.1.2 | 确定常见问题跟踪方法和解决方案 |  | 1d? | 2007-03-26 | 2007-03-27 | 129 | 0d | 客户服务工作组 | 8h |
| 131 | 8.1.3 | 确定跟踪支持问题的方法以及产品的各个方面 |  | 1d? | 2007-03-27 | 2007-03-28 | 130 | 0d | 客户服务工作组 | 8h |
| 132 | 8.1.4 | 确定向所有支持资源分发常用解决方案的方法 |  | 1d? | 2007-03-28 | 2007-03-29 | 131 | 0d | 客户服务工作组 | 8h |
| 133 | 8.1.5 | 完成产品上市后准备工作 | milestone | 0d | 2007-03-29 | 2007-03-29 | 132 | 0d |  |  |
| 134 | 8.2 | **监控** |  | 5d? | 2007-03-29 | 2007-04-05 |  | 0d |  | 40h |
| 135 | 8.2.1 | 监控客户支持问题 - 查找常见问题 |  | 1d? | 2007-03-29 | 2007-03-30 | 133 | 0d | 客户服务工作组 | 8h |
| 136 | 8.2.2 | 汇集最佳做法(解决方案) - 分发给支持服务部门 |  | 1d? | 2007-03-30 | 2007-04-02 | 135 | 0d | 客户服务工作组 | 8h |
| 137 | 8.2.3 | 审核支持数据，确定引发支持事件最多的产品方面 |  | 1d? | 2007-04-02 | 2007-04-03 | 136 | 0d | 客户服务工作组 | 8h |
| 138 | 8.2.4 | 审核资源采取的措施，确定最有效的措施 |  | 1d? | 2007-04-03 | 2007-04-04 | 137 | 0d | 客户服务工作组 | 8h |
| 139 | 8.2.5 | 根据从客户服务方案收集到的数据修订培训材料 |  | 1d? | 2007-04-04 | 2007-04-05 | 138 | 0d | 内容开发人员 | 8h |
| 140 | 8.3 | 完成产品上市后活动 | milestone | 0d | 2007-04-05 | 2007-04-05 | 139 | 0d |  |  |
| 141 | 9 | 完成客户服务方案制定工作 | milestone | 0d | 2007-04-05 | 2007-04-05 | 140 | 0d |  |  |
