# 工程设计

Schedule from MS Project, 2007-01-01 to 2009-05-06.

## Calendars

- 标准: Mon-Fri 08:00-12:00, 13:00-17:00; Sat-Sun off.

## Resources

| Resource |
| --- |
| 设计师 |
| 项目工程师 |
| 专业工程师 |
| 成本工程师 |
| 绘图员 |
| 生产计划员 |
| 项目出资人 |

## Schedule

| ID | WBS | Task | Type | Duration | Start | Finish | Predecessors | Total slack | Free slack | Resources | Work |
| --- | --- | --- | --- | --- | --- | --- | --- | --- | --- | --- | --- |
| 1 | 1 | **可行性分析** |  | 80d | 2007-01-01 | 2007-04-20 |  | 0d |  |  | 2772h |
| 2 | 1.1 | **规划和控制** |  | 20d | 2007-01-01 | 2007-01-26 |  | 0d |  |  | 320h |
| 3 | 1.1.1 | 制定阐明项目机会的商业计划 |  | 5d | 2007-01-01 | 2007-01-05 |  | 0d |  | 项目出资人 | 40h |
| 4 | 1.1.2 | 定义项目目标和信息需求 |  | 5d | 2007-01-08 | 2007-01-12 | 3 | 0d |  | 项目出资人 | 40h |
| 5 | 1.1.3 | 确定项目目标应符合的行业标准 |  | 5d | 2007-01-15 | 2007-01-19 | 4 | 0d |  | 项目出资人; 项目工程师 | 80h |
| 6 | 1.1.4 | 制定初步的可行性分析日程和人员配备计划 |  | 5d | 2007-01-15 | 2007-01-19 | 4 | 0d |  | 项目工程师 | 40h |
| 7 | 1.1.5 | 结束初步规划 | milestone | 0d | 2007-01-19 | 2007-01-19 | 6 | 0d |  |  |  |
| 8 | 1.1.6 | 制定拨款策略 |  | 5d | 2007-01-22 | 2007-01-26 | 7 | 40d | 27d | 项目出资人 | 40h |
| 9 | 1.1.7 | 制定管理模式和人员配备计划 |  | 5d | 2007-01-22 | 2007-01-26 | 7 | 50d |  | 项目出资人; 项目工程师 | 80h |
| 10 | 1.2 | **选址** |  | 40d | 2007-01-22 | 2007-03-16 |  | 0d |  |  | 864h |
| 11 | 1.2.1 | 确定备选场地 |  | 10d | 2007-01-22 | 2007-02-02 | 7 | 0d |  | 项目出资人; 项目工程师 | 160h |
| 12 | 1.2.2 | 定义对基础设施的要求 |  | 15d | 2007-02-05 | 2007-02-23 | 21, 11 | 0d |  | 项目工程师 | 120h |
| 13 | 1.2.3 | 定义对公用事业的需求 |  | 10d | 2007-02-05 | 2007-02-16 | 21, 11 | 5d |  | 项目工程师; 专业工程师 | 160h |
| 14 | 1.2.4 | 确定项目的场地 |  | 5d | 2007-02-05 | 2007-02-09 | 21, 11 | 10d |  | 项目工程师; 专业工程师 | 80h |
| 15 | 1.2.5 | 评估行政管理和环境问题所带来的影响 |  | 10d | 2007-02-05 | 2007-02-16 | 21, 11 | 2d | 0d | 项目工程师; 专业工程师 | 160h |
| 16 | 1.2.6 | 确定需要获得的许可 |  | 3d | 2007-02-19 | 2007-02-21 | 15 | 2d |  | 项目工程师 | 24h |
| 17 | 1.2.7 | 推荐场地 |  | 10d | 2007-02-26 | 2007-03-09 | 15, 12, 13, 14, 16 | 0d |  | 项目出资人; 项目工程师 | 160h |
| 18 | 1.2.8 | 审阅场地和计划 |  | 5d | 2007-03-12 | 2007-03-16 | 17 | 0d |  |  |  |
| 19 | 1.3 | **定义范围** |  | 45d | 2007-01-22 | 2007-03-23 |  | 0d |  |  | 616h |
| 20 | 1.3.1 | 确定项目目标的大致范围 |  | 5d | 2007-01-22 | 2007-01-26 | 4, 5 | 0d |  | 项目出资人; 项目工程师 | 80h |
| 21 | 1.3.2 | 评估项目需求并制定主要研究项目列表 |  | 5d | 2007-01-29 | 2007-02-02 | 20 | 0d |  | 项目工程师; 专业工程师 | 80h |
| 22 | 1.3.3 | 开始主要项目的研究 |  | 2d | 2007-02-05 | 2007-02-06 | 21 | 8d | 0d | 专业工程师 | 16h |
| 23 | 1.3.4 | 结束主要项目的研究并提出建议 |  | 15d | 2007-02-07 | 2007-02-27 | 22 | 8d | 0d | 专业工程师 | 120h |
| 24 | 1.3.5 | 确定明确的范围 |  | 5d | 2007-02-28 | 2007-03-06 | 23 | 8d | 0d | 项目工程师; 专业工程师 | 80h |
| 25 | 1.3.6 | 准备最终的可行性分析日程 |  | 10d | 2007-03-07 | 2007-03-20 | 8, 24 | 13d |  | 项目工程师; 专业工程师 | 160h |
| 26 | 1.3.7 | 提供书面的范围信息 |  | 5d | 2007-03-19 | 2007-03-23 | 24, 18 | 10d |  | 项目工程师; 专业工程师 | 80h |

Notes:
- 1: 做出判断: / 是否进行此项目?

| ID | WBS | Task | Type | Duration | Start | Finish | Predecessors | Total slack | Free slack | Resources | Work |
| --- | --- | --- | --- | --- | --- | --- | --- | --- | --- | --- | --- |
| 27 | 1.4 | **专业支持** |  | 43d | 2007-02-07 | 2007-04-06 |  | 0d |  |  | 888h |
| 28 | 1.4.1 | 拟定可交付结果列表 |  | 6d | 2007-02-07 | 2007-02-14 | 22 | 11d | 0d | 项目工程师; 专业工程师 | 96h |
| 29 | 1.4.2 | 开始制定流程图和标准 |  | 5d | 2007-02-15 | 2007-02-21 | 28 | 17d |  | 专业工程师 | 40h |
| 30 | 1.4.3 | 开始绘制各专业图纸并拟定设备列表 |  | 11d | 2007-02-15 | 2007-03-01 | 28 | 11d |  | 项目工程师; 专业工程师 | 176h |
| 31 | 1.4.4 | 开始规划概念性布局 |  | 11d | 2007-02-15 | 2007-03-01 | 28 | 11d |  | 专业工程师; 项目工程师; 绘图员 | 92h |
| 32 | 1.4.5 | 结束制定流程图和标准 |  | 15d | 2007-03-19 | 2007-04-06 | 29, 24, 23, 18 | 0d |  | 专业工程师; 绘图员 | 240h |
| 33 | 1.4.6 | 结束绘制各专业图纸并拟定设备列表 |  | 15d | 2007-03-19 | 2007-04-06 | 30, 24, 23, 18 | 0d |  | 专业工程师; 项目工程师; 绘图员 | 124h |
| 34 | 1.4.7 | 结束规划概念性布局 |  | 15d | 2007-03-19 | 2007-04-06 | 31, 24, 23, 18 | 0d |  | 绘图员 | 120h |
| 35 | 1.5 | **结束可行性分析阶段** |  | 10d | 2007-04-09 | 2007-04-20 |  | 0d |  |  | 84h |
| 36 | 1.5.1 | 准备概念性范围报告和评估报告以供审阅 |  | 5d | 2007-04-09 | 2007-04-13 | 25, 8, 9, 26, 32, 33, 34 | 0d |  | 项目工程师; 成本工程师; 绘图员 | 44h |
| 37 | 1.5.2 | 评估商业计划，如必要则重新制定 |  | 5d | 2007-04-16 | 2007-04-20 | 36 | 0d |  | 项目出资人 | 40h |
| 38 | 1.5.3 | 可行性分析阶段结束 | milestone | 0d | 2007-04-20 | 2007-04-20 | 37 | 0d |  |  |  |
| 39 | 2 | **定义** |  | 85d | 2007-04-23 | 2007-08-17 |  | 0d |  |  | 2764h |
| 40 | 2.1 | **规划和控制** |  | 15d | 2007-04-23 | 2007-05-11 |  | 0d |  |  | 320h |
| 41 | 2.1.1 | 审阅概念性计划 |  | 5d | 2007-04-23 | 2007-04-27 | 38 | 0d |  | 项目出资人; 项目工程师 | 80h |
| 42 | 2.1.2 | 更新项目人员配备计划 |  | 5d | 2007-04-23 | 2007-04-27 | 38 | 55d |  | 项目工程师; 专业工程师 | 80h |
| 43 | 2.1.3 | 确定工程设计定义阶段的可交付结果 |  | 5d | 2007-04-30 | 2007-05-04 | 41 | 15d | 0d | 项目工程师; 专业工程师 | 80h |
| 44 | 2.1.4 | 预测项目的意外开支和间接成本因素 |  | 5d | 2007-05-07 | 2007-05-11 | 43 | 45d |  | 项目工程师; 成本工程师 | 80h |
| 45 | 2.2 | **定义范围** |  | 45d | 2007-04-30 | 2007-06-29 |  | 0d |  |  | 760h |
| 46 | 2.2.1 | 审阅研究项目列表 |  | 5d | 2007-04-30 | 2007-05-04 | 41 | 0d |  | 项目工程师; 专业工程师 | 80h |
| 47 | 2.2.2 | 提出设计要求 |  | 5d | 2007-05-07 | 2007-05-11 | 43 | 15d |  | 专业工程师 | 40h |
| 48 | 2.2.3 | 建立供应商资料需求/设备预算 |  | 10d | 2007-05-07 | 2007-05-18 | 46 | 0d |  | 项目工程师; 专业工程师 | 160h |
| 49 | 2.2.4 | 制定设备规格要求和列表 |  | 10d | 2007-05-21 | 2007-06-01 | 41, 48 | 0d |  | 项目工程师; 专业工程师 | 160h |
| 50 | 2.2.5 | 绘制管道和设备图(PID) |  | 20d | 2007-06-04 | 2007-06-29 | 43, 48, 49 | 0d |  | 专业工程师; 设计师 | 320h |

| ID | WBS | Task | Type | Duration | Start | Finish | Predecessors | Total slack | Free slack | Resources | Work |
| --- | --- | --- | --- | --- | --- | --- | --- | --- | --- | --- | --- |
| 51 | 2.3 | **专业支持** |  | 40d | 2007-05-07 | 2007-06-29 |  | 0d |  |  | 880h |
| 52 | 2.3.1 | 审阅对管理机构的要求 |  | 20d | 2007-05-07 | 2007-06-01 | 46 | 0d |  | 专业工程师 | 160h |
| 53 | 2.3.2 | 制定大致安排和场地计划 |  | 20d | 2007-06-04 | 2007-06-29 | 47, 43, 48, 49 | 0d |  | 专业工程师; 设计师 | 320h |
| 54 | 2.3.3 | 制定各专业的控制图纸、列表和规格说明 |  | 20d | 2007-06-04 | 2007-06-29 | 43, 52, 49 | 0d |  | 专业工程师; 设计师 | 320h |
| 55 | 2.3.4 | 对建筑投入适宜性的评估 |  | 10d | 2007-06-18 | 2007-06-29 | 53SS+5%, 50SS+5%, 54SS+5% | 10d |  | 专业工程师 | 80h |
| 56 | 2.4 | **结束定义阶段** |  | 45d | 2007-06-18 | 2007-08-17 |  | 0d |  |  | 804h |
| 57 | 2.4.1 | 编写范围文档(包括基础设施) |  | 20d | 2007-06-18 | 2007-07-13 | 53SS+5%, 50SS+5%, 54SS+5% | 0d |  | 项目工程师; 专业工程师 | 320h |
| 58 | 2.4.2 | 生成项目资金预算 |  | 15d | 2007-06-18 | 2007-07-06 | 53SS+5%, 50SS+5% | 5d |  | 成本工程师 | 120h |
| 59 | 2.4.3 | 建立项目日程 |  | 10d | 2007-06-18 | 2007-06-29 | 53SS+5%, 50SS+5% | 10d |  | 项目工程师; 生产计划员 | 160h |
| 60 | 2.4.4 | 核查项目定义、范围和预算 |  | 5d | 2007-07-16 | 2007-07-20 | 57, 58, 59, 42, 48, 53, 44, 50, 55 | 0d |  | 项目出资人; 项目工程师; 成本工程师 | 44h |
| 61 | 2.4.5 | 范围定义结束/发布成本预算 | milestone | 0d | 2007-07-20 | 2007-07-20 | 60 | 0d |  |  |  |
| 62 | 2.4.6 | 拨发项目款项 |  | 20d | 2007-07-23 | 2007-08-17 | 61 | 0d |  | 项目出资人 | 160h |
| 63 | 2.4.7 | 项目获得批准 | milestone | 0d | 2007-08-17 | 2007-08-17 | 62 | 0d |  |  |  |
| 64 | 3 | **设计** |  | 201.25d | 2007-08-20 | 2008-05-27 |  | 0d |  |  | 20804h |
| 65 | 3.1 | **规划和控制** |  | 166d | 2007-08-20 | 2008-04-07 |  | 0d |  |  | 7364h |
| 66 | 3.1.1 | 核查项目定义、范围和预算 |  | 1d | 2007-08-20 | 2007-08-20 | 63 | 0d |  | 项目出资人; 项目工程师 | 16h |
| 67 | 3.1.2 | 制定或更新项目流程 |  | 10d | 2007-08-21 | 2007-09-03 | 66 | 0d |  | 项目工程师 | 80h |
| 68 | 3.1.3 | 确定最终的设计和建筑日程 |  | 6d | 2007-08-21 | 2007-08-28 | 66 | 4d | 0d | 生产计划员; 项目工程师 | 96h |
| 69 | 3.1.4 | 制定和管理问题列表 |  | 100d | 2007-08-21 | 2008-01-07 | 66 | 98.25d |  | 项目工程师 | 800h |
| 70 | 3.1.5 | 采购交货时间较长的设备 |  | 133d | 2007-08-23 | 2008-02-25 | 84 | 58d | 30.5d | 项目工程师 | 1064h |
| 71 | 3.1.6 | 制定和执行采购和承包计划 |  | 3d | 2007-08-24 | 2007-08-28 | 68SS+5%, 84 | 4d |  | 项目出资人; 项目工程师 | 48h |
| 72 | 3.1.7 | 制定设计阶段计划并配备人员 |  | 3d | 2007-09-04 | 2007-09-06 | 66, 67 | 7.75d |  | 项目工程师 | 24h |
| 73 | 3.1.8 | 为规格说明和绘图定义工程设计演示文稿和目录 |  | 3d | 2007-09-04 | 2007-09-06 | 68SS+5%, 67, 71 | 0d |  | 项目工程师; 专业工程师 | 48h |
| 74 | 3.1.9 | 实施文档控制 |  | 5d | 2007-09-04 | 2007-09-10 | 67 | 38.25d | 5d | 项目工程师 | 40h |
| 75 | 3.1.10 | 建立项目监控机制 |  | 5d | 2007-09-04 | 2007-09-10 | 67, 71 | 38.25d | 5d | 项目工程师 | 40h |
| 76 | 3.1.11 | 建立项目成本控制和盈余分析系统 |  | 10d | 2007-09-04 | 2007-09-17 | 66, 67 | 33.25d | 0d | 项目工程师; 生产计划员; 成本工程师 | 84h |
| 77 | 3.1.12 | 最终确定可交付结果列表 |  | 10d | 2007-09-04 | 2007-09-18 | 66, 73SS+2.5%, 71 | 0d |  | 项目工程师; 专业工程师 | 160h |
| 78 | 3.1.13 | 实施项目报告制度 |  | 145d | 2007-09-18 | 2008-04-07 | 76, 67, 74, 75 | 33.25d |  | 项目工程师 | 1160h |
| 79 | 3.1.14 | 要求支付得到批准的/合同规定的报酬 |  | 100d | 2007-10-02 | 2008-02-18 | 85 | 68.25d |  | 项目工程师 | 800h |
| 80 | 3.1.15 | 采购设备 |  | 123d | 2007-10-09 | 2008-03-27 | 85, 88SS+5% | 27.5d | 0d | 项目工程师 | 984h |
| 81 | 3.1.16 | 制做图纸(包括供应商的图纸) |  | 100d | 2007-10-09 | 2008-02-25 | 85, 88SS+5% | 63.25d |  | 项目工程师; 生产计划员 | 1600h |
| 82 | 3.1.17 | 培训启动计划 |  | 20d | 2008-02-08 | 2008-03-06 | 89 | 55.25d |  | 项目工程师; 专业工程师 | 320h |

| ID | WBS | Task | Duration | Start | Finish | Predecessors | Total slack | Free slack | Resources | Work |
| --- | --- | --- | --- | --- | --- | --- | --- | --- | --- | --- |
| 83 | 3.2 | **进一步明确范围** | 123d | 2007-08-21 | 2008-02-07 |  | 5d |  |  | 2032h |
| 84 | 3.2.1 | 更新项目设计准则 | 2d | 2007-08-21 | 2007-08-22 | 66 | 5d | 0d | 项目工程师; 专业工程师 | 32h |
| 85 | 3.2.2 | 设计问题: 设备列表 | 30d | 2007-08-21 | 2007-10-01 | 66 | 27.5d | 0d | 专业工程师 | 240h |
| 86 | 3.2.3 | 专业设计问题: 管道和设备图(PID) | 30d | 2007-09-07 | 2007-10-18 | 73 | 35.25d | 0d | 专业工程师; 设计师 | 480h |
| 87 | 3.2.4 | 专业设计问题: 总体布局图(GA)/场地计划 | 30d | 2007-09-07 | 2007-10-18 | 73 | 35.25d | 0d | 专业工程师; 设计师 | 480h |
| 88 | 3.2.5 | 设备规格说明、投标和供应商选择 | 40d | 2007-09-11 | 2007-11-05 | 73, 85SS+5% | 27.5d | 0d | 项目工程师; 专业工程师 | 640h |
| 89 | 3.2.6 | 处理设备功能说明 | 20d | 2008-01-11 | 2008-02-07 | 106SS+7.5% | 35.25d | 0d | 专业工程师 | 160h |
| 90 | 3.3 | **专业支持** | 200.25d | 2007-08-21 | 2008-05-27 |  | 0d |  |  | 11408h |
| 91 | 3.3.1 | 建立专业指导规范要求 | 2d | 2007-08-21 | 2007-08-22 | 66 | 18.75d |  | 专业工程师 | 16h |
| 92 | 3.3.2 | 审阅并最终制定专业标准和规格说明 | 5d | 2007-09-18 | 2007-09-25 | 73, 91, 72, 77 | 0d |  | 专业工程师 | 40h |
| 93 | 3.3.3 | **开始专业设计** | 55d | 2007-09-25 | 2007-12-11 |  | 0d |  |  | 3280h |
| 94 | 3.3.3.1 | 开始建筑学设计 | 25d | 2007-09-25 | 2007-10-30 | 92 | 0d |  | 专业工程师; 设计师 | 400h |
| 95 | 3.3.3.2 | 开始土木工程设计 | 30d | 2007-10-02 | 2007-11-13 | 94SS+5d | 0d |  | 专业工程师; 设计师 | 480h |
| 96 | 3.3.3.3 | 开始机械设计 | 30d | 2007-10-09 | 2007-11-20 | 95SS+5d | 0d |  | 专业工程师; 设计师 | 480h |
| 97 | 3.3.3.4 | 开始管道设计 | 30d | 2007-10-16 | 2007-11-27 | 96SS+5d | 0d |  | 专业工程师; 设计师 | 480h |
| 98 | 3.3.3.5 | 开始结构设计 | 30d | 2007-10-02 | 2007-11-13 | 94SS+5d | 20d |  | 专业工程师; 设计师 | 480h |
| 99 | 3.3.3.6 | 开始电气设计 | 30d | 2007-10-23 | 2007-12-04 | 97SS+5d | 0d |  | 专业工程师; 设计师 | 480h |
| 100 | 3.3.3.7 | 开始基础设施设计 | 30d | 2007-10-30 | 2007-12-11 | 99SS+5d | 0d |  | 专业工程师; 设计师 | 480h |
| 101 | 3.3.4 | 执行第一次质量检查 | 5d | 2007-11-30 | 2007-12-07 | 94SS+7.5%, 95SS+7.5%, 96SS+7.5%, 97SS+7.5%, 98SS+7.5%, 99SS+7.5%, 100SS+7.5% | 0d |  | 专业工程师 | 40h |
| 102 | 3.3.5 | 供应商图纸检查(所有专业) | 60d | 2007-11-20 | 2008-02-12 | 80SS+2.5%, 70SS+2.5% | 27.5d | 0d | 专业工程师 | 480h |
| 103 | 3.3.6 | 供应商图纸认证(所有专业) | 5d | 2008-02-12 | 2008-02-19 | 102 | 27.5d |  | 专业工程师; 项目工程师 | 80h |
| 104 | 3.3.7 | 跨专业工程设计检查 | 5d | 2007-11-30 | 2007-12-07 | 94SS+7.5%, 95SS+7.5%, 96SS+7.5%, 97SS+7.5%, 98SS+7.5%, 99SS+7.5%, 100SS+7.5% | 0d |  | 专业工程师; 设计师 | 80h |
| 105 | 3.3.8 | 完成设备列表 | 90d | 2007-10-02 | 2008-02-04 | 85 | 38.25d |  | 专业工程师; 项目工程师 | 1440h |
| 106 | 3.3.9 | 完成设备连接图 | 80d | 2007-10-19 | 2008-02-07 | 86 | 35.25d | 0d | 专业工程师; 设计师; 绘图员 | 644h |
| 107 | 3.3.10 | 完成总体布局图/场地计划 | 80d | 2007-10-19 | 2008-02-07 | 87 | 35.25d |  | 专业工程师; 设计师; 绘图员 | 644h |

Notes:
- 94: 此任务包括: / 效果图 / 楼层布置计划 / 建筑物立面图 / 完成日程
- 95: 此任务包括: / 平面布置图 / 腐蚀 / 定坡度 / 地下管道 / 基础设施
- 96: 此任务包括: / 水箱 / 特殊设备 / 采暖、通风和空调 / 原料处理 / 水泵
- 97: 此任务包括: / 设备连接图 / 计划 / 零件 / 等角投影图 / 防火 / 管道工程 / 吊架 / 应力计算 / 管线列表
- 98: 此任务包括: / 钢材 / 板石 / 设备支持 / 地基
- 99: 此任务包括: / 供电计划 / 发动机控制中心(MCC) / 可编程逻辑控制器(PLC) / 接地 / 照明 / 通讯 / 基础
- 100: 此任务包括: / 设备连接图 / 数据表 / 循环 / 逻辑 / 位置 / 索引

| ID | WBS | Task | Type | Duration | Start | Finish | Predecessors | Total slack | Free slack | Resources | Work |
| --- | --- | --- | --- | --- | --- | --- | --- | --- | --- | --- | --- |
| 108 | 3.3.11 | **完成专业设计** |  | 80d | 2007-12-07 | 2008-03-28 |  | 0d |  |  | 4108h |
| 109 | 3.3.11.1 | 完成建筑学设计 |  | 70d | 2007-12-07 | 2008-03-14 | 104, 87, 101 | 10d | 7.5d | 专业工程师; 设计师; 绘图员 | 564h |
| 110 | 3.3.11.2 | 完成土木工程设计 |  | 70d | 2007-12-07 | 2008-03-14 | 104, 87, 101 | 10d |  | 专业工程师; 设计师; 绘图员 | 564h |
| 111 | 3.3.11.3 | 完成机械设计 |  | 70d | 2007-12-07 | 2008-03-14 | 104, 87, 101 | 10d | 7.5d | 专业工程师; 设计师; 绘图员 | 564h |
| 112 | 3.3.11.4 | 完成结构设计 |  | 70d | 2007-12-07 | 2008-03-14 | 104, 87, 101 | 10d | 7.5d | 专业工程师; 设计师; 绘图员 | 564h |
| 113 | 3.3.11.5 | 完成管道设计 |  | 70d | 2007-12-07 | 2008-03-14 | 104, 86, 101 | 10d | 7.5d | 专业工程师; 设计师; 绘图员 | 564h |
| 114 | 3.3.11.6 | 完成电气设计 |  | 80d | 2007-12-07 | 2008-03-28 | 104, 86, 101 | 0d |  | 专业工程师; 设计师; 绘图员 | 644h |
| 115 | 3.3.11.7 | 完成基础设施设计 |  | 80d | 2007-12-07 | 2008-03-28 | 104, 86, 101 | 0d |  | 专业工程师; 设计师; 绘图员 | 644h |
| 116 | 3.3.12 | 执行第二次质量检查 |  | 5d | 2008-02-29 | 2008-03-07 | 109SS+7.5%, 111SS+7.5%, 112SS+7.5%, 113SS+7.5%, 114SS+7.5% | 15d |  | 专业工程师 | 40h |
| 117 | 3.3.13 | 检查代码符合性和安全性 |  | 10d | 2008-02-29 | 2008-03-14 | 109SS+7.5%, 111SS+7.5%, 112SS+7.5%, 113SS+7.5%, 114SS+7.5% | 10d |  | 专业工程师 | 80h |
| 118 | 3.3.14 | **完成设计阶段** |  | 42d | 2008-03-28 | 2008-05-27 |  | 0d |  |  | 436h |
| 119 | 3.3.14.1 | 检查并重新绘制图纸和拟定列表(所有专业) |  | 15d | 2008-03-28 | 2008-04-18 | 109, 110, 111, 112, 113, 114, 115, 89, 103, 105, 106, 107, 116, 117 | 0d |  | 专业工程师; 设计师; 绘图员 | 124h |
| 120 | 3.3.14.2 | 绘制得到批准的图纸并得到规范顺应性计算结果(所有专业) |  | 5d | 2008-04-18 | 2008-04-25 | 119 | 0d |  | 专业工程师; 项目工程师 | 80h |
| 121 | 3.3.14.3 | 发布准许、投标和建筑工程 |  | 15d | 2008-04-25 | 2008-05-16 | 120 | 0d |  | 项目工程师 | 120h |
| 122 | 3.3.14.4 | 选择承包商/审阅合同 |  | 5d | 2008-05-16 | 2008-05-23 | 121 | 0d |  | 专业工程师; 项目工程师 | 80h |
| 123 | 3.3.14.5 | 结束项目 - 结束报告，发布记录图纸 |  | 2d | 2008-05-23 | 2008-05-27 | 122, 69, 78, 80, 81, 79, 82, 70 | 0d |  | 项目工程师; 项目出资人 | 32h |
| 124 | 4 | **建筑** |  | 246d | 2008-05-27 | 2009-05-06 | 123 | 0d |  |  |  |
| 125 | 4.1 | 选择建筑承包商 |  | 30d | 2008-05-27 | 2008-07-08 | 123 | 0d |  |  |  |
| 126 | 4.2 | 现场动员 |  | 20d | 2008-07-08 | 2008-08-05 | 125 | 0d |  |  |  |
| 127 | 4.3 | 建筑 |  | 196d | 2008-08-05 | 2009-05-06 | 126 | 0d |  |  |  |
| 128 | 4.4 | 完成建筑 | milestone | 0d | 2009-05-06 | 2009-05-06 | 127 | 0d |  |  |  |
