# 准备年度报告

Schedule from MS Project, 2007-01-01 to 2007-02-28.
从财务会计角度来看，此模板用于处理在确定年度财务报表典型准备工作时的常规活动。该模板包括的活动以从多个部门获取必要信息为重点，与其他部门(例如法律和公关部门)协作以确保提供的所有必需信息都准确无误，并持续到整个打印和分发流程。

## Calendars

- 标准: Mon-Fri 08:00-12:00, 13:00-17:00; Sat-Sun off.

## Resources

| Resource |
| --- |
| 审计委员会 |
| 法律部门 |
| 外部审计员 |
| 执行委员会 |
| CFO/总会计师 |
| 营销组 |
| 战略规划委员会 |
| PR/IR 部门 |
| 主席 |

## Schedule

| ID | WBS | Task | Type | Duration | Start | Finish | Predecessors | Total slack | Free slack | Resources | Work |
| --- | --- | --- | --- | --- | --- | --- | --- | --- | --- | --- | --- |
| 1 | 1 | **进行初步规划** |  | 6d? | 2007-01-01 | 2007-01-08 |  | 0d |  |  | 48h |
| 2 | 1.1 | 审阅项目文件/去年的年度报告过程中的经验教训 |  | 1d? | 2007-01-01 | 2007-01-01 |  | 0d |  | 战略规划委员会 | 8h |
| 3 | 1.2 | 确认对财务报表要求的更改(如果有) |  | 1d? | 2007-01-02 | 2007-01-02 | 2 | 0d |  | CFO/总会计师 | 8h |
| 4 | 1.3 | 确定年度报告主题和章节要求 |  | 1d? | 2007-01-03 | 2007-01-03 | 3 | 0d |  | 战略规划委员会 | 8h |
| 5 | 1.4 | 确认要添加或删除的其他章节 |  | 1d? | 2007-01-04 | 2007-01-04 | 4 | 0d |  | 战略规划委员会 | 8h |
| 6 | 1.5 | 确认 SEC 编档和年度报告检查点 |  | 1d? | 2007-01-05 | 2007-01-05 | 5 | 0d |  | CFO/总会计师 | 8h |
| 7 | 1.6 | 选择内部审计员 |  | 1d? | 2007-01-08 | 2007-01-08 | 6 | 0d |  | 审计委员会 | 8h |
| 8 | 1.7 | 结束初步规划 | milestone | 0d | 2007-01-08 | 2007-01-08 | 7 | 0d |  |  |  |
| 9 | 2 | **设计年度报告** |  | 6d? | 2007-01-09 | 2007-01-16 |  | 0d |  |  | 48h |
| 10 | 2.1 | 分配初步设计的资源 |  | 1d? | 2007-01-09 | 2007-01-09 | 8 | 0d |  | 战略规划委员会 | 8h |
| 11 | 2.2 | 制定初步设计和信息要求 |  | 1d? | 2007-01-10 | 2007-01-10 | 10 | 0d |  | 战略规划委员会 | 8h |
| 12 | 2.3 | **评估/确认报告分发机制** |  | 3d? | 2007-01-11 | 2007-01-15 |  | 0d |  |  | 24h |
| 13 | 2.3.1 | 评估/确认年度报告设计和通讯供应商 |  | 1d? | 2007-01-11 | 2007-01-11 | 11 | 0d |  | PR/IR 部门 | 8h |
| 14 | 2.3.2 | 评估/确认公司网站设计和集成要求 |  | 1d? | 2007-01-12 | 2007-01-12 | 13 | 0d |  | PR/IR 部门 | 8h |
| 15 | 2.3.3 | 评估/确认年度报告制作和邮递供应商 |  | 1d? | 2007-01-15 | 2007-01-15 | 14 | 0d |  | PR/IR 部门 | 8h |
| 16 | 2.3.4 | 报告分发机制已确认 | milestone | 0d | 2007-01-15 | 2007-01-15 | 15 | 0d |  | PR/IR 部门 |  |
| 17 | 2.4 | 计划/确认制作日程 |  | 1d? | 2007-01-16 | 2007-01-16 | 16 | 0d |  | PR/IR 部门 | 8h |
| 18 | 2.5 | 完成年度报告设计 | milestone | 0d | 2007-01-16 | 2007-01-16 | 17 | 0d |  |  |  |
| 19 | 3 | **确定 SEC 10-K 和代理文档制作日程** |  | 3d? | 2007-01-17 | 2007-01-19 |  | 0d |  |  | 24h |
| 20 | 3.1 | 计划/确认 10-K 制作日程 |  | 1d? | 2007-01-17 | 2007-01-17 | 18 | 0d |  | CFO/总会计师 | 8h |
| 21 | 3.2 | 计划/确认委托书制作日程 |  | 1d? | 2007-01-18 | 2007-01-18 | 20 | 0d |  | CFO/总会计师 | 8h |
| 22 | 3.3 | 确定满足制作日程所需的过程步骤 |  | 1d? | 2007-01-19 | 2007-01-19 | 21 | 0d |  | CFO/总会计师 | 8h |
| 23 | 3.4 | 完成 SEC 10-K 和代理文档制作日程安排 | milestone | 0d | 2007-01-19 | 2007-01-19 | 22 | 0d |  |  |  |
| 24 | 4 | **制定年度报告** |  | 22d? | 2007-01-22 | 2007-02-20 |  | 5.5d |  |  | 216h |
| 25 | 4.1 | **制定主题制作组件** |  | 7d? | 2007-01-22 | 2007-01-30 |  | 16.5d |  |  | 56h |
| 26 | 4.1.1 | 安排和举行主题制定会议 |  | 1d? | 2007-01-22 | 2007-01-22 | 23 | 16.5d | 0d | PR/IR 部门 | 8h |
| 27 | 4.1.2 | 收集主题统计信息/验证主题消息 |  | 1d? | 2007-01-23 | 2007-01-23 | 26 | 16.5d | 0d | PR/IR 部门 | 8h |
| 28 | 4.1.3 | 拜访主题负责人 |  | 1d? | 2007-01-24 | 2007-01-24 | 27 | 16.5d | 0d | PR/IR 部门 | 8h |
| 29 | 4.1.4 | 制定初步的主题章节书面说明 |  | 1d? | 2007-01-25 | 2007-01-25 | 28 | 16.5d | 0d | PR/IR 部门 | 8h |
| 30 | 4.1.5 | 安排主题图片和网站设计会议 |  | 1d? | 2007-01-26 | 2007-01-26 | 29 | 16.5d | 0d | PR/IR 部门 | 8h |
| 31 | 4.1.6 | 验证主题事实 |  | 1d? | 2007-01-29 | 2007-01-29 | 30 | 16.5d | 0d | PR/IR 部门 | 8h |
| 32 | 4.1.7 | 与行政领导一起最终确定主题设计和书面说明 |  | 1d? | 2007-01-30 | 2007-01-30 | 31 | 16.5d | 0d | PR/IR 部门 | 8h |
| 33 | 4.1.8 | 完成主题制作 | milestone | 0d | 2007-01-30 | 2007-01-30 | 32 | 16.5d | 0d |  |  |

Notes:
- 4: 确定主题后，制定主题内容中涉及的负责人列表

| ID | WBS | Task | Type | Duration | Start | Finish | Predecessors | Total slack | Free slack | Resources | Work |
| --- | --- | --- | --- | --- | --- | --- | --- | --- | --- | --- | --- |
| 34 | 4.2 | **制定致股东的信** |  | 15d? | 2007-01-31 | 2007-02-20 |  | 5.5d |  |  | 40h |
| 35 | 4.2.1 | 计划对主席/CEO 的拜访 |  | 1d? | 2007-01-31 | 2007-01-31 | 33 | 16.5d | 0d | PR/IR 部门 | 8h |
| 36 | 4.2.2 | 进行拜访 |  | 1d? | 2007-02-01 | 2007-02-01 | 35 | 16.5d | 0d | PR/IR 部门; 主席 | 16h |
| 37 | 4.2.3 | 撰写和审阅书信 |  | 1d? | 2007-02-02 | 2007-02-02 | 36 | 16.5d | 11d | PR/IR 部门 | 8h |
| 38 | 4.2.4 | 根据审计的财务结果审阅书信 |  | 1d? | 2007-02-20 | 2007-02-20 | 37, 83 | 5.5d | 0d | PR/IR 部门 | 8h |
| 39 | 4.2.5 | 完成致股东的信 | milestone | 0d | 2007-02-20 | 2007-02-20 | 38 | 5.5d |  |  |  |
| 40 | 4.3 | **确定关注组件的公共和投资人关系** |  | 10.5d? | 2007-02-06 | 2007-02-20 |  | 0d |  |  | 120h |
| 41 | 4.3.1 | **设立 PR 和 IR 里程碑** |  | 0.5d? | 2007-02-06 | 2007-02-06 |  | 0d |  |  | 4h |
| 42 | 4.3.1.1 | 确定主要的 PR 和 IR 里程碑(与可交付结果一致) |  | 0.5d? | 2007-02-06 | 2007-02-06 | 76 | 0d |  | PR/IR 部门 | 4h |
| 43 | 4.3.2 | **制定公共关系信息** |  | 3.5d? | 2007-02-06 | 2007-02-09 |  | 11d |  |  | 28h |
| 44 | 4.3.2.1 | 确定包含在年度报告中的 PR 信息 |  | 0.5d? | 2007-02-06 | 2007-02-06 | 42 | 11d | 0d | PR/IR 部门 | 4h |
| 45 | 4.3.2.2 | 确定有关财务结果的 PR 信息 |  | 2d? | 2007-02-07 | 2007-02-08 | 44 | 11d | 0d | PR/IR 部门 | 16h |
| 46 | 4.3.2.3 | 修改分销渠道和时间表 |  | 1d? | 2007-02-09 | 2007-02-09 | 45 | 11d | 6d | PR/IR 部门 | 8h |
| 47 | 4.3.3 | **制定投资人关系信息** |  | 10d? | 2007-02-06 | 2007-02-20 |  | 0d |  |  | 88h |
| 48 | 4.3.3.1 | 确定年度报告 IR 信息 |  | 2d? | 2007-02-06 | 2007-02-08 | 42 | 9.5d | 0d | PR/IR 部门 | 16h |
| 49 | 4.3.3.2 | 确定有关财务结果的 IR 信息 |  | 2d? | 2007-02-08 | 2007-02-12 | 48 | 9.5d | 0d | PR/IR 部门 | 16h |
| 50 | 4.3.3.3 | 确认报告年度报告的分发列表和渠道 |  | 2d? | 2007-02-12 | 2007-02-14 | 49 | 9.5d | 3.5d | PR/IR 部门 | 16h |
| 51 | 4.3.3.4 | 从 CFO 获取财务结果 |  | 0.5d? | 2007-02-20 | 2007-02-20 | 50, 83 | 6d |  | CFO/总会计师; PR/IR 部门 | 8h |
| 52 | 4.3.3.5 | **确认股东的邮件列表获取和分发过程** |  | 4d? | 2007-02-06 | 2007-02-12 |  | 0d |  |  | 32h |
| 53 | 4.3.3.5.1 | 确认机构分发列表/过程 |  | 1d? | 2007-02-06 | 2007-02-07 | 42 | 0d |  | PR/IR 部门 | 8h |
| 54 | 4.3.3.5.2 | 确认佣金分发列表/过程 |  | 1d? | 2007-02-07 | 2007-02-08 | 53 | 0d |  | PR/IR 部门 | 8h |
| 55 | 4.3.3.5.3 | 确认个人投资者分发列表/过程 |  | 1d? | 2007-02-08 | 2007-02-09 | 54 | 0d |  | PR/IR 部门 | 8h |
| 56 | 4.3.3.5.4 | 确认公司网站更新/设置格式/发布过程 |  | 1d? | 2007-02-09 | 2007-02-12 | 55 | 0d |  | PR/IR 部门 | 8h |
| 57 | 4.3.3.5.5 | 完成发布和分发过程确认 | milestone | 0d | 2007-02-12 | 2007-02-12 | 56 | 0d |  |  |  |
| 58 | 4.3.4 | 完成公共和投资人关系消息的制定和规划 | milestone | 0d | 2007-02-12 | 2007-02-12 | 57 | 0d |  |  |  |

| ID | WBS | Task | Type | Duration | Start | Finish | Predecessors | Total slack | Free slack | Resources | Work |
| --- | --- | --- | --- | --- | --- | --- | --- | --- | --- | --- | --- |
| 59 | 5 | **进行财务结算活动** |  | 22.5d? | 2007-01-22 | 2007-02-21 |  | 0d |  |  | 196h |
| 60 | 5.1 | **确定财务检查组件和相关 SEC 文档的日程安排** |  | 5d? | 2007-01-22 | 2007-01-26 |  | 0d |  |  | 48h |
| 61 | 5.1.1 | 制定财务结算日程 |  | 1d? | 2007-01-22 | 2007-01-22 | 23 | 0d |  | CFO/总会计师 | 8h |
| 62 | 5.1.2 | 制定和确认外部审计评论日程 |  | 1d? | 2007-01-23 | 2007-01-23 | 61 | 0d |  | 外部审计员; CFO/总会计师 | 16h |
| 63 | 5.1.3 | 确定/分配用于制定和确认财务报表和备注的资源 |  | 1d? | 2007-01-24 | 2007-01-24 | 62 | 0d |  | CFO/总会计师 | 8h |
| 64 | 5.1.4 | 确定/分配用于制定和确认 10-K 章节的资源 |  | 1d? | 2007-01-25 | 2007-01-25 | 63 | 0d |  | CFO/总会计师 | 8h |
| 65 | 5.1.5 | 确定/分配用于制定和确认委托书章节的资源 |  | 1d? | 2007-01-26 | 2007-01-26 | 64 | 0d |  | CFO/总会计师 | 8h |
| 66 | 5.1.6 | 完成财务检查和相关 SEC 文档的日程安排 | milestone | 0d | 2007-01-26 | 2007-01-26 | 65 | 0d |  |  |  |
| 67 | 5.2 | **进行财务结算** |  | 3d? | 2007-01-29 | 2007-01-31 |  | 0d |  |  | 24h |
| 68 | 5.2.1 | 结算财政年度帐簿 |  | 1d? | 2007-01-29 | 2007-01-29 | 66 | 0d |  | CFO/总会计师 | 8h |
| 69 | 5.2.2 | 进行财务调整(累算和储量)检查和批准 |  | 1d? | 2007-01-30 | 2007-01-30 | 68 | 0d |  | CFO/总会计师 | 8h |
| 70 | 5.2.3 | 制定包括在年度报告、10-K 和委托书中的财务结果 |  | 1d? | 2007-01-31 | 2007-01-31 | 69 | 0d |  | CFO/总会计师 | 8h |
| 71 | 5.2.4 | 完成财务结算和结果 | milestone | 0d | 2007-01-31 | 2007-01-31 | 70 | 0d |  |  |  |
| 72 | 5.3 | **制定财务报表备注和 SEC 文档** |  | 3d? | 2007-02-01 | 2007-02-05 |  | 0d |  |  | 24h |
| 73 | 5.3.1 | 起草财务报表备注 |  | 1d? | 2007-02-01 | 2007-02-01 | 71 | 0d |  | CFO/总会计师 | 8h |
| 74 | 5.3.2 | 起草 10-K |  | 1d? | 2007-02-02 | 2007-02-02 | 73 | 0d |  | CFO/总会计师 | 8h |
| 75 | 5.3.3 | 起草委托书信息 |  | 1d? | 2007-02-05 | 2007-02-05 | 74 | 0d |  | 法律部门 | 8h |
| 76 | 5.3.4 | 完成财务报表备注和 SEC 文档起草 | milestone | 0d | 2007-02-05 | 2007-02-05 | 75 | 0d |  |  |  |
| 77 | 5.4 | **进行外部审计** |  | 4d? | 2007-02-14 | 2007-02-19 |  | 5d |  |  | 44h |
| 78 | 5.4.1 | 进行国外公司和子公司财务审计 |  | 1d? | 2007-02-14 | 2007-02-14 | 91 | 5d | 0d | 外部审计员 | 8h |
| 79 | 5.4.2 | 进行公司财务审计 |  | 1d? | 2007-02-15 | 2007-02-15 | 78 | 5d | 0d | 外部审计员 | 8h |
| 80 | 5.4.3 | 完成外部审计 | milestone | 0d | 2007-02-15 | 2007-02-15 | 79 | 5d | 0d |  |  |
| 81 | 5.4.4 | 与审计委员会一起审阅和最终确定审计结果 |  | 1d? | 2007-02-16 | 2007-02-16 | 80 | 5d | 0d | 审计委员会; 外部审计员; CFO/总会计师 | 12h |
| 82 | 5.4.5 | 正式认可财务报表/获取高级管理认证 |  | 1d? | 2007-02-19 | 2007-02-19 | 81 | 5d | 0d | 审计委员会; CFO/总会计师 | 16h |
| 83 | 5.4.6 | 完成外部审计 | milestone | 0d | 2007-02-19 | 2007-02-19 | 82 | 5d | 0d |  |  |

Notes:
- 61: 对于结算财务帐簿以及制作年度报告和 10-K 所需的财务报表信息，请将日程基准基于实现里程碑所需的时间和资源投入。 / 换句话说，首先确定日期，然后回来确定要支持这些最后期限日期，必须开始活动的时间。
- 77: 外部审计活动的执行贯穿于整个年度。这些活动关注于年末的结算，以作为创建外部审计员正式认可的年度报告和财务报表的准备。

| ID | WBS | Task | Type | Duration | Start | Finish | Predecessors | Total slack | Free slack | Resources | Work |
| --- | --- | --- | --- | --- | --- | --- | --- | --- | --- | --- | --- |
| 84 | 5.5 | **进行内部法律审查** |  | 6d? | 2007-02-06 | 2007-02-13 |  | 5d |  |  | 48h |
| 85 | 5.5.1 | 协调和审阅要包括在年度报告中的重要事件 |  | 1d? | 2007-02-06 | 2007-02-06 | 76 | 5d | 0d | 法律部门 | 8h |
| 86 | 5.5.2 | 协调和审阅要包括在 10-K 中的重要事件 |  | 1d? | 2007-02-07 | 2007-02-07 | 85 | 5d | 0d | 法律部门 | 8h |
| 87 | 5.5.3 | 协调/制定委托书 |  | 1d? | 2007-02-08 | 2007-02-08 | 86 | 5d | 0d | 法律部门 | 8h |
| 88 | 5.5.4 | 协调/审阅发送给股东的邮件 |  | 1d? | 2007-02-09 | 2007-02-09 | 87 | 5d | 0d | 法律部门 | 8h |
| 89 | 5.5.5 | 协调/审阅外部审计评论和批注 |  | 1d? | 2007-02-12 | 2007-02-12 | 88 | 5d | 0d | 法律部门 | 8h |
| 90 | 5.5.6 | 协调/审阅高级管理认证 |  | 1d? | 2007-02-13 | 2007-02-13 | 89 | 5d | 0d | 法律部门 | 8h |
| 91 | 5.5.7 | 完成内部法律审查 | milestone | 0d | 2007-02-13 | 2007-02-13 | 90 | 5d | 0d |  |  |
| 92 | 5.6 | 公开发布财务结果 |  | 0.5d? | 2007-02-20 | 2007-02-20 | 46, 83 | 5d | 0d | 审计委员会; CFO/总会计师; PR/IR 部门; 主席 | 8h |
| 93 | 5.7 | 完成财务结算 |  | 1d? | 2007-02-20 | 2007-02-21 | 92 | 5d |  |  |  |
| 94 | 6 | **制作年度报告** |  | 8d? | 2007-02-12 | 2007-02-22 |  | 0d |  |  | 64h |
| 95 | 6.1 | 起草年度报告设计布局并确定占位符 |  | 1d? | 2007-02-12 | 2007-02-13 | 58 | 0d |  | PR/IR 部门 | 8h |
| 96 | 6.2 | 准备行政管理的模型 |  | 1d? | 2007-02-13 | 2007-02-14 | 95 | 0d |  | PR/IR 部门 | 8h |
| 97 | 6.3 | 迭代设计/最终确定生产日程 |  | 1d? | 2007-02-14 | 2007-02-15 | 96 | 0d |  | PR/IR 部门 | 8h |
| 98 | 6.4 | 最终确定年度报告设计和占位符数据 |  | 1d? | 2007-02-15 | 2007-02-16 | 97 | 0d |  | PR/IR 部门 | 8h |
| 99 | 6.5 | 制作最终布局/获取最终批准 |  | 1d? | 2007-02-16 | 2007-02-19 | 98 | 0d |  | PR/IR 部门 | 8h |
| 100 | 6.6 | 打印年度报告 |  | 1d? | 2007-02-19 | 2007-02-20 | 99 | 0d |  | PR/IR 部门 | 8h |
| 101 | 6.7 | 获取 10-K 文档文件 |  | 1d? | 2007-02-20 | 2007-02-21 | 100 | 0d |  | PR/IR 部门 | 8h |
| 102 | 6.8 | 获取委托书文档文件 |  | 1d? | 2007-02-21 | 2007-02-22 | 101 | 0d |  | PR/IR 部门 | 8h |
| 103 | 6.9 | 完成年度报告制作 | milestone | 0d | 2007-02-22 | 2007-02-22 | 102 | 0d |  |  |  |
| 104 | 7 | **分发年度报告** |  | 4d? | 2007-02-22 | 2007-02-28 |  | 0d |  |  | 32h |
| 105 | 7.1 | 获取最终邮件分发列表 |  | 1d? | 2007-02-22 | 2007-02-23 | 103 | 0d |  | PR/IR 部门 | 8h |
| 106 | 7.2 | 打印 10-K 年度报告邮件 |  | 1d? | 2007-02-23 | 2007-02-26 | 105 | 0d |  | PR/IR 部门 | 8h |
| 107 | 7.3 | 打印年度报告委托书邮件 |  | 1d? | 2007-02-26 | 2007-02-27 | 106 | 0d |  | PR/IR 部门 | 8h |
| 108 | 7.4 | 合并并邮递年度报告 |  | 1d? | 2007-02-27 | 2007-02-28 | 107 | 0d |  | PR/IR 部门 | 8h |
| 109 | 7.5 | 完成分发 | milestone | 0d | 2007-02-28 | 2007-02-28 | 108 | 0d |  |  |  |
| 110 | 8 | 完成年度报告 | milestone | 0d | 2007-02-28 | 2007-02-28 | 109 | 0d |  |  |  |
