# 开始提供财务服务

Schedule from MS Project, 2007-01-01 to 2007-02-20.

## Calendars

- 标准: Mon-Fri 08:00-12:00, 13:00-17:00; Sat-Sun off.

## Resources

| Resource |
| --- |
| 服务内容赞助商 |
| 服务内容审核工作组 |
| 初始工作组 |
| 工作组负责人 |
| 客户服务代表 |
| 营销代表 |
| 运营代表 |
| 销售代表 |
| IT 代表 |
| 法律事务代表 |

## Schedule

| ID | WBS | Task | Type | Duration | Start | Finish | Predecessors | Total slack | Resources | Work |
| --- | --- | --- | --- | --- | --- | --- | --- | --- | --- | --- |
| 1 | 1 | 阅读说明此模板用途的注释 | milestone | 0d | 2007-01-01 | 2007-01-01 |  | 0d |  |  |
| 2 | 2 | **第一阶段: 进行初始规划** |  | 11d? | 2007-01-01 | 2007-01-15 |  | 0d |  | 192h |
| 3 | 2.1 | **组建初始工作组** |  | 3d? | 2007-01-01 | 2007-01-03 |  | 0d |  | 72h |
| 4 | 2.1.1 | 确定工作组负责人 |  | 1d? | 2007-01-01 | 2007-01-01 | 1 | 0d | 服务内容赞助商 | 8h |
| 5 | 2.1.2 | 确定客户服务资源 |  | 1d? | 2007-01-02 | 2007-01-02 | 4 | 0d | 工作组负责人 | 8h |
| 6 | 2.1.3 | 确定营销资源 |  | 1d? | 2007-01-02 | 2007-01-02 | 4 | 0d | 工作组负责人 | 8h |
| 7 | 2.1.4 | 确定运作资源 |  | 1d? | 2007-01-02 | 2007-01-02 | 4 | 0d | 工作组负责人 | 8h |
| 8 | 2.1.5 | 确定销售资源 |  | 1d? | 2007-01-02 | 2007-01-02 | 4 | 0d | 工作组负责人 | 8h |
| 9 | 2.1.6 | 确定 IT/技术资源 |  | 1d? | 2007-01-02 | 2007-01-02 | 4 | 0d | 工作组负责人 | 8h |
| 10 | 2.1.7 | 确定法律资源 |  | 1d? | 2007-01-02 | 2007-01-02 | 4 | 0d | 工作组负责人 | 8h |
| 11 | 2.1.8 | 初始工作组启动会议 |  | 1d? | 2007-01-03 | 2007-01-03 | 10, 5, 6, 7, 8, 9, 4 | 0d | 服务内容赞助商; 初始工作组 | 16h |
| 12 | 2.2 | **确定服务内容和提供机会** |  | 6d? | 2007-01-04 | 2007-01-11 |  | 0d |  | 48h |
| 13 | 2.2.1 | 确定客户细分目标 |  | 1d? | 2007-01-04 | 2007-01-04 | 11 | 0d | 初始工作组 | 8h |
| 14 | 2.2.2 | 确定市场大小和成长率 |  | 1d? | 2007-01-05 | 2007-01-05 | 13 | 0d | 初始工作组 | 8h |
| 15 | 2.2.3 | 确定成本和收入预测 |  | 1d? | 2007-01-08 | 2007-01-08 | 14 | 0d | 初始工作组 | 8h |
| 16 | 2.2.4 | 确定面向目标客户细分的职位需求价值 |  | 1d? | 2007-01-09 | 2007-01-09 | 15 | 0d | 初始工作组 | 8h |
| 17 | 2.2.5 | 确定目标客户敏感度(了解客户细分) |  | 1d? | 2007-01-10 | 2007-01-10 | 16 | 0d | 初始工作组 | 8h |
| 18 | 2.2.6 | 定义目标地理/地缘政治区域 |  | 1d? | 2007-01-11 | 2007-01-11 | 17 | 0d | 初始工作组 | 8h |
| 19 | 2.2.7 | 完成服务内容确定 | milestone | 0d | 2007-01-11 | 2007-01-11 | 18 | 0d |  |  |
| 20 | 2.3 | **影响分析** |  | 10d? | 2007-01-01 | 2007-01-12 |  | 9d |  | 64h |
| 21 | 2.3.1 | 确定新服务对客户服务的影响 |  | 1d? | 2007-01-12 | 2007-01-12 | 19 | 0d | 客户服务代表 | 8h |
| 22 | 2.3.2 | 确定新服务对营销运作的影响 |  | 1d? | 2007-01-12 | 2007-01-12 | 19 | 0d | 营销代表 | 8h |
| 23 | 2.3.3 | 确定新服务对常规金融业务运营的影响 |  | 1d? | 2007-01-12 | 2007-01-12 | 19 | 0d | 运营代表 | 8h |
| 24 | 2.3.4 | 确定新服务对销售职能的影响 |  | 1d? | 2007-01-12 | 2007-01-12 | 19 | 0d | 销售代表 | 8h |
| 25 | 2.3.5 | 确定新服务对技术组织的影响 |  | 1d? | 2007-01-12 | 2007-01-12 | 19 | 0d | IT 代表 | 8h |
| 26 | 2.3.6 | 确定新服务对其他现有服务的影响 |  | 1d? | 2007-01-01 | 2007-01-01 |  | 36d | IT 代表 | 8h |
| 27 | 2.3.7 | 确定产品上市期间可能遇到的各种法规问题 |  | 1d? | 2007-01-12 | 2007-01-12 | 19 | 0d | 初始工作组 | 8h |
| 28 | 2.3.8 | 确定各种区域化问题及影响 |  | 1d? | 2007-01-12 | 2007-01-12 | 19 | 0d | 初始工作组 | 8h |
| 29 | 2.3.9 | 完成影响分析 | milestone | 0d | 2007-01-12 | 2007-01-12 | 28, 21, 22, 23, 24, 25, 27 | 0d |  |  |
| 30 | 2.4 | 定义产品上市一般成功措施 |  | 1d? | 2007-01-15 | 2007-01-15 | 29 | 26d | 初始工作组 | 8h |

Notes:
- 1: 此模板提供了从计划、执行和产品上市后活动到停止提供财务服务的整个流程。这不包括财务服务内容的制定，而只是包括从营销角度进行的产品上市相关部分。 / 为简化起见，我们针对使用的资源定义了一个称为初始工作组的资源。 / 如果使用此计划的环境调用可用性预测，则在所有将初始工作组用做资源的情况下，将初始工作组替换为工作组中的所有单个成员。初始工作组资源上的注释字段(资源表视图)将显示工作组的成员。
- 12: 进行定义时，请记住定义的是用于衡量产品上市是否成功的标准。 / 服务赞助商充当专家，设定服务内容的初步远景目标和需求。
- 17: 了解您所跟踪的客户细分，确保产品上市战略考虑到了此客户细分可能存在的任何敏感问题。 / 在同一种情况下，这些问题并非总是产生消极作用。请了解产品上市时可利用的热点问题，以便激发出热情
- 20: 以下分析活动的大部分都是并发运行的，每项活动均由初始工作组的特定成员担任负责人。 / 但是，法规性问题以及区域化问题最好在了解初始影响之后再进行研究。
- 27: 此操作将被视为检查点，以确保包含该操作。我们不专门安排法律/法定人员作为工作组的成员，因为这将在开发服务内容时完成，服务内容专家可以指导已确认的材料和问题，也可由适当人员来讲解。
- 30: 请仔细考虑目标细分以及影响分析结果，并定义监控和成功标准。这些操作将在投放市场后期间以及产品上市后期完成。同时还应考虑可用作中途纠正标准的标准。如果产品上市活动跨越多个地区，则有可能在产品上市期间进行很小的调整。 / 另请注意，这些成功标准可以在创建报表/监控流程和系统部分进行细化。

| ID | WBS | Task | Type | Duration | Start | Finish | Predecessors | Total slack | Resources | Work |
| --- | --- | --- | --- | --- | --- | --- | --- | --- | --- | --- |
| 31 | 3 | **第二阶段: 执行** |  | 24d? | 2007-01-15 | 2007-02-15 |  | 0d |  | 240h |
| 32 | 3.1 | **业务开展** |  | 10d? | 2007-01-15 | 2007-01-26 |  | 0d |  | 112h |
| 33 | 3.1.1 | **执行营销活动** |  | 8d? | 2007-01-15 | 2007-01-24 |  | 0d |  | 72h |
| 34 | 3.1.1.1 | 制定总体营销战略 |  | 1d? | 2007-01-15 | 2007-01-15 | 29 | 0d | 营销代表 | 8h |
| 35 | 3.1.1.2 | 传播策划(外部) |  | 1d? | 2007-01-16 | 2007-01-16 | 34 | 0d | 营销代表 | 8h |
| 36 | 3.1.1.3 | 制定广告战略 |  | 1d? | 2007-01-17 | 2007-01-17 | 35 | 0d | 营销代表 | 8h |
| 37 | 3.1.1.4 | 选择外部供应商 |  | 1d? | 2007-01-18 | 2007-01-18 | 36 | 0d | 营销代表 | 8h |
| 38 | 3.1.1.5 | 执行广告计划 |  | 1d? | 2007-01-19 | 2007-01-19 | 37 | 0d | 营销代表 | 8h |
| 39 | 3.1.1.6 | 传播策划(内部) |  | 1d? | 2007-01-22 | 2007-01-22 | 38 | 0d | 营销代表 | 8h |
| 40 | 3.1.1.7 | 创建营销宣传品 |  | 1d? | 2007-01-23 | 2007-01-23 | 39 | 0d | 营销代表 | 8h |
| 41 | 3.1.1.8 | 对面向客户的材料进行法律问题审核 |  | 1d? | 2007-01-24 | 2007-01-24 | 40 | 0d | 营销代表; 法律事务代表 | 16h |
| 42 | 3.1.1.9 | 完成营销活动 | milestone | 0d | 2007-01-24 | 2007-01-24 | 41 | 0d |  |  |
| 43 | 3.1.2 | **进行销售人员入职准备活动** |  | 2d? | 2007-01-25 | 2007-01-26 |  | 0d |  | 40h |
| 44 | 3.1.2.1 | 制定总体销售战略 |  | 1d? | 2007-01-25 | 2007-01-25 | 42 | 0d | 销售代表 | 8h |
| 45 | 3.1.2.2 | **开展针对所有销售资源的销售入职准备培训** |  | 1d? | 2007-01-26 | 2007-01-26 |  | 0d |  | 16h |
| 46 | 3.1.2.2.1 | 销售工作组内部培训 |  | 1d? | 2007-01-26 | 2007-01-26 | 44 | 0d | 销售代表 | 8h |
| 47 | 3.1.2.2.2 | 销售工作组外部培训 |  | 1d? | 2007-01-26 | 2007-01-26 | 44 | 0d | 销售代表 | 8h |
| 48 | 3.1.2.3 | 参与一般销售人员入职准备活动 |  | 1d? | 2007-01-26 | 2007-01-26 | 44 | 0d | 销售代表 | 8h |
| 49 | 3.1.2.4 | 更新面向客户的网站 - 服务说明 |  | 1d? | 2007-01-26 | 2007-01-26 | 44 | 0d | 销售代表 | 8h |
| 50 | 3.1.2.5 | 完成销售准备活动 | milestone | 0d | 2007-01-26 | 2007-01-26 | 49, 44, 46, 47, 48 | 0d |  |  |
| 51 | 3.2 | **客户服务和内部履行准备** |  | 1d? | 2007-01-29 | 2007-01-29 |  | 0d |  | 24h |
| 52 | 3.2.1 | 培训电话代表 |  | 1d? | 2007-01-29 | 2007-01-29 | 50, 42 | 0d | 运营代表 | 8h |
| 53 | 3.2.2 | 培训现场分公司代表 |  | 1d? | 2007-01-29 | 2007-01-29 | 42, 50 | 0d | 运营代表 | 8h |
| 54 | 3.2.3 | 执行系统更新 |  | 1d? | 2007-01-29 | 2007-01-29 | 42, 50 | 0d | 运营代表 | 8h |
| 55 | 3.2.4 | 完成客户服务准备 | milestone | 0d | 2007-01-29 | 2007-01-29 | 54, 52, 53 | 0d |  |  |

Notes:
- 31: 理想情况下，此部分中的活动并非都是连续的。然而，根据资源安排和外包决定，可以并发执行的活动也有所不同。因此，我们将每一部分都视为连续活动。此模板的用户应对活动进行审核，并确定可以并发运行的活动。
- 51: 此模板着重于营销和产品上市。该模板假定已将订单履行组件定型为其他计划的一部分。此处包含的这组任务可以确保这些相同的订单履行组件能够识别营销/产品上市活动，并为该活动做好准备。

| ID | WBS | Task | Type | Duration | Start | Finish | Predecessors | Total slack | Resources | Work |
| --- | --- | --- | --- | --- | --- | --- | --- | --- | --- | --- |
| 56 | 3.3 | **创建报告/监控流程和系统** |  | 4d? | 2007-01-30 | 2007-02-02 |  | 0d |  | 32h |
| 57 | 3.3.1 | 审核新服务的业务目标 |  | 1d? | 2007-01-30 | 2007-01-30 | 50, 55 | 0d | 初始工作组 | 8h |
| 58 | 3.3.2 | 确定服务成功标准 |  | 1d? | 2007-01-31 | 2007-01-31 | 57 | 0d | 初始工作组 | 8h |
| 59 | 3.3.3 | 创建新服务业务监控流程 |  | 1d? | 2007-02-01 | 2007-02-01 | 58 | 0d | 初始工作组 | 8h |
| 60 | 3.3.4 | 创建报告基本架构 |  | 1d? | 2007-02-02 | 2007-02-02 | 59 | 0d | 初始工作组 | 8h |
| 61 | 3.3.5 | 完成报告/监控流程和系统创建工作 | milestone | 0d | 2007-02-02 | 2007-02-02 | 60 | 0d |  |  |
| 62 | 3.4 | **更新操作流程和系统** |  | 4d? | 2007-02-05 | 2007-02-08 |  | 0d |  | 32h |
| 63 | 3.4.1 | 更新监控/报告 - 交易系统 |  | 1d? | 2007-02-05 | 2007-02-05 | 61 | 0d | IT 代表 | 8h |
| 64 | 3.4.2 | 培训防损资源 |  | 1d? | 2007-02-06 | 2007-02-06 | 63 | 0d | 运营代表 | 8h |
| 65 | 3.4.3 | **执行法律问题审核活动** |  | 2d? | 2007-02-07 | 2007-02-08 |  | 0d |  | 16h |
| 66 | 3.4.3.1 | 拟定服务协议条款 |  | 1d? | 2007-02-07 | 2007-02-07 | 64 | 0d | 法律事务代表 | 8h |
| 67 | 3.4.3.2 | 确认新服务符合法规要求 |  | 1d? | 2007-02-08 | 2007-02-08 | 66 | 0d | 法律事务代表 | 8h |
| 68 | 3.4.4 | 完成运营准备 | milestone | 0d | 2007-02-08 | 2007-02-08 | 67 | 0d |  |  |
| 69 | 3.5 | **更新技术服务和系统** |  | 5d? | 2007-02-09 | 2007-02-15 |  | 0d |  | 40h |
| 70 | 3.5.1 | 更新交易系统(软件) |  | 1d? | 2007-02-09 | 2007-02-09 | 68 | 0d | IT 代表 | 8h |
| 71 | 3.5.2 | 提高交易能力(硬件) |  | 1d? | 2007-02-12 | 2007-02-12 | 70 | 0d | IT 代表 | 8h |
| 72 | 3.5.3 | 执行常规技术更新 |  | 1d? | 2007-02-13 | 2007-02-13 | 71 | 0d | IT 代表 | 8h |
| 73 | 3.5.4 | 更新面向客户的网站(内容) |  | 1d? | 2007-02-14 | 2007-02-14 | 72 | 0d | 营销代表 | 8h |
| 74 | 3.5.5 | 更新面向客户的网站(基础架构) |  | 1d? | 2007-02-15 | 2007-02-15 | 73 | 0d | IT 代表 | 8h |
| 75 | 3.5.6 | 完成技术更新 | milestone | 0d | 2007-02-15 | 2007-02-15 | 74 | 0d |  |  |
| 76 | 3.6 | 产品上市 | milestone | 0d | 2007-02-15 | 2007-02-15 | 75 | 0d | 初始工作组 |  |
| 77 | 4 | **第 3 阶段 - 产品上市后 - 服务监控** |  | 3d? | 2007-02-16 | 2007-02-20 |  | 0d |  | 24h |
| 78 | 4.1 | 监控产品上市成功率以及计划阶段定义的影响标准 |  | 1d? | 2007-02-16 | 2007-02-16 | 76 | 0d | 初始工作组 | 8h |
| 79 | 4.2 | **事后 - 审核执行计划** |  | 2d? | 2007-02-19 | 2007-02-20 |  | 0d |  | 16h |
| 80 | 4.2.1 | 确定产品上市中的薄弱环节 |  | 1d? | 2007-02-19 | 2007-02-19 | 78 | 0d | 初始工作组 | 8h |
| 81 | 4.2.2 | 确定将来提供服务的最佳做法 |  | 1d? | 2007-02-20 | 2007-02-20 | 80 | 0d | 初始工作组 | 8h |
| 82 | 4.2.3 | 完成执行计划审核 | milestone | 0d | 2007-02-20 | 2007-02-20 | 81 | 0d |  |  |
| 83 | 5 | 完成产品上市项目 | milestone | 0d | 2007-02-20 | 2007-02-20 | 82 | 0d |  |  |

Notes:
- 58: 我们可以确保具有具体的成功标准。这些标准与规划部分确定的一般成功标准一致。
- 76: 产品上市在此处被视为里程碑，但因为产品在多个地区上市，因此也可以是一个持续的时间。此种情况下，执行阶段可以在所有产品上市地点进行，也可以在各个产品上市地点进行。
- 78: 这将在产品上市期间以及稍后的一段时间内执行(由初始工作组指定)。
- 80: 确定与服务内容有关的内部问题或意外的客户问题。 / 按需要将活动计划分离，或按需要收集必备知识供下次产品上市使用。
- 83: 这将真正结束此产品上市换代。换而言之，我们已经将产品投放市场、监控其结果、收集反馈，并将反馈纳入下次产品上市的准备工作中。
