# 战略合并或收购评估

Schedule from MS Project, 2007-01-01 to 2007-04-04.
从战略性业务发展角度来看，此模板可以处理公司为确定业务发展战略而开展的常规活动。路线图包括了解市场定位、评估并购与内部开发间的均衡关系、评估并购对象以及评估目标公司。

## Calendars

- 标准: Mon-Fri 08:00-12:00, 13:00-17:00; Sat-Sun off.

## Resources

| Resource |
| --- |
| 关键执行委员会 |
| 合并和收购工作组 |
| 投资银行家 |

## Schedule

| ID | WBS | Task | Type | Duration | Start | Finish | Predecessors | Total slack | Free slack | Resources | Work |
| --- | --- | --- | --- | --- | --- | --- | --- | --- | --- | --- | --- |
| 1 | 1 | **制定合并和收购策略** |  | 10d? | 2007-01-01 | 2007-01-12 |  | 0d |  |  | 120h |
| 2 | 1.1 | **确定当前能力和定位** |  | 3d? | 2007-01-01 | 2007-01-03 |  | 0d |  |  | 24h |
| 3 | 1.1.1 | 进行竞争分析 |  | 1d? | 2007-01-01 | 2007-01-01 |  | 0d |  | 关键执行委员会 | 8h |
| 4 | 1.1.2 | 进行市场趋势分析 |  | 1d? | 2007-01-02 | 2007-01-02 | 3 | 0d |  | 关键执行委员会 | 8h |
| 5 | 1.1.3 | 确定当前定位和差距 |  | 1d? | 2007-01-03 | 2007-01-03 | 4 | 0d |  | 关键执行委员会 | 8h |
| 6 | 1.1.4 | 完成当前定位分析 | milestone | 0d | 2007-01-03 | 2007-01-03 | 5 | 0d |  |  |  |
| 7 | 1.2 | **确定合并/收购目标** |  | 4d? | 2007-01-04 | 2007-01-09 |  | 0d |  |  | 32h |
| 8 | 1.2.1 | 确定合并和收购的战略目标 |  | 1d? | 2007-01-04 | 2007-01-04 | 6 | 0d |  | 关键执行委员会 | 8h |
| 9 | 1.2.2 | **确定合并和收购的风险允许范围** |  | 3d? | 2007-01-05 | 2007-01-09 |  | 9d |  |  | 24h |
| 10 | 1.2.2.1 | 确定财务风险允许范围 |  | 1d? | 2007-01-05 | 2007-01-05 | 8 | 9d | 0d | 关键执行委员会 | 8h |
| 11 | 1.2.2.2 | 确定市场定位风险允许范围 |  | 1d? | 2007-01-08 | 2007-01-08 | 10 | 9d | 0d | 关键执行委员会 | 8h |
| 12 | 1.2.2.3 | 确定能力风险允许范围 |  | 1d? | 2007-01-09 | 2007-01-09 | 11 | 9d | 0d | 关键执行委员会 | 8h |
| 13 | 1.2.2.4 | 完成风险允许范围评估 | milestone | 0d | 2007-01-09 | 2007-01-09 | 12 | 9d | 0d | 关键执行委员会 |  |
| 14 | 1.3 | **确定内部对比合并和收购评估标准** |  | 3d? | 2007-01-10 | 2007-01-12 |  | 9d |  |  | 24h |
| 15 | 1.3.1 | 确定内部开发能力模式 |  | 1d? | 2007-01-10 | 2007-01-10 | 13 | 9d | 0d | 关键执行委员会 | 8h |
| 16 | 1.3.2 | 确定内部对比合并和收购比较模式 |  | 1d? | 2007-01-11 | 2007-01-11 | 15 | 9d | 0d | 关键执行委员会 | 8h |
| 17 | 1.3.3 | 确定选择方案和目标性能措施 |  | 1d? | 2007-01-12 | 2007-01-12 | 16 | 9d | 0d | 关键执行委员会 | 8h |
| 18 | 1.3.4 | 完成内部对比合并和收购评估标准 | milestone | 0d | 2007-01-12 | 2007-01-12 | 17 | 9d | 0d | 关键执行委员会 |  |
| 19 | 1.4 | **建立合并和收购工作组** |  | 5d? | 2007-01-05 | 2007-01-11 |  | 0d |  |  | 40h |
| 20 | 1.4.1 | 确定合并和收购工作组成员 |  | 1d? | 2007-01-05 | 2007-01-05 | 8 | 0d |  | 关键执行委员会 | 8h |
| 21 | 1.4.2 | 合并和收购工作组章程编档 |  | 1d? | 2007-01-08 | 2007-01-08 | 20 | 0d |  | 关键执行委员会 | 8h |
| 22 | 1.4.3 | 设置合并和收购工作组主要里程碑 |  | 1d? | 2007-01-09 | 2007-01-09 | 21 | 0d |  | 关键执行委员会 | 8h |
| 23 | 1.4.4 | 设置合并和收购工作组过程 |  | 1d? | 2007-01-10 | 2007-01-10 | 22 | 0d |  | 关键执行委员会 | 8h |
| 24 | 1.4.5 | 举行合并和收购工作组启动会议 |  | 1d? | 2007-01-11 | 2007-01-11 | 23 | 0d |  | 关键执行委员会 | 8h |
| 25 | 1.4.6 | 完成建立合并和收购工作组 | milestone | 0d | 2007-01-11 | 2007-01-11 | 24 | 0d |  |  |  |

| ID | WBS | Task | Type | Duration | Start | Finish | Predecessors | Total slack | Resources | Work |
| --- | --- | --- | --- | --- | --- | --- | --- | --- | --- | --- |
| 26 | 2 | **确定合并和收购目标确认和筛选标准** |  | 11d? | 2007-01-12 | 2007-01-26 |  | 0d |  | 88h |
| 27 | 2.1 | **确定目标识别标准** |  | 6d? | 2007-01-12 | 2007-01-19 |  | 0d |  | 48h |
| 28 | 2.1.1 | 确定行业、产品和渠道标准 |  | 1d? | 2007-01-12 | 2007-01-12 | 19, 25 | 0d | 合并和收购工作组 | 8h |
| 29 | 2.1.2 | 确定盈利能力、资本化和现金流标准 |  | 1d? | 2007-01-15 | 2007-01-15 | 28 | 0d | 合并和收购工作组 | 8h |
| 30 | 2.1.3 | 确定知识产权和研发标准 |  | 1d? | 2007-01-16 | 2007-01-16 | 29 | 0d | 合并和收购工作组 | 8h |
| 31 | 2.1.4 | 确定管理、组织和控制标准 |  | 1d? | 2007-01-17 | 2007-01-17 | 30 | 0d | 合并和收购工作组 | 8h |
| 32 | 2.1.5 | 确定风险、法律和财务公开标准 |  | 1d? | 2007-01-18 | 2007-01-18 | 31 | 0d | 合并和收购工作组 | 8h |
| 33 | 2.1.6 | 确定和汇总协同标准 |  | 1d? | 2007-01-19 | 2007-01-19 | 32 | 0d | 合并和收购工作组 | 8h |
| 34 | 2.1.7 | 完成目标确定标准 | milestone | 0d | 2007-01-19 | 2007-01-19 | 33 | 0d |  |  |
| 35 | 2.2 | **确定定量和定性筛选标准** |  | 5d? | 2007-01-22 | 2007-01-26 |  | 0d |  | 40h |
| 36 | 2.2.1 | 确定行业、产品和渠道筛选 |  | 1d? | 2007-01-22 | 2007-01-22 | 34 | 0d | 合并和收购工作组 | 8h |
| 37 | 2.2.2 | 确定盈利能力、资本化和现金流筛选 |  | 1d? | 2007-01-23 | 2007-01-23 | 36 | 0d | 合并和收购工作组 | 8h |
| 38 | 2.2.3 | 确定知识产权和研发筛选 |  | 1d? | 2007-01-24 | 2007-01-24 | 37 | 0d | 合并和收购工作组 | 8h |
| 39 | 2.2.4 | 确定管理、组织和控制筛选 |  | 1d? | 2007-01-25 | 2007-01-25 | 38 | 0d | 合并和收购工作组 | 8h |
| 40 | 2.2.5 | 确定风险、法律和财务公开允许范围筛选 |  | 1d? | 2007-01-26 | 2007-01-26 | 39 | 0d | 合并和收购工作组 | 8h |
| 41 | 2.2.6 | 完成筛选标准 | milestone | 0d | 2007-01-26 | 2007-01-26 | 40 | 0d |  |  |
| 42 | 3 | **制定潜在收购列表** |  | 40d? | 2007-01-15 | 2007-03-09 |  | 0d |  | 248h |
| 43 | 3.1 | 选择投资银行家 |  | 1d? | 2007-01-15 | 2007-01-15 | 18 | 9d | 合并和收购工作组 | 8h |
| 44 | 3.2 | 制定潜在收购列表 |  | 30d? | 2007-01-29 | 2007-03-09 | 43, 41 | 0d | 投资银行家 | 240h |
| 45 | 3.3 | 完成潜在收购列表 | milestone | 0d | 2007-03-09 | 2007-03-09 | 44 | 0d |  |  |
| 46 | 4 | **进行合并和收购目标评估分析和审慎调查** |  | 11d? | 2007-03-12 | 2007-03-26 |  | 0d |  | 200h |
| 47 | 4.1 | **进行评估分析** |  | 3d? | 2007-03-12 | 2007-03-14 |  | 0d |  | 136h |
| 48 | 4.1.1 | **进行财务评估分析** |  | 3d? | 2007-03-12 | 2007-03-14 |  | 0d |  | 24h |
| 49 | 4.1.1.1 | 确定财务方案 |  | 1d? | 2007-03-12 | 2007-03-12 | 45 | 0d | 合并和收购工作组 | 8h |
| 50 | 4.1.1.2 | 制定财务协同分析 |  | 1d? | 2007-03-13 | 2007-03-13 | 49 | 0d | 合并和收购工作组 | 8h |
| 51 | 4.1.1.3 | 确定财务风险和机会 |  | 1d? | 2007-03-14 | 2007-03-14 | 50 | 0d | 合并和收购工作组 | 8h |

Notes:
- 26: 本部分将制定发给经纪人标准，用于建立公司可能性列表。
- 50: 例如，本次收购/合并在财务上是否符合以前确定并且一直在努力支持的策略?

| ID | WBS | Task | Type | Duration | Start | Finish | Predecessors | Total slack | Free slack | Resources | Work |
| --- | --- | --- | --- | --- | --- | --- | --- | --- | --- | --- | --- |
| 52 | 4.1.2 | **进行市场和产品分析** |  | 3d? | 2007-03-12 | 2007-03-14 |  | 0d |  |  | 24h |
| 53 | 4.1.2.1 | 确定市场协同 |  | 1d? | 2007-03-12 | 2007-03-12 | 45 | 0d |  | 合并和收购工作组 | 8h |
| 54 | 4.1.2.2 | 确定产品协同 |  | 1d? | 2007-03-13 | 2007-03-13 | 53 | 0d |  | 合并和收购工作组 | 8h |
| 55 | 4.1.2.3 | 确定联合投资组合策略 |  | 1d? | 2007-03-14 | 2007-03-14 | 54 | 0d |  | 合并和收购工作组 | 8h |
| 56 | 4.1.3 | 进行行业特定分析 |  | 1d? | 2007-03-12 | 2007-03-12 | 45 | 2d |  | 合并和收购工作组 | 8h |
| 57 | 4.1.4 | 进行知识产权和研发分析(如果合适) |  | 1d? | 2007-03-12 | 2007-03-12 | 45 | 2d |  | 合并和收购工作组 | 8h |
| 58 | 4.1.5 | **进行法律和政府一致性分析** |  | 3d? | 2007-03-12 | 2007-03-14 |  | 0d |  |  | 24h |
| 59 | 4.1.5.1 | 确定法律风险、问题和协同 |  | 1d? | 2007-03-12 | 2007-03-12 | 45 | 0d |  | 合并和收购工作组 | 8h |
| 60 | 4.1.5.2 | 确定 SEC 一致性风险、问题和方案 |  | 1d? | 2007-03-13 | 2007-03-13 | 59 | 0d |  | 合并和收购工作组 | 8h |
| 61 | 4.1.5.3 | 确定其他政府管理风险、问题和协同 |  | 1d? | 2007-03-14 | 2007-03-14 | 60 | 0d |  | 合并和收购工作组 | 8h |
| 62 | 4.1.6 | **进行管理和公司控制分析** |  | 3d? | 2007-03-12 | 2007-03-14 |  | 0d |  |  | 24h |
| 63 | 4.1.6.1 | 确定管理协同和方案 |  | 1d? | 2007-03-12 | 2007-03-12 | 45 | 0d |  | 合并和收购工作组 | 8h |
| 64 | 4.1.6.2 | 确定公司控制协同和方案 |  | 1d? | 2007-03-13 | 2007-03-13 | 63 | 0d |  | 合并和收购工作组 | 8h |
| 65 | 4.1.6.3 | 确定机构股东协同、影响和方案 |  | 1d? | 2007-03-14 | 2007-03-14 | 64 | 0d |  | 合并和收购工作组 | 8h |
| 66 | 4.1.7 | **最终确定审慎调查清单** |  | 3d? | 2007-03-12 | 2007-03-14 |  | 15d |  |  | 24h |
| 67 | 4.1.7.1 | 确定审慎调查活动优先次序 |  | 1d? | 2007-03-12 | 2007-03-12 | 45 | 15d | 0d | 合并和收购工作组 | 8h |
| 68 | 4.1.7.2 | 分配审慎调查活动 |  | 1d? | 2007-03-13 | 2007-03-13 | 67 | 15d | 0d | 合并和收购工作组 | 8h |
| 69 | 4.1.7.3 | 确定审慎调查日程 |  | 1d? | 2007-03-14 | 2007-03-14 | 68 | 15d |  | 合并和收购工作组 | 8h |
| 70 | 4.1.8 | 完成评估分析 | milestone | 0d | 2007-03-14 | 2007-03-14 | 51, 55, 56, 57, 61, 65 | 0d |  |  |  |
| 71 | 4.2 | **进行审慎调查活动** |  | 8d? | 2007-03-15 | 2007-03-26 |  | 0d |  |  | 64h |
| 72 | 4.2.1 | 进行金融成本/收益审慎调查 |  | 1d? | 2007-03-15 | 2007-03-15 | 70 | 0d |  | 合并和收购工作组 | 8h |
| 73 | 4.2.2 | 进行财务报告要求审慎调查 |  | 1d? | 2007-03-16 | 2007-03-16 | 72 | 0d |  | 合并和收购工作组 | 8h |
| 74 | 4.2.3 | 进行市场和产品审慎调查 |  | 1d? | 2007-03-19 | 2007-03-19 | 73 | 0d |  | 合并和收购工作组 | 8h |
| 75 | 4.2.4 | 进行行业特定审慎调查 |  | 1d? | 2007-03-20 | 2007-03-20 | 74 | 0d |  | 合并和收购工作组 | 8h |
| 76 | 4.2.5 | 进行知识产权和研发审慎调查 |  | 1d? | 2007-03-21 | 2007-03-21 | 75 | 0d |  | 合并和收购工作组 | 8h |
| 77 | 4.2.6 | 进行法律、风险和政府一致性审慎调查 |  | 1d? | 2007-03-22 | 2007-03-22 | 76 | 0d |  | 合并和收购工作组 | 8h |
| 78 | 4.2.7 | 进行管理和公司控制审慎调查 |  | 1d? | 2007-03-23 | 2007-03-23 | 77 | 0d |  | 合并和收购工作组 | 8h |
| 79 | 4.2.8 | 汇编审慎调查评估结果 |  | 1d? | 2007-03-26 | 2007-03-26 | 78 | 0d |  | 合并和收购工作组 | 8h |
| 80 | 4.2.9 | 完成审慎调查评估 | milestone | 0d | 2007-03-26 | 2007-03-26 | 79 | 0d |  |  |  |
| 81 | 4.3 | 完成评估和审慎调查 | milestone | 0d | 2007-03-26 | 2007-03-26 | 70, 80 | 0d |  |  |  |

Notes:
- 56: 例如，对于制造公司: / 确定全球/本地分销渠道分析 / 确定供应链协同和风险
- 75: 行业特定的审慎调查的一个实例，如分析制造和分销能力，或其他行业特定的与履行相关的过程。

| ID | WBS | Task | Type | Duration | Start | Finish | Predecessors | Total slack | Resources | Work |
| --- | --- | --- | --- | --- | --- | --- | --- | --- | --- | --- |
| 82 | 5 | **进行选择** |  | 2d? | 2007-03-27 | 2007-03-28 |  | 0d |  | 24h |
| 83 | 5.1 | 列出选择结果 |  | 1d? | 2007-03-27 | 2007-03-27 | 81 | 0d | 关键执行委员会; 合并和收购工作组 | 16h |
| 84 | 5.2 | 确认初始选择 |  | 1d? | 2007-03-28 | 2007-03-28 | 83 | 0d | 关键执行委员会 | 8h |
| 85 | 5.3 | 完成初始选择 | milestone | 0d | 2007-03-28 | 2007-03-28 | 84 | 0d |  |  |
| 86 | 6 | **进行投资活动** |  | 5d? | 2007-03-29 | 2007-04-04 |  | 0d |  | 40h |
| 87 | 6.1 | 制定合并/收购融资策略 |  | 1d? | 2007-03-29 | 2007-03-29 | 85 | 0d | 合并和收购工作组 | 8h |
| 88 | 6.2 | 制定 SEC 文档 |  | 1d? | 2007-03-30 | 2007-03-30 | 87 | 0d | 合并和收购工作组 | 8h |
| 89 | 6.3 | 保护融资安全 |  | 1d? | 2007-04-02 | 2007-04-02 | 88 | 0d | 合并和收购工作组 | 8h |
| 90 | 6.4 | 准备和举行代理投票 |  | 1d? | 2007-04-03 | 2007-04-03 | 89 | 0d | 合并和收购工作组 | 8h |
| 91 | 6.5 | 最终确定投资活动 |  | 1d? | 2007-04-04 | 2007-04-04 | 90 | 0d | 合并和收购工作组 | 8h |
| 92 | 6.6 | 完成交易 | milestone | 0d | 2007-04-04 | 2007-04-04 | 91 | 0d | 关键执行委员会 |  |
| 93 | 7 | 完成合并和收购交易 | milestone | 0d | 2007-04-04 | 2007-04-04 | 92 | 0d |  |  |
