# 策划营销活动

Schedule from MS Project, 2007-01-01 to 2007-10-12.
成功的活动应是经过缜密研究、深思熟虑之后，并注重细节和执行情况的活动。策划营销活动时，在活动的开始阶段首先应了解您的市场定位，在活动的结束阶段应当收集数据并对活动的有效性进行分析。此模板罗列了组织在策划营销活动时应当考虑的各种事项。

## Calendars

- 标准: Mon-Fri 08:00-12:00, 13:00-17:00; Sat-Sun off.

## Resources

| Resource |
| --- |
| 后勤领导组 |
| 营销领导组 |
| 赞助商 |
| 销售人员 |
| 创意人员 |
| 内容顾问 |
| 营销人员 |
| 营销研究人员 |
| 公司赞助商 |
| 主题专家 |
| 内部销售人员 |
| 营销人员 |
| 产品营销人员 |
| 区域总经理 |
| 国家(地区)经理 |
| 战略联盟领导组 |
| 营销代表 |
| 营销研究人员 |
| 内部 PR |
| PR 公司 |
| 供应商 |

## Schedule

| ID | WBS | Task | Type | Duration | Start | Finish | Predecessors | Total slack | Free slack | Resources | Work |
| --- | --- | --- | --- | --- | --- | --- | --- | --- | --- | --- | --- |
| 1 | 1 | **审阅业务策略前景** |  | 27d? | 2007-01-01 | 2007-02-06 |  | 0d |  |  | 256h |
| 2 | 1.1 | 确定服务/产品差距和机会 |  | 5d? | 2007-01-01 | 2007-01-05 |  | 0d |  | 营销领导组 | 40h |
| 3 | 1.2 | 分析完成 SWOT |  | 5d? | 2007-01-08 | 2007-01-12 | 2 | 0d |  | 营销领导组 | 40h |
| 4 | 1.3 | 审阅业务模式 |  | 1d? | 2007-01-15 | 2007-01-15 | 3 | 0d |  | 营销领导组 | 8h |
| 5 | 1.4 | 审阅组织营销策略 |  | 3d? | 2007-01-16 | 2007-01-18 | 4 | 0d |  | 营销领导组 | 24h |
| 6 | 1.5 | 审阅本地营销策略 |  | 1d? | 2007-01-19 | 2007-01-19 | 5 | 0d |  | 营销领导组 | 8h |
| 7 | 1.6 | 审阅全球营销策略 |  | 1d? | 2007-01-22 | 2007-01-22 | 6 | 0d |  | 营销代表 | 8h |
| 8 | 1.7 | 审阅营销计划以确定活动预算 |  | 1d? | 2007-01-23 | 2007-01-23 | 7 | 0d |  | 营销代表 | 8h |
| 9 | 1.8 | 建立组织的走向市场策略 |  | 1d? | 2007-01-24 | 2007-01-24 | 8 | 0d |  | 营销领导组 | 8h |
| 10 | 1.9 | 评估公司策略目标定位 |  | 2d? | 2007-01-25 | 2007-01-26 | 9 | 0d |  | 营销领导组; 赞助商 | 32h |
| 11 | 1.10 | 评估竞争优势 |  | 3d? | 2007-01-29 | 2007-01-31 | 10 | 0d |  | 营销领导组; 营销研究人员 | 48h |
| 12 | 1.11 | 审阅产品和服务利润 |  | 3d? | 2007-02-01 | 2007-02-05 | 11 | 0d |  | 营销领导组 | 24h |
| 13 | 1.12 | 审阅先前的活动业绩 |  | 1d? | 2007-02-06 | 2007-02-06 | 12 | 0d |  | 营销领导组 | 8h |
| 14 | 1.13 | 完成业务策略前景审阅 | milestone | 0d | 2007-02-06 | 2007-02-06 | 13 | 0d |  |  |  |
| 15 | 2 | **制定活动概念** |  | 49d? | 2007-02-07 | 2007-04-16 |  | 0d |  |  | 504h |
| 16 | 2.1 | 创建验证设想的过程 |  | 5d? | 2007-02-07 | 2007-02-13 | 14 | 0d |  | 营销人员 | 40h |
| 17 | 2.2 | 创建共享设想的过程 |  | 5d? | 2007-02-14 | 2007-02-20 | 16 | 0d |  | 营销人员 | 40h |
| 18 | 2.3 | 收集设想 |  | 1d? | 2007-02-21 | 2007-02-21 | 17 | 0d |  |  |  |
| 19 | 2.4 | 设想的最终形成和确定 |  | 5d? | 2007-02-22 | 2007-02-28 | 18 | 0d |  | 营销领导组 | 40h |
| 20 | 2.5 | 研究市场环境 |  | 5d? | 2007-03-01 | 2007-03-07 | 19 | 0d |  | 营销研究人员 | 40h |
| 21 | 2.6 | 制定初步活动概念 |  | 5d? | 2007-03-08 | 2007-03-14 | 20 | 0d |  | 营销领导组 | 40h |
| 22 | 2.7 | 确定活动目标 |  | 2d? | 2007-03-15 | 2007-03-16 | 21 | 0d |  | 营销领导组 | 16h |
| 23 | 2.8 | 制定衡量活动成功的标准 |  | 2d? | 2007-03-19 | 2007-03-20 | 22 | 0d |  | 营销代表 | 16h |
| 24 | 2.9 | 制定活动跟踪和分析过程 |  | 3d? | 2007-03-21 | 2007-03-23 | 23 | 0d |  | 营销人员 | 24h |
| 25 | 2.10 | 通过测试群体和市场研究验证概念 |  | 5d? | 2007-03-26 | 2007-03-30 | 24 | 0d |  | 营销代表 | 40h |
| 26 | 2.11 | 建立活动焦点列表 |  | 1d? | 2007-04-02 | 2007-04-02 | 25 | 0d |  | 营销代表 | 8h |
| 27 | 2.12 | 建立活动类别 |  | 1d? | 2007-04-03 | 2007-04-03 | 26 | 5d | 0d | 营销代表 | 8h |
| 28 | 2.13 | 制定公共关系策略 |  | 3d? | 2007-04-04 | 2007-04-06 | 27 | 5d | 0d | 内部 PR | 24h |
| 29 | 2.14 | 为促销建立初步理想活动时间 |  | 1d? | 2007-04-09 | 2007-04-09 | 28 | 5d |  | 营销代表 | 8h |
| 30 | 2.15 | 确定组织区域活动 |  | 5d? | 2007-04-03 | 2007-04-09 | 26 | 0d |  | 营销领导组 | 40h |
| 31 | 2.16 | 确定组织全球活动 |  | 5d? | 2007-04-03 | 2007-04-09 | 26 | 0d |  | 营销领导组 | 40h |
| 32 | 2.17 | 确定组织国家(地区)活动 |  | 5d? | 2007-04-03 | 2007-04-09 | 26 | 0d |  | 营销领导组 | 40h |
| 33 | 2.18 | 确定本地化要求 |  | 5d? | 2007-04-10 | 2007-04-16 | 30, 31, 32 | 0d |  | 营销人员 | 40h |
| 34 | 2.19 | 完成活动概念 | milestone | 0d | 2007-04-16 | 2007-04-16 | 33, 29 | 0d |  |  |  |

Notes:
- 3: SWOT 优势、弱点、机会、威胁

| ID | WBS | Task | Type | Duration | Start | Finish | Predecessors | Total slack | Free slack | Resources | Work |
| --- | --- | --- | --- | --- | --- | --- | --- | --- | --- | --- | --- |
| 35 | 3 | **创建本地化策略** |  | 18d? | 2007-04-17 | 2007-05-10 |  | 0d |  |  | 224h |
| 36 | 3.1 | 审阅公司销售目标 |  | 1d? | 2007-04-17 | 2007-04-17 | 34 | 0d |  | 营销人员 | 8h |
| 37 | 3.2 | 审阅区域业务模式 |  | 1d? | 2007-04-17 | 2007-04-17 | 34 | 0d |  | 营销代表 | 8h |
| 38 | 3.3 | 审阅全球/国家(地区)业务模式 |  | 1d? | 2007-04-17 | 2007-04-17 | 34 | 0d |  | 营销代表 | 8h |
| 39 | 3.4 | 审阅营销目标 |  | 1d? | 2007-04-17 | 2007-04-17 | 34 | 0d |  | 营销代表 | 8h |
| 40 | 3.5 | 审阅营销计划 |  | 1d? | 2007-04-17 | 2007-04-17 | 34 | 0d |  | 营销代表 | 8h |
| 41 | 3.6 | 建立活动机会 |  | 3d? | 2007-04-18 | 2007-04-20 | 36, 37, 38, 39, 40 | 0d |  | 营销代表 | 24h |
| 42 | 3.7 | 审阅服务、产品组合和预测 |  | 3d? | 2007-04-23 | 2007-04-25 | 41 | 0d |  | 营销代表 | 24h |
| 43 | 3.8 | 审阅产品发布周期 |  | 3d? | 2007-04-26 | 2007-04-30 | 42 | 6d |  | 营销代表 | 24h |
| 44 | 3.9 | 确定每个区域的活动组合 |  | 3d? | 2007-04-26 | 2007-04-30 | 42 | 0d |  | 营销领导组 | 24h |
| 45 | 3.10 | 确定每个区域的活动成功量度标准 |  | 3d? | 2007-05-01 | 2007-05-03 | 44 | 0d |  | 营销领导组; 区域总经理 | 48h |
| 46 | 3.11 | 确定跟踪机制 |  | 3d? | 2007-05-04 | 2007-05-08 | 45 | 0d |  | 营销人员 | 24h |
| 47 | 3.12 | 创建本地化策略 |  | 2d? | 2007-05-09 | 2007-05-10 | 46, 44, 43 | 0d |  | 营销人员 | 16h |
| 48 | 3.13 | 完成本地化策略 | milestone | 0d | 2007-05-10 | 2007-05-10 | 47 | 0d |  |  |  |
| 49 | 4 | **与内部组织交流并进行培训** |  | 24d? | 2007-05-11 | 2007-06-13 |  | 0d |  |  | 240h |
| 50 | 4.1 | 建立公司内部交流过程 |  | 3d? | 2007-05-11 | 2007-05-15 | 48 | 0d |  | 营销人员 | 24h |
| 51 | 4.2 | 确定区域和国家(地区)部门交流过程 |  | 5d? | 2007-05-16 | 2007-05-22 | 50 | 0d |  | 营销人员 | 40h |
| 52 | 4.3 | 计划交流方法、后勤和时间 |  | 4d? | 2007-05-23 | 2007-05-28 | 51 | 0d |  | 后勤领导组; 营销人员 | 64h |
| 53 | 4.4 | 就销售、营销和管理进行区域和国家(地区)交流 |  | 5d? | 2007-05-29 | 2007-06-04 | 52 | 0d |  | 营销代表 | 40h |
| 54 | 4.5 | 确定响应活动的内部系统 |  | 5d? | 2007-06-05 | 2007-06-11 | 53 | 0d |  | 营销人员 | 40h |
| 55 | 4.6 | 创建交流计划 |  | 2d? | 2007-06-12 | 2007-06-13 | 54 | 0d |  |  |  |
| 56 | 4.7 | 确定内部培训需求 |  | 1d? | 2007-05-11 | 2007-05-11 | 48 | 20d | 0d | 营销人员 | 8h |
| 57 | 4.8 | 制定内部培训 |  | 3d? | 2007-05-14 | 2007-05-16 | 56 | 20d |  | 营销人员 | 24h |
| 58 | 4.9 | 完成组织内部交流和培训 | milestone | 0d | 2007-06-13 | 2007-06-13 | 55, 57 | 0d |  |  |  |

| ID | WBS | Task | Type | Duration | Start | Finish | Predecessors | Total slack | Free slack | Resources | Work |
| --- | --- | --- | --- | --- | --- | --- | --- | --- | --- | --- | --- |
| 59 | 5 | **客户关系管理** |  | 16d? | 2007-05-11 | 2007-06-01 |  | 8d |  |  | 152h |
| 60 | 5.1 | 审阅客户资料和反馈 |  | 3d? | 2007-05-11 | 2007-05-15 | 48 | 8d | 0d | 营销人员 | 24h |
| 61 | 5.2 | 审阅公司市场细分和渠道 |  | 3d? | 2007-05-11 | 2007-05-15 | 48 | 8d | 0d | 营销人员 | 24h |
| 62 | 5.3 | 确定每个活动的目标 |  | 3d? | 2007-05-16 | 2007-05-18 | 60, 61 | 8d | 0d | 营销研究人员 | 24h |
| 63 | 5.4 | 每个活动的市场细分数据 |  | 5d? | 2007-05-21 | 2007-05-25 | 62 | 8d | 0d | 营销人员 | 40h |
| 64 | 5.5 | 根据每个活动的材料列表进行准备/采购 |  | 5d? | 2007-05-28 | 2007-06-01 | 63 | 8d | 0d | 营销人员 | 40h |
| 65 | 5.6 | 完成客户关系管理 | milestone | 0d | 2007-06-01 | 2007-06-01 | 64 | 8d |  |  |  |
| 66 | 6 | **分析区域/全球/国家(地区)业务模式** |  | 9d? | 2007-05-11 | 2007-05-23 |  | 15d |  |  | 88h |
| 67 | 6.1 | 建立目标区域 |  | 1d? | 2007-05-11 | 2007-05-11 | 48 | 15d | 0d | 营销人员 | 8h |
| 68 | 6.2 | 确定本地差距 |  | 2d? | 2007-05-14 | 2007-05-15 | 67 | 15d | 0d | 营销人员 | 16h |
| 69 | 6.3 | 审阅本地竞争 |  | 3d? | 2007-05-16 | 2007-05-18 | 68 | 15d | 0d | 营销研究人员 | 24h |
| 70 | 6.4 | 确定竞争优势 |  | 2d? | 2007-05-21 | 2007-05-22 | 69 | 15d | 0d | 营销领导组; 营销研究人员 | 32h |
| 71 | 6.5 | 确定意向合作伙伴 |  | 1d? | 2007-05-23 | 2007-05-23 | 70 | 15d | 0d | 战略联盟领导组 | 8h |
| 72 | 6.6 | 完成区域/全球/国家(地区)业务模式 | milestone | 0d | 2007-05-23 | 2007-05-23 | 71 | 15d |  |  |  |
| 73 | 7 | **制定活动** |  | 14d? | 2007-06-14 | 2007-07-03 |  | 0d |  |  | 104h |
| 74 | 7.1 | 审阅活动概念 |  | 2d? | 2007-06-14 | 2007-06-15 | 58, 65, 72 | 0d |  | 营销领导组 | 16h |
| 75 | 7.2 | 创建活动列表 |  | 1d? | 2007-06-18 | 2007-06-18 | 74 | 0d |  | 营销代表 | 8h |
| 76 | 7.3 | 确定活动领导组 |  | 1d? | 2007-06-19 | 2007-06-19 | 75 | 0d |  | 营销代表 | 8h |
| 77 | 7.4 | 制定单个活动 |  | 1d? | 2007-06-20 | 2007-06-20 | 76 | 0d |  |  |  |
| 78 | 7.5 | 制定活动日程 |  | 2d? | 2007-06-21 | 2007-06-22 | 77 | 0d |  | 营销代表 | 16h |
| 79 | 7.6 | 确定行动动员 |  | 2d? | 2007-06-25 | 2007-06-26 | 78 | 0d |  | 营销领导组 | 16h |
| 80 | 7.7 | 确定广告/促销方法和组合 |  | 5d? | 2007-06-27 | 2007-07-03 | 79 | 0d |  | 营销领导组 | 40h |
| 81 | 7.8 | 完成活动制定 | milestone | 0d | 2007-07-03 | 2007-07-03 | 80 | 0d |  |  |  |
| 82 | 8 | **制定活动创意和测试** |  | 30d? | 2007-07-04 | 2007-08-14 |  | 0d |  |  | 312h |
| 83 | 8.1 | 选择有创意的供应商 |  | 1d? | 2007-07-04 | 2007-07-04 | 81 | 0d |  | 营销领导组; 营销代表 | 16h |
| 84 | 8.2 | 确定活动口号/信息风格 |  | 3d? | 2007-07-05 | 2007-07-09 | 83 | 0d |  | 营销领导组; 创意人员 | 48h |
| 85 | 8.3 | 制定概念和活动 |  | 5d? | 2007-07-10 | 2007-07-16 | 84 | 0d |  | 创意人员 | 40h |
| 86 | 8.4 | 选择活动创意 |  | 5d? | 2007-07-17 | 2007-07-23 | 85 | 0d |  | 营销领导组; 公司赞助商 | 80h |
| 87 | 8.5 | 准备预测试材料 |  | 5d? | 2007-07-24 | 2007-07-30 | 86 | 0d |  | 营销代表 | 40h |
| 88 | 8.6 | 预测试活动 |  | 5d? | 2007-07-31 | 2007-08-06 | 87 | 0d |  | 营销代表 | 40h |
| 89 | 8.7 | 确定预测试创意是否达到目标 |  | 1d? | 2007-08-07 | 2007-08-07 | 88 | 0d |  | 营销代表 | 8h |
| 90 | 8.8 | 根据预测试结果改善创意 |  | 5d? | 2007-08-08 | 2007-08-14 | 89 | 0d |  | 创意人员 | 40h |
| 91 | 8.9 | 完成活动创意和测试 | milestone | 0d | 2007-08-14 | 2007-08-14 | 90 | 0d |  |  |  |

| ID | WBS | Task | Type | Duration | Start | Finish | Predecessors | Total slack | Free slack | Resources | Work |
| --- | --- | --- | --- | --- | --- | --- | --- | --- | --- | --- | --- |
| 92 | 9 | **制定外部促销策略** |  | 9d? | 2007-08-15 | 2007-08-27 |  | 0d |  |  | 368h |
| 93 | 9.1 | 制定促销策略 |  | 2d? | 2007-08-15 | 2007-08-16 | 91 | 0d |  | 营销领导组; 内部 PR | 32h |
| 94 | 9.2 | 制定新闻发布 |  | 4d? | 2007-08-17 | 2007-08-22 | 93 | 0d |  | 内部 PR; PR 公司 | 64h |
| 95 | 9.3 | 制定通知 |  | 4d? | 2007-08-17 | 2007-08-22 | 93 | 0d |  | 内部 PR; PR 公司 | 64h |
| 96 | 9.4 | 向分析人员提供预发布信息 |  | 3d? | 2007-08-23 | 2007-08-27 | 94, 95 | 0d |  | 内部 PR; PR 公司 | 48h |
| 97 | 9.5 | 编写“宣传语” |  | 5d? | 2007-08-17 | 2007-08-23 | 93 | 2d |  | 内部 PR; PR 公司 | 80h |
| 98 | 9.6 | 执行宣传策略 |  | 5d? | 2007-08-15 | 2007-08-21 | 91 | 4d |  | 内部 PR; PR 公司 | 80h |
| 99 | 9.7 | 完成外部促销 | milestone | 0d | 2007-08-27 | 2007-08-27 | 98, 96, 97 | 0d |  |  |  |
| 100 | 10 | **生产** |  | 14d? | 2007-08-28 | 2007-09-14 |  | 0d |  |  | 112h |
| 101 | 10.1 | 提交用于广播发布的活动材料 |  | 3d? | 2007-08-28 | 2007-08-30 | 99 | 0d |  | 营销代表 | 24h |
| 102 | 10.2 | 针对相应的生产方法选择供应商 |  | 1d? | 2007-08-31 | 2007-08-31 | 101 | 20d | 0d | 营销人员 | 8h |
| 103 | 10.3 | 材料生产 |  | 5d? | 2007-09-03 | 2007-09-07 | 102 | 20d | 0d | 供应商 | 40h |
| 104 | 10.4 | 材料分发 |  | 5d? | 2007-09-10 | 2007-09-14 | 103 | 20d | 0d | 供应商 | 40h |
| 105 | 10.5 | 完成生产 | milestone | 0d | 2007-09-14 | 2007-09-14 | 104 | 20d |  |  |  |
| 106 | 11 | **活动发布** |  | 13d? | 2007-08-31 | 2007-09-18 |  | 0d |  |  | 144h |
| 107 | 11.1 | 制定活动发布日程 |  | 2d? | 2007-08-31 | 2007-09-03 | 101 | 0d |  | 营销代表 | 16h |
| 108 | 11.2 | 确定发布工作组 |  | 1d? | 2007-09-04 | 2007-09-04 | 107 | 0d |  | 营销领导组 | 8h |
| 109 | 11.3 | 进行内部销售动员 |  | 5d? | 2007-09-05 | 2007-09-11 | 108 | 0d |  | 营销领导组; 内部销售人员 | 80h |
| 110 | 11.4 | 执行活动 |  | 5d? | 2007-09-12 | 2007-09-18 | 109 | 0d |  | 营销领导组 | 40h |
| 111 | 11.5 | 完成活动发布 | milestone | 0d | 2007-09-18 | 2007-09-18 | 110 | 0d |  |  |  |
| 112 | 12 | **活动效益** |  | 18d? | 2007-09-19 | 2007-10-12 |  | 0d |  |  | 192h |
| 113 | 12.1 | 评估活动效益 |  | 3d? | 2007-09-19 | 2007-09-21 | 111 | 3d |  | 营销领导组 | 24h |
| 114 | 12.2 | 审阅区域销售 |  | 1d? | 2007-09-19 | 2007-09-19 | 111 | 0d |  | 营销领导组; 销售人员 | 16h |
| 115 | 12.3 | 审阅全球销售 |  | 1d? | 2007-09-20 | 2007-09-20 | 114 | 0d |  | 营销领导组; 销售人员 | 16h |
| 116 | 12.4 | 审阅客户资料和反馈 |  | 1d? | 2007-09-21 | 2007-09-21 | 115 | 0d |  | 营销人员; 营销代表 | 16h |
| 117 | 12.5 | 进行市场分析 |  | 3d? | 2007-09-24 | 2007-09-26 | 116 | 0d |  | 营销研究人员 | 24h |
| 118 | 12.6 | 审阅成功量度标准 |  | 3d? | 2007-09-27 | 2007-10-01 | 113, 114, 115, 116, 117 | 0d |  | 营销领导组 | 24h |
| 119 | 12.7 | 评估活动效益 |  | 3d? | 2007-10-02 | 2007-10-04 | 118 | 0d |  | 营销领导组 | 24h |
| 120 | 12.8 | 确定所有差距 |  | 1d? | 2007-10-05 | 2007-10-05 | 119 | 0d |  | 营销领导组 | 8h |
| 121 | 12.9 | 制定将来的活动设想 |  | 5d? | 2007-10-08 | 2007-10-12 | 120 | 0d |  | 营销领导组 | 40h |
| 122 | 12.10 | 活动效益 | milestone | 0d | 2007-10-12 | 2007-10-12 | 121 | 0d |  |  |  |
| 123 | 13 | 完成营销活动策划 | milestone | 0d | 2007-10-12 | 2007-10-12 | 122 | 0d |  |  |  |

Notes:
- 92: 您可以有更详细的 PR 计划来管理此部分活动执行的工作。
