# 管理收到的询价(RFQ)

Schedule from MS Project, 2007-01-01 to 2007-02-20.

## Calendars

- 标准: Mon-Fri 08:00-12:00, 13:00-17:00; Sat-Sun off.

## Resources

| Resource |
| --- |
| 采购人员 |
| 产品工程设计人员 |
| 制造工程师 |
| 加工工程师 |
| 会计 |
| 营销人员 |
| 法律部门 |
| 管理人员 |
| 客户 |
| 信息系统 |
| 销售经理 |
| 建议专家 |
| 主题专家 |

## Schedule

| ID | WBS | Task | Type | Duration | Start | Finish | Predecessors | Total slack | Resources | Work |
| --- | --- | --- | --- | --- | --- | --- | --- | --- | --- | --- |
| 1 | 1 | 阅读说明此模板用途的注释 | milestone | 0d | 2007-01-01 | 2007-01-01 |  | 0d |  |  |
| 2 | 2 | **选择审核工作组** |  | 2d? | 2007-01-01 | 2007-01-02 |  | 0d |  | 48h |
| 3 | 2.1 | 确定审核工作组可用性 |  | 1d? | 2007-01-01 | 2007-01-01 | 1 | 0d | 销售经理; 建议专家 | 16h |
| 4 | 2.2 | 确定审核会议日程选项 |  | 1d? | 2007-01-02 | 2007-01-02 | 3 | 35d | 销售经理; 建议专家 | 16h |
| 5 | 2.3 | 最终确定询价角色和负责人 |  | 1d? | 2007-01-02 | 2007-01-02 | 3 | 35d | 销售经理; 建议专家 | 16h |
| 6 | 2.4 | 审核选择的工作组 | milestone | 0d | 2007-01-01 | 2007-01-01 | 3 | 0d |  |  |
| 7 | 3 | **执行询价分析** |  | 4d? | 2007-01-02 | 2007-01-05 |  | 0d |  | 152h |
| 8 | 3.1 | 分析并确定范围 |  | 1d? | 2007-01-02 | 2007-01-02 | 6 | 0d | 建议专家 | 8h |
| 9 | 3.2 | 分析并确定管理要求 |  | 2d? | 2007-01-03 | 2007-01-04 | 8 | 0d | 建议专家 | 16h |
| 10 | 3.3 | 分析并确定法律要求 |  | 2d? | 2007-01-03 | 2007-01-04 | 8 | 0d | 法律部门; 建议专家 | 32h |
| 11 | 3.4 | 分析并确定格式要求 |  | 1d? | 2007-01-03 | 2007-01-03 | 8 | 1d | 建议专家 | 8h |
| 12 | 3.5 | 分析并确定内容要求 |  | 2d? | 2007-01-03 | 2007-01-04 | 8 | 0d | 建议专家; 主题专家 | 32h |
| 13 | 3.6 | 完成初始要求审核 | milestone | 0d | 2007-01-04 | 2007-01-04 | 8, 9, 10, 11, 12 | 0d |  |  |
| 14 | 3.7 | **确定审核标准** |  | 1d? | 2007-01-05 | 2007-01-05 |  | 0d |  | 56h |
| 15 | 3.7.1 | 确定/确认业务证明 |  | 1d? | 2007-01-05 | 2007-01-05 | 13 | 0d | 销售经理 | 8h |
| 16 | 3.7.2 | 确定/确认客户特定需求 |  | 1d? | 2007-01-05 | 2007-01-05 | 13 | 0d | 建议专家 | 8h |
| 17 | 3.7.3 | 确定/确认组织能力/资源需求 |  | 1d? | 2007-01-05 | 2007-01-05 | 13 | 0d | 管理人员 | 8h |
| 18 | 3.7.4 | 确定需要咨询的主题专家 |  | 1d? | 2007-01-05 | 2007-01-05 | 13 | 0d | 管理人员 | 8h |
| 19 | 3.7.5 | 确定/确认所需客户参考 |  | 1d? | 2007-01-05 | 2007-01-05 | 13 | 0d | 销售经理 | 8h |
| 20 | 3.7.6 | 确定/确认类似询价的跟踪记录 |  | 1d? | 2007-01-05 | 2007-01-05 | 13 | 0d | 建议专家 | 8h |
| 21 | 3.7.7 | 确定/确认准备询价所需的工作强度 |  | 1d? | 2007-01-05 | 2007-01-05 | 13 | 0d | 建议专家 | 8h |
| 22 | 3.7.8 | 确定审核标准 | milestone | 0d | 2007-01-05 | 2007-01-05 | 21, 15, 16, 17, 18, 19, 20 | 0d |  |  |
| 23 | 3.8 | 完成询价分析 | milestone | 0d | 2007-01-05 | 2007-01-05 | 22 | 32d |  |  |
| 24 | 4 | **执行投标/不投标分析** |  | 2d? | 2007-01-08 | 2007-01-09 |  | 0d |  | 16h |
| 25 | 4.1 | 将分析结果与投标标准比较 |  | 1d? | 2007-01-08 | 2007-01-08 | 22 | 0d | 销售经理 | 8h |
| 26 | 4.2 | 确定投标/不投标 | milestone | 0d | 2007-01-08 | 2007-01-08 | 25 | 1d | 法律部门; 管理人员; 销售经理; 建议专家 |  |
| 27 | 4.3 | 向出标方和参与者传达决定 |  | 1d? | 2007-01-09 | 2007-01-09 | 25 | 0d | 销售经理 | 8h |
| 28 | 4.4 | 完成投标分析 | milestone | 0d | 2007-01-09 | 2007-01-09 | 26, 27 | 0d |  |  |

Notes:
- 1: 此模板可向销售经理提供管理询价流程的控管方法。
- 9: 需要审核的内容包括: / 后勤 / 投标人会议时间/地点(如果可用) / 提问截止日期/格式 / 联系点 / 副本数量/要求或允许的答复类型 / 截止日期 / 日程 / 用于答复的实际地址 / 用于答复的电子邮件地址/传真号
- 10: 要审核的内容包括: / 合同的条款与条件 / 分包合同的条款与条件和/或限制 / 证明和陈述 / 任何其他可确定您能否遵守法律要求的法律限制
- 11: 要审核的内容包括: / 页限制(例如，不超过 25 页) / 格式(字体/字号、边距大小等) / 图片的使用
- 12: 要审核的内容包括: / 要求的规范 / 工作范围 / 技术要求 / 要包含的领域 / 评估标准 / 需要的证据(包括推荐信、简历、类似工作经验等)
- 28: 如果决定投标 - 转移到下一项目阶段 / 如果决定不投标 - 项目到此结束

| ID | WBS | Task | Type | Duration | Start | Finish | Predecessors | Total slack | Free slack | Resources | Work |
| --- | --- | --- | --- | --- | --- | --- | --- | --- | --- | --- | --- |
| 29 | 5 | **制定询价项目计划** |  | 3d? | 2007-01-10 | 2007-01-12 |  | 0d |  |  | 36h |
| 30 | 5.1 | 输入/更新询价管理系统 |  | 0.5d? | 2007-01-10 | 2007-01-10 | 28 | 1.5d |  | 销售经理 | 4h |
| 31 | 5.2 | 确定项目任务和审核里程碑 |  | 1d? | 2007-01-10 | 2007-01-10 | 28 | 0d |  | 建议专家 | 8h |
| 32 | 5.3 | 定义审核可交付结果和分配 |  | 1d? | 2007-01-11 | 2007-01-11 | 31 | 0d |  | 建议专家 | 8h |
| 33 | 5.4 | 准备审核日程/交流指南 |  | 1d? | 2007-01-12 | 2007-01-12 | 30, 31, 32 | 0d |  | 销售经理; 建议专家 | 16h |
| 34 | 5.5 | 完成询价项目计划 | milestone | 0d | 2007-01-12 | 2007-01-12 | 33 | 0d |  |  |  |
| 35 | 6 | **制定询价** |  | 11d? | 2007-01-15 | 2007-01-29 |  | 0d |  |  | 112h |
| 36 | 6.1 | 制定成功主题并编档 |  | 1d? | 2007-01-15 | 2007-01-15 | 28, 34 | 26d |  | 销售经理 | 8h |
| 37 | 6.2 | 组织行政管理需求响应并编档 |  | 2d? | 2007-01-15 | 2007-01-16 | 34 | 0d |  | 建议专家 | 16h |
| 38 | 6.3 | 组织法律需求响应并编档 |  | 1d? | 2007-01-17 | 2007-01-17 | 37 | 2d |  | 法律部门 | 8h |
| 39 | 6.4 | 组织并询价结构/分段并确定其格式 |  | 3d? | 2007-01-17 | 2007-01-19 | 37 | 0d |  | 建议专家 | 24h |
| 40 | 6.5 | 收集并最终确定询价内容 |  | 2d? | 2007-01-22 | 2007-01-23 | 38, 39, 37 | 0d |  | 建议专家 | 16h |
| 41 | 6.6 | 最终确定询价产品/服务价格报价和选项 |  | 2d? | 2007-01-24 | 2007-01-25 | 40 | 0d |  | 建议专家 | 16h |
| 42 | 6.7 | 制作随函和(或)执行摘要 |  | 1d? | 2007-01-24 | 2007-01-24 | 40 | 1d |  | 建议专家 | 8h |
| 43 | 6.8 | 进行询价质量审核 |  | 1d? | 2007-01-26 | 2007-01-26 | 41, 42 | 0d |  | 管理人员 | 8h |
| 44 | 6.9 | 更新询价管理系统 |  | 1d? | 2007-01-29 | 2007-01-29 | 43 | 0d |  | 销售经理 | 8h |
| 45 | 6.10 | 结束询价制定工作 | milestone | 0d | 2007-01-29 | 2007-01-29 | 44, 43 | 0d |  |  |  |
| 46 | 7 | **询价管理审核和审批** |  | 3d? | 2007-01-30 | 2007-02-01 |  | 0d |  |  | 24h |
| 47 | 7.1 | 进行管理询价审核 |  | 1d? | 2007-01-30 | 2007-01-30 | 45 | 0d |  | 管理人员 | 8h |
| 48 | 7.2 | 最终确定对询价的更改 |  | 1d? | 2007-01-31 | 2007-01-31 | 47 | 0d |  | 建议专家 | 8h |
| 49 | 7.3 | 批准询价 | milestone | 0d | 2007-01-31 | 2007-01-31 | 48 | 0d |  |  |  |
| 50 | 7.4 | 更新询价管理系统 |  | 1d? | 2007-02-01 | 2007-02-01 | 49 | 13d | 0d | 销售经理 | 8h |
| 51 | 7.5 | 完成询价管理审核和审批 | milestone | 0d | 2007-02-01 | 2007-02-01 | 50, 49 | 13d |  |  |  |
| 52 | 8 | **询价提交和答复** |  | 12d? | 2007-02-01 | 2007-02-16 |  | 0d |  |  | 136h |
| 53 | 8.1 | 将询价提交给客户 |  | 1d? | 2007-02-01 | 2007-02-01 | 49 | 0d |  | 销售经理 | 8h |
| 54 | 8.2 | 监控答复 |  | 5d? | 2007-02-02 | 2007-02-08 | 53 | 0d |  | 销售经理 | 40h |
| 55 | 8.3 | 提供其他要求的信息 |  | 5d? | 2007-02-09 | 2007-02-15 | 54 | 0d |  | 销售经理; 建议专家 | 80h |
| 56 | 8.4 | 成功/失败决策 | milestone | 0d | 2007-02-15 | 2007-02-15 | 55 | 0d |  |  |  |
| 57 | 8.5 | 更新询价管理系统 |  | 1d? | 2007-02-16 | 2007-02-16 | 56 | 0d |  | 销售经理 | 8h |
| 58 | 8.6 | 完成询价提交和答复 | milestone | 0d | 2007-02-16 | 2007-02-16 | 57 | 0d |  |  |  |

| ID | WBS | Task | Type | Duration | Start | Finish | Predecessors | Total slack | Resources | Work |
| --- | --- | --- | --- | --- | --- | --- | --- | --- | --- | --- |
| 59 | 9 | **询价成功和接受** |  | 2d? | 2007-02-19 | 2007-02-20 |  | 0d |  | 16h |
| 60 | 9.1 | 最终确定合同安排 |  | 1d? | 2007-02-19 | 2007-02-19 | 58 | 0d | 法律部门 | 8h |
| 61 | 9.2 | 组建初始工作组 |  | 1d? | 2007-02-20 | 2007-02-20 | 60 | 0d | 管理人员 | 8h |
| 62 | 9.3 | 开始与供应商进行服务提供讨论 | milestone | 0d | 2007-02-20 | 2007-02-20 | 61 | 0d |  |  |
| 63 | 10 | 完成询价流程 | milestone | 0d | 2007-02-20 | 2007-02-20 | 62 | 0d |  |  |
