# 绩效考核

Schedule from MS Project, 2007-01-01 to 2007-02-16.
从人力资源部门角度来看，此模板用于确定典型的季度或年度绩效审核周期常规活动。此模板假定以前已经建立绩效审核流程，并假定未将绩效与报酬挂钩。

## Calendars

- 标准: Mon-Fri 08:00-12:00, 13:00-17:00; Sat-Sun off.

## Resources

| Resource |
| --- |
| 人力资源主管 |
| 绩效考核工作组 |
| 行政工作组 |
| 人力资源管理助理 |
| 雇员 |
| 主管 |

## Schedule

| ID | WBS | Task | Type | Duration | Start | Finish | Predecessors | Total slack | Resources | Work |
| --- | --- | --- | --- | --- | --- | --- | --- | --- | --- | --- |
| 1 | 1 | **进行周期规划** |  | 3d? | 2007-01-01 | 2007-01-03 |  | 0d |  | 28h |
| 2 | 1.1 | 审阅和修改绩效考核项目计划 |  | 1d? | 2007-01-01 | 2007-01-01 |  | 0d | 人力资源主管 | 8h |
| 3 | 1.2 | 组织新的绩效考核工作组 |  | 1d? | 2007-01-02 | 2007-01-02 | 2 | 0d | 人力资源主管 | 8h |
| 4 | 1.3 | 周期启动会议 |  | 1d? | 2007-01-03 | 2007-01-03 | 3 | 0d | 人力资源主管; 绩效考核工作组; 人力资源管理助理 | 12h |
| 5 | 1.4 | 完成周期规划 | milestone | 0d | 2007-01-03 | 2007-01-03 | 4 | 0d |  |  |
| 6 | 2 | **审阅和修改业绩规划工具和过程** |  | 12d? | 2007-01-04 | 2007-01-19 |  | 0d |  | 120h |
| 7 | 2.1 | **审阅工具和过程** |  | 6d? | 2007-01-04 | 2007-01-11 |  | 0d |  | 56h |
| 8 | 2.1.1 | 审阅前一个周期的经验教训 |  | 1d? | 2007-01-04 | 2007-01-04 | 5 | 0d | 绩效考核工作组 | 8h |
| 9 | 2.1.2 | 评估现有绩效考核/规划标准和范围 |  | 1d? | 2007-01-05 | 2007-01-05 | 8 | 0d | 绩效考核工作组 | 8h |
| 10 | 2.1.3 | 评估新的绩效考核/规划行执行人员任命 |  | 1d? | 2007-01-08 | 2007-01-08 | 9 | 0d | 绩效考核工作组 | 8h |
| 11 | 2.1.4 | 评估新的绩效考核/规划的行业最佳做法 |  | 1d? | 2007-01-09 | 2007-01-09 | 10 | 0d | 绩效考核工作组 | 8h |
| 12 | 2.1.5 | 编档审阅结果和建议的修改 |  | 1d? | 2007-01-10 | 2007-01-10 | 11 | 0d | 绩效考核工作组 | 8h |
| 13 | 2.1.6 | 行政审阅和决定 |  | 1d? | 2007-01-11 | 2007-01-11 | 12 | 0d | 人力资源主管; 行政工作组 | 16h |
| 14 | 2.1.7 | 完成工具和过程审阅 | milestone | 0d | 2007-01-11 | 2007-01-11 | 13 | 0d |  |  |
| 15 | 2.2 | **修改工具和过程** |  | 3d? | 2007-01-12 | 2007-01-16 |  | 0d |  | 32h |
| 16 | 2.2.1 | 起草对工具和过程的更改 |  | 1d? | 2007-01-12 | 2007-01-12 | 14 | 0d | 绩效考核工作组 | 8h |
| 17 | 2.2.2 | 领导审阅和批准 |  | 1d? | 2007-01-15 | 2007-01-15 | 16 | 0d | 人力资源主管; 行政工作组 | 16h |
| 18 | 2.2.3 | 最终确定对工具和过程的更改 |  | 1d? | 2007-01-16 | 2007-01-16 | 17 | 0d | 绩效考核工作组 | 8h |
| 19 | 2.2.4 | 完成工具和过程修改 | milestone | 0d | 2007-01-16 | 2007-01-16 | 18 | 0d |  |  |
| 20 | 2.3 | **交流规划** |  | 3d? | 2007-01-17 | 2007-01-19 |  | 0d |  | 32h |
| 21 | 2.3.1 | 起草绩效考核/规划过程的说明 |  | 1d? | 2007-01-17 | 2007-01-17 | 19 | 0d | 绩效考核工作组 | 8h |
| 22 | 2.3.2 | 领导审阅和批准 |  | 1d? | 2007-01-18 | 2007-01-18 | 21 | 0d | 人力资源主管; 行政工作组 | 16h |
| 23 | 2.3.3 | 最终确定对交流的更改 |  | 1d? | 2007-01-19 | 2007-01-19 | 22 | 0d | 绩效考核工作组 | 8h |
| 24 | 2.3.4 | 完成交流规划 | milestone | 0d | 2007-01-19 | 2007-01-19 | 23 | 0d |  |  |
| 25 | 2.4 | 完成审阅和修改业绩规划工具和过程 | milestone | 0d | 2007-01-19 | 2007-01-19 | 24 | 0d |  |  |

Notes:
- 6: 大多数组织使用一套标准绩效规划和考核标准的组合，包括接近组织努力实现的价值的各个方面(例如，诚实、创造力和协作)，以及超出基于目标或职责的标准，这些标准对于被考核的个人来说是唯一的(例如，在六个月内完成 XYZ 项目)。这些任务反映了以下必要性: 从上一个周期的绩效规划和考核中汲取教训，确定对于工具或过程是否有新的行政委任(或者对公司任务、构想、价值的更改)，调查对于此设备或过程是否存在行业最佳做法的变化，并相应地修改工具或过程。交流活动反映以下必要性: 确保所有雇员(主管和被监管者)对于绩效考核和规划过程都接受目的、原则、期望和最后期限的培训。

| ID | WBS | Task | Type | Duration | Start | Finish | Predecessors | Total slack | Free slack | Resources | Work |
| --- | --- | --- | --- | --- | --- | --- | --- | --- | --- | --- | --- |
| 26 | 3 | **更新报告关系模式** |  | 2d? | 2007-01-04 | 2007-01-05 |  | 11d |  |  | 16h |
| 27 | 3.1 | 审阅和修改报告关系模式 |  | 1d? | 2007-01-04 | 2007-01-04 | 5 | 11d | 0d | 人力资源管理助理 | 8h |
| 28 | 3.2 | 新报告关系模式的审阅和批准 |  | 1d? | 2007-01-05 | 2007-01-05 | 27 | 11d | 0d | 人力资源主管 | 8h |
| 29 | 3.3 | 完成报告关系模式更新 | milestone | 0d | 2007-01-05 | 2007-01-05 | 28 | 11d |  |  |  |
| 30 | 4 | 就过程和时间表与所有雇员交流 |  | 1d? | 2007-01-22 | 2007-01-22 | 25 | 0d |  | 人力资源主管 | 8h |
| 31 | 5 | **组织和分发业绩计划** |  | 3d? | 2007-01-23 | 2007-01-25 |  | 0d |  |  | 24h |
| 32 | 5.1 | 组织前一个周期的业绩计划 |  | 1d? | 2007-01-23 | 2007-01-23 | 29, 30 | 0d |  | 人力资源管理助理 | 8h |
| 33 | 5.2 | 复制当前周期的业绩计划 |  | 1d? | 2007-01-24 | 2007-01-24 | 32 | 0d |  | 人力资源管理助理 | 8h |
| 34 | 5.3 | 向雇员和主管分发前一个周期的业绩计划和当前周期的业绩计划 |  | 1d? | 2007-01-25 | 2007-01-25 | 33 | 0d |  | 人力资源管理助理 | 8h |
| 35 | 5.4 | 完成组织和分发业绩计划 | milestone | 0d | 2007-01-25 | 2007-01-25 | 34 | 0d |  |  |  |
| 36 | 6 | **雇员进行自我评估审核** |  | 3d? | 2007-01-26 | 2007-01-30 |  | 0d |  |  | 24h |
| 37 | 6.1 | 雇员审核前一个周期的业绩计划目标 |  | 1d? | 2007-01-26 | 2007-01-26 | 35 | 0d |  | 雇员 | 8h |
| 38 | 6.2 | 雇员就前一个周期的目标和价值撰写自我评估 |  | 1d? | 2007-01-29 | 2007-01-29 | 37 | 0d |  | 雇员 | 8h |
| 39 | 6.3 | 雇员向主管提交自我评估 |  | 1d? | 2007-01-30 | 2007-01-30 | 38 | 0d |  | 雇员 | 8h |
| 40 | 6.4 | 完成雇员进行自我评估审核 | milestone | 0d | 2007-01-30 | 2007-01-30 | 39 | 0d |  |  |  |
| 41 | 7 | **主管准备书面审核** |  | 2d? | 2007-01-31 | 2007-02-01 |  | 0d |  |  | 16h |
| 42 | 7.1 | 主管审核前一个周期的雇员目标 |  | 1d? | 2007-01-31 | 2007-01-31 | 40 | 0d |  | 主管 | 8h |
| 43 | 7.2 | 主管准备书面审核 |  | 1d? | 2007-02-01 | 2007-02-01 | 42 | 0d |  | 主管 | 8h |
| 44 | 7.3 | 完成主管准备书面审核 | milestone | 0d | 2007-02-01 | 2007-02-01 | 43 | 0d |  |  |  |
| 45 | 8 | **绩效考核讨论** |  | 1d? | 2007-02-02 | 2007-02-02 |  | 0d |  |  | 16h |
| 46 | 8.1 | 雇员和主管讨论过去的业绩 |  | 1d? | 2007-02-02 | 2007-02-02 | 44 | 0d |  | 雇员; 主管 | 16h |
| 47 | 8.2 | 完成绩效考核讨论/最终确定书面考核 | milestone | 0d | 2007-02-02 | 2007-02-02 | 46 | 0d |  |  |  |
| 48 | 9 | **最终确定书面考核** |  | 3d? | 2007-02-05 | 2007-02-07 |  | 0d |  |  | 32h |
| 49 | 9.1 | 准备好最终书面考核 |  | 1d? | 2007-02-05 | 2007-02-05 | 47 | 0d |  | 主管 | 8h |
| 50 | 9.2 | 雇员和主管开会讨论并签署最终考核 |  | 1d? | 2007-02-06 | 2007-02-06 | 49 | 0d |  | 雇员; 主管 | 16h |
| 51 | 9.3 | 向人力资源部提交书面考核 |  | 1d? | 2007-02-07 | 2007-02-07 | 50 | 0d |  | 主管 | 8h |
| 52 | 9.4 | 完成最终确定书面考核 | milestone | 0d | 2007-02-07 | 2007-02-07 | 51 | 0d |  |  |  |

Notes:
- 26: 在此步骤中，工作组考核上一个周期的报告关系(主管和下属)，并对上一个周期以来组织的变更相应地做出更改。
- 32: 检索当前雇员上一个周期的机密业绩计划，复制这些计划以分发到记录的雇员和主管，组织包含自己业绩计划的个人数据包，如果个人具有主管角色，则组织包含前一个周期其下属的业绩计划的数据包。
- 33: 复制新计划以分发到记录的雇员和主管。
- 36: 通常，雇员审核前一个周期中声明的目标，并就实现这些目标对自身进行评估，以及就预期体现公司价值的各种目标行为对自身进行评定。
- 41: 通常，主管审核雇员自己的自我评估、主管自己的备注和前一个审核周期中收集的观测数据，并对每个雇员撰写叙述性总结和总体评定。
- 45: 通常，雇员和主管开会讨论需要改善的各个地区的成果、优势和状况，以及自我评定和主管评定之间的差异。一般会在讨论过程中最终确定书面绩效考核。
- 48: 一般会在绩效考核讨论过程中最终确定书面绩效考核。

| ID | WBS | Task | Type | Duration | Start | Finish | Predecessors | Total slack | Resources | Work |
| --- | --- | --- | --- | --- | --- | --- | --- | --- | --- | --- |
| 53 | 10 | **制定下一个考核阶段的目标** |  | 2d? | 2007-02-08 | 2007-02-09 |  | 0d |  | 24h |
| 54 | 10.1 | 雇员和主管开会讨论将来的目标 |  | 1d? | 2007-02-08 | 2007-02-08 | 52 | 0d | 雇员; 主管 | 16h |
| 55 | 10.2 | 向人力资源部门提交目标 |  | 1d? | 2007-02-09 | 2007-02-09 | 54 | 0d | 雇员 | 8h |
| 56 | 10.3 | 完成制定下一个审核阶段的目标 | milestone | 0d | 2007-02-09 | 2007-02-09 | 55 | 0d |  |  |
| 57 | 11 | **数据分析** |  | 3d? | 2007-02-12 | 2007-02-14 |  | 0d |  | 32h |
| 58 | 11.1 | 在 Microsoft Excel 中输入评定数据以供分析 |  | 1d? | 2007-02-12 | 2007-02-12 | 56 | 0d | 人力资源管理助理 | 8h |
| 59 | 11.2 | 各个部门和主管分析评定数据 |  | 1d? | 2007-02-13 | 2007-02-13 | 58 | 0d | 人力资源主管 | 8h |
| 60 | 11.3 | 与行政人员讨论评定数据结果 |  | 1d? | 2007-02-14 | 2007-02-14 | 59 | 0d | 人力资源主管; 行政工作组 | 16h |
| 61 | 11.4 | 完成数据分析 | milestone | 0d | 2007-02-14 | 2007-02-14 | 60 | 0d |  |  |
| 62 | 12 | **经验教训** |  | 2d? | 2007-02-15 | 2007-02-16 |  | 0d |  | 20h |
| 63 | 12.1 | 绩效考核工作组讨论从当前周期的实践中获取的经验教训 |  | 1d? | 2007-02-15 | 2007-02-15 | 61 | 0d | 人力资源主管; 绩效考核工作组; 人力资源管理助理 | 12h |
| 64 | 12.2 | 编档并存储经验教训 |  | 1d? | 2007-02-16 | 2007-02-16 | 63 | 0d | 人力资源主管 | 8h |
| 65 | 13 | 完成绩效考核周期 | milestone | 0d | 2007-02-16 | 2007-02-16 | 64 | 0d |  |  |

Notes:
- 53: 有时，将来目标的讨论会在绩效考核讨论的相同环境，或同一次会议中进行。
- 54: 利用当前阶段的文档编写将来的计划。
- 57: 此活动的总体目标是确保主管的评定是公平和公正的。
- 60: 此活动的目的不是共享个人机密数据，而是与行政工作组共享公司或部门所有总体模式(要说明的改善、拒绝、重要趋势)。
