# 评估海外人力资源职能策略

Schedule from MS Project, 2007-01-01 to 2007-05-14.
从人力资源的角度来看，此模板可以处理确定人力资源部门职能外包战略评估的常规活动。

## Calendars

- 标准: Mon-Fri 08:00-12:00, 13:00-17:00; Sat-Sun off.

## Resources

| Resource |
| --- |
| 人力资源主管 |
| 绩效考核工作组 |
| 行政工作组 |
| 人力资源管理助理 |
| 雇员 |
| 主管 |
| 人力资源 |
| 财务 |
| 法律人员 |
| 信息系统 |
| 采购 |
| 试生产供应商 |

## Schedule

| ID | WBS | Task | Type | Duration | Start | Finish | Predecessors | Total slack | Resources | Work |
| --- | --- | --- | --- | --- | --- | --- | --- | --- | --- | --- |
| 1 | 1 | **分析当前人力资源职能并确定海外人力资源职能候选者** |  | 7d? | 2007-01-01 | 2007-01-09 |  | 0d |  | 80h |
| 2 | 1.1 | 确定公司内的所有人力资源职能 |  | 1d? | 2007-01-01 | 2007-01-01 |  | 0d | 人力资源 | 8h |
| 3 | 1.2 | 描述管理人员和雇员对人力资源职能过程的访问权限 |  | 1d? | 2007-01-02 | 2007-01-02 | 2 | 0d | 人力资源 | 8h |
| 4 | 1.3 | 对内部管理人力资源职能进行成本/收益/问题分析 |  | 1d? | 2007-01-03 | 2007-01-03 | 3 | 0d | 人力资源; 财务; 法律人员 | 12h |
| 5 | 1.4 | 初步确定用于海外对比的人力资源职能 |  | 1d? | 2007-01-04 | 2007-01-04 | 4 | 0d | 人力资源; 财务; 法律人员 | 12h |
| 6 | 1.5 | 准备摘要和详细结果 |  | 1d? | 2007-01-05 | 2007-01-05 | 5 | 0d | 人力资源 | 8h |
| 7 | 1.6 | 审阅摘要 |  | 1d? | 2007-01-08 | 2007-01-08 | 6 | 0d | 人力资源主管; 行政工作组 | 16h |
| 8 | 1.7 | 确定用于海外对比的人力资源职能 |  | 1d? | 2007-01-09 | 2007-01-09 | 7 | 0d | 人力资源主管; 行政工作组 | 16h |
| 9 | 1.8 | 完成分析当前人力资源职能和评估海外候选者 | milestone | 0d | 2007-01-09 | 2007-01-09 | 8 | 0d |  |  |
| 10 | 2 | **初步研究海外/对比** |  | 5d? | 2007-01-10 | 2007-01-16 |  | 0d |  | 40h |
| 11 | 2.1 | 研究海外人力资源职能公司 |  | 1d? | 2007-01-10 | 2007-01-10 | 9 | 0d |  |  |
| 12 | 2.2 | 对指定的海外人力资源职能进行成本/收益/风险分析 |  | 1d? | 2007-01-11 | 2007-01-11 | 11 | 0d |  |  |
| 13 | 2.3 | 准备摘要和详细结果 |  | 1d? | 2007-01-12 | 2007-01-12 | 12 | 0d | 人力资源 | 8h |
| 14 | 2.4 | 审阅摘要 |  | 1d? | 2007-01-15 | 2007-01-15 | 13 | 0d | 人力资源主管; 行政工作组 | 16h |
| 15 | 2.5 | 确定人力资源职能和公司以便进一步分析 |  | 1d? | 2007-01-16 | 2007-01-16 | 14 | 0d | 人力资源主管; 行政工作组 | 16h |
| 16 | 2.6 | 完成初步研究海外/对比 | milestone | 0d | 2007-01-16 | 2007-01-16 | 15 | 0d |  |  |
| 17 | 3 | **深入分析** |  | 12d? | 2007-01-17 | 2007-02-01 |  | 0d |  | 160h |
| 18 | 3.1 | 确定可能海外处理的服务范围 |  | 1d? | 2007-01-17 | 2007-01-17 | 16 | 0d | 人力资源 | 8h |
| 19 | 3.2 | 确定内部服务级别(可用性和准确性标准) |  | 1d? | 2007-01-18 | 2007-01-18 | 18 | 0d | 人力资源 | 8h |
| 20 | 3.3 | 创建适用于试生产参与者的调查机制(效益标准) |  | 1d? | 2007-01-18 | 2007-01-18 | 18 | 0d | 人力资源 | 8h |
| 21 | 3.4 | **评估海外解决方案** |  | 7d? | 2007-01-19 | 2007-01-29 |  | 0d |  | 104h |
| 22 | 3.4.1 | 制定 RFP |  | 1d? | 2007-01-19 | 2007-01-19 | 19, 20 | 0d | 人力资源; 信息系统 | 16h |
| 23 | 3.4.2 | 确定赋予答复的权重 |  | 1d? | 2007-01-22 | 2007-01-22 | 22 | 0d | 人力资源; 信息系统 | 16h |
| 24 | 3.4.3 | 发布 RFP |  | 1d? | 2007-01-23 | 2007-01-23 | 23 | 0d | 采购 | 8h |
| 25 | 3.4.4 | 评估答复 |  | 1d? | 2007-01-24 | 2007-01-24 | 24 | 0d | 人力资源; 信息系统 | 16h |
| 26 | 3.4.5 | 进行供应商答复/要求差距分析 |  | 1d? | 2007-01-25 | 2007-01-25 | 25 | 0d | 人力资源; 信息系统 | 16h |
| 27 | 3.4.6 | 邀请前几位候选者进行演示 |  | 1d? | 2007-01-26 | 2007-01-26 | 26 | 0d | 人力资源; 采购 | 16h |
| 28 | 3.4.7 | 选择最合适的供应商解决方案 |  | 1d? | 2007-01-29 | 2007-01-29 | 27 | 0d | 人力资源; 信息系统 | 16h |
| 29 | 3.4.8 | 完成海外解决方案评估 | milestone | 0d | 2007-01-29 | 2007-01-29 | 28 | 0d |  |  |

Notes:
- 2: 典型职能包括薪酬管理、薪酬减税、扣款、福利(医疗、牙科、眼科、退休计划、就业援助计划、自助等)、工人报酬、索赔管理、失业，编制员工手册、安全手册、政府报告、就业记录，雇用和离职、绩效评估、报酬规划及许多其他方面的职能。了解存在哪些由内部或外部管理的人力资源职能非常重要。
- 3: 完全了解雇员当前管理和访问的所有人力资源职能的过程非常关键，以便评估是否存在对指定人力资源职能进行海外处理的价值。
- 4: 确定内部对每项人力资源职能提供的真实成本/收益/问题。这应该包括客观分析(财务状况、遵守立法等)和主观分析(雇员认知)，而且与海外处理指定的人力资源职能进行比较也是必要的。
- 5: 根据对内部管理人力资源职能的分析，为海外处理确定潜在的人力资源职能候选者。
- 7: 使人力资源之外的部门领导参与非常关键。
- 8: 为海外处理确定潜在的人力资源职能候选者，以便进行进一步的研究和分析。
- 11: 对在领导选择的特定领域内提供海外人力资源职能管理的公司进行研究。
- 12: 确定对所选人力资源职能进行海外处理的真实成本/收益/潜在风险。
- 15: 为海外处理确定潜在的人力资源职能候选者，以便进行进一步的研究和分析。

| ID | WBS | Task | Type | Duration | Start | Finish | Predecessors | Total slack | Resources | Work |
| --- | --- | --- | --- | --- | --- | --- | --- | --- | --- | --- |
| 30 | 3.5 | **对本国保留人力资源职能进行分析/比较** |  | 3d? | 2007-01-30 | 2007-02-01 |  | 0d |  | 32h |
| 31 | 3.5.1 | 对指定的海外人力资源职能进行最终成本/收益/风险分析 |  | 1d? | 2007-01-30 | 2007-01-30 | 29 | 0d | 人力资源主管 | 8h |
| 32 | 3.5.2 | 准备详细结果 |  | 1d? | 2007-01-31 | 2007-01-31 | 31 | 0d | 人力资源 | 8h |
| 33 | 3.5.3 | 审阅结果并做出判断 |  | 1d? | 2007-02-01 | 2007-02-01 | 32 | 0d | 人力资源主管; 行政工作组 | 16h |
| 34 | 3.5.4 | 已做出判断 | milestone | 0d | 2007-02-01 | 2007-02-01 | 33 | 0d | 人力资源主管; 行政工作组 |  |
| 35 | 3.6 | 完成深入分析 | milestone | 0d | 2007-02-01 | 2007-02-01 | 34 | 0d |  |  |
| 36 | 4 | 授予海外人力资源职能试生产合同 |  | 1d? | 2007-02-02 | 2007-02-02 | 35 | 0d | 采购 | 8h |
| 37 | 5 | 完成分析工作 | milestone | 0d | 2007-02-02 | 2007-02-02 | 36 | 0d |  |  |
| 38 | 6 | **试生产** |  | 71d? | 2007-02-05 | 2007-05-14 |  | 0d |  | 1672.2h |
| 39 | 6.1 | 选择将参与海外人力资源职能测试的组 |  | 1d? | 2007-02-05 | 2007-02-05 | 37 | 0d | 人力资源; 试生产供应商 | 16h |
| 40 | 6.2 | 设置过程和系统 |  | 1d? | 2007-02-06 | 2007-02-06 | 39 | 0d | 人力资源; 试生产供应商 | 16h |
| 41 | 6.3 | 建立评估服务级别协议符合性的标准 |  | 1d? | 2007-02-07 | 2007-02-07 | 40 | 0d | 人力资源; 试生产供应商 | 16h |
| 42 | 6.4 | 建立适用于试生产参与者的调查机制 |  | 1d? | 2007-02-08 | 2007-02-08 | 41 | 0d | 人力资源 | 8h |
| 43 | 6.5 | 培训试生产组 |  | 1d? | 2007-02-09 | 2007-02-09 | 42 | 0d | 人力资源; 试生产供应商 | 16h |
| 44 | 6.6 | 进行试生产 |  | 60d? | 2007-02-12 | 2007-05-04 | 43 | 0d | 人力资源; 试生产供应商 | 960h |
| 45 | 6.7 | **评估试生产结果** |  | 64d? | 2007-02-13 | 2007-05-11 |  | 0d |  | 632.2h |
| 46 | 6.7.1 | 确定 SLA 符合性 |  | 59d? | 2007-02-13 | 2007-05-04 | 44SS+1ed | 0d | 人力资源 | 472h |
| 47 | 6.7.2 | 调查试生产参与者 |  | 59d? | 2007-02-13 | 2007-05-04 | 44SS+1ed | 0d | 雇员 [16.9%]; 人力资源 [16.9%] | 80.2h |
| 48 | 6.7.3 | 评估 SLA 和调查的结果 |  | 5d? | 2007-05-07 | 2007-05-11 | 46, 47 | 0d | 人力资源主管; 行政工作组 | 80h |
| 49 | 6.8 | 发布结果 |  | 1d? | 2007-05-14 | 2007-05-14 | 48 | 0d | 人力资源主管 | 8h |
| 50 | 6.9 | 完成试生产 | milestone | 0d | 2007-05-14 | 2007-05-14 | 49 | 0d |  |  |
| 51 | 7 | 完成评估 | milestone | 0d | 2007-05-14 | 2007-05-14 | 50 | 0d |  |  |

Notes:
- 44: 建议将外包人力资源职能的试生产期限设置为 60 个工作日(约 3 个工作月)，以便有充足的时间来完成多个周期。该期限根据选择进行外包的人力资源职能的不同而不同，但至少必须包括 3 个完整的报告周期，以便稳定标准和完成足够多的活动，从而有足够的数据用于进行分析。
