# 贸易展览规划、执行和总结

Schedule from MS Project, 2007-01-01 to 2007-05-07.
贸易展览无所不在! 贸易展览是展示组织、扩充受众的一种方式。不管是第一次、还是已经在一年中举行了多次贸易展览，使用此模板均可帮助策划贸易展览。进行了多次贸易展览并形成规律后，使用此模板可缩减完成任务的时间。

## Calendars

- 标准: Mon-Fri 08:00-12:00, 13:00-17:00; Sat-Sun off.

## Resources

| Resource |
| --- |
| 后勤领导组 |
| 营销领导组 |
| 主办方 |
| 销售人员 |
| 贸易展览人员 |
| 创意人员 |
| 内容顾问 |
| 营销人员 |
| 营销研究人员 |
| 打印机 |
| Web 内容/创意人员 |
| 营销代表 |
| CMO |
| 供应商 |
| 内部公关人员 |
| 内部销售人员 |

## Schedule

| ID | WBS | Task | Type | Duration | Start | Finish | Predecessors | Total slack | Resources | Work |
| --- | --- | --- | --- | --- | --- | --- | --- | --- | --- | --- |
| 1 | 1 | **进行初步研究** |  | 27.5d? | 2007-01-01 08:00 | 2007-02-07 12:00 |  | 0d |  | 224h |
| 2 | 1.1 | 研究贸易展览机会 |  | 5d? | 2007-01-01 08:00 | 2007-01-05 17:00 |  | 0d | 营销代表 | 40h |
| 3 | 1.2 | 审阅业务部门(LOB)输入 |  | 5d? | 2007-01-08 08:00 | 2007-01-12 17:00 | 2 | 0d | 营销代表 | 40h |
| 4 | 1.3 | 审阅各个贸易展览信息 |  | 3d? | 2007-01-15 08:00 | 2007-01-17 17:00 | 3 | 0d | 营销代表 | 24h |
| 5 | 1.4 | 组织的贸易展览暴光率 |  | 1d? | 2007-01-18 08:00 | 2007-01-18 17:00 | 4 | 0d | 营销代表 | 8h |
| 6 | 1.5 | 组织的贸易展览价值 |  | 1d? | 2007-01-19 08:00 | 2007-01-19 17:00 | 5 | 0d | 营销代表 | 8h |
| 7 | 1.6 | 审阅贸易展览费用 |  | 1d? | 2007-01-22 08:00 | 2007-01-22 17:00 | 6 | 0d | 营销代表 | 8h |
| 8 | 1.7 | 制定贸易展览初步预算 |  | 4d? | 2007-01-23 08:00 | 2007-01-26 17:00 | 7 | 0d | 营销代表 | 32h |
| 9 | 1.8 | 评估组织的相关性 |  | 1d? | 2007-01-29 08:00 | 2007-01-29 17:00 | 8 | 0d | 营销代表 | 8h |
| 10 | 1.9 | 评估与公司策略目标的一致性 |  | 0.5d? | 2007-01-30 08:00 | 2007-01-30 12:00 | 9 | 0d | 营销领导组; 主办方 | 8h |
| 11 | 1.10 | 评估竞争优势 |  | 1d? | 2007-01-30 13:00 | 2007-01-31 12:00 | 10 | 0d | 营销领导组 | 8h |
| 12 | 1.11 | 确定公司贸易展览目标 |  | 1d? | 2007-01-31 13:00 | 2007-02-01 12:00 | 11 | 0d | 营销领导组 | 8h |
| 13 | 1.12 | 审阅公司与会者列表(过去和当前) |  | 1d? | 2007-02-01 13:00 | 2007-02-02 12:00 | 12 | 0d | 营销代表 | 8h |
| 14 | 1.13 | 审阅竞争对手参与情况 |  | 1d? | 2007-02-02 13:00 | 2007-02-05 12:00 | 13 | 0d | 营销代表 | 8h |
| 15 | 1.14 | 审阅观众分析数据 |  | 1d? | 2007-02-05 13:00 | 2007-02-06 12:00 | 14 | 0d | 营销代表 | 8h |
| 16 | 1.15 | 审阅组织的营销计划 |  | 1d? | 2007-02-06 13:00 | 2007-02-07 12:00 | 15 | 0d | 营销代表 | 8h |
| 17 | 1.16 | 完成初步研究 | milestone | 0d | 2007-02-07 12:00 | 2007-02-07 12:00 | 16 | 0d |  |  |
| 18 | 2 | **选择和审批** |  | 12.5d? | 2007-02-07 13:00 | 2007-02-23 17:00 |  | 0d |  | 108h |
| 19 | 2.1 | 审阅事件赞助机会和促销手段 |  | 1d? | 2007-02-07 13:00 | 2007-02-08 12:00 | 17 | 0d | 营销代表 | 8h |
| 20 | 2.2 | 选择适合组织的贸易展览 |  | 3d? | 2007-02-08 13:00 | 2007-02-13 12:00 | 19 | 0d | 营销领导组 | 24h |
| 21 | 2.3 | 制定贸易展览参与计划 |  | 3d? | 2007-02-13 13:00 | 2007-02-16 12:00 | 20 | 0d | 营销领导组 | 24h |
| 22 | 2.4 | 制定贸易展览预算 |  | 2d? | 2007-02-16 13:00 | 2007-02-20 12:00 | 21 | 0d | 营销领导组 | 16h |
| 23 | 2.5 | 确定衡量贸易展览成功的标准 |  | 1d? | 2007-02-20 13:00 | 2007-02-21 12:00 | 22 | 0d | 营销领导组 | 8h |
| 24 | 2.6 | 制定销售线索跟踪策略与手段 |  | 1d? | 2007-02-21 13:00 | 2007-02-22 12:00 | 23 | 0d | 营销代表 | 8h |
| 25 | 2.7 | 与主办方一起审阅贸易展览计划 |  | 1d? | 2007-02-22 13:00 | 2007-02-23 12:00 | 24 | 0d | 营销领导组; 主办方 | 16h |
| 26 | 2.8 | 通过主办方审批 |  | 0.5d? | 2007-02-23 13:00 | 2007-02-23 17:00 | 25 | 0d | 主办方 | 4h |
| 27 | 2.9 | 完成选择和审批 | milestone | 0d | 2007-02-23 17:00 | 2007-02-23 17:00 | 26 | 0d |  |  |

Notes:
- 4: 贸易展览估计的与会者数量、日期、位置/地点、行业划分、展位选项和食宿。

| ID | WBS | Task | Type | Duration | Start | Finish | Predecessors | Total slack | Free slack | Resources | Work |
| --- | --- | --- | --- | --- | --- | --- | --- | --- | --- | --- | --- |
| 28 | 3 | **注册** |  | 1d? | 2007-02-26 08:00 | 2007-02-26 17:00 |  | 7d |  |  | 72h |
| 29 | 3.1 | 确定贸易展览现场主要联系人 |  | 0.5d? | 2007-02-26 08:00 | 2007-02-26 12:00 | 27 | 7d | 0d | 营销代表 | 4h |
| 30 | 3.2 | 确定贸易展览规划联系人 |  | 0.5d? | 2007-02-26 08:00 | 2007-02-26 12:00 | 27 | 7.5d | 0.5d | 营销代表 | 4h |
| 31 | 3.3 | 确定贸易展览开单联系人 |  | 0.5d? | 2007-02-26 13:00 | 2007-02-26 17:00 | 29 | 7d | 0d | 营销代表 | 4h |
| 32 | 3.4 | 审阅展位资源数量限制 |  | 0.5d? | 2007-02-26 08:00 | 2007-02-26 12:00 | 27 | 7.5d | 0.5d | 营销代表 | 4h |
| 33 | 3.5 | 确定注册的资源数量 |  | 0.5d? | 2007-02-26 08:00 | 2007-02-26 12:00 | 27 | 7.5d | 0.5d | 营销代表 | 4h |
| 34 | 3.6 | 审阅注册过程的贸易展览材料 |  | 0.5d? | 2007-02-26 08:00 | 2007-02-26 12:00 | 27 | 7d | 0d | 营销代表 | 4h |
| 35 | 3.7 | 确定展位电源要求 |  | 0.5d? | 2007-02-26 13:00 | 2007-02-26 17:00 | 34 | 7d | 0d | 营销代表 | 4h |
| 36 | 3.8 | 确定 Internet 和电话要求 |  | 0.5d? | 2007-02-26 13:00 | 2007-02-26 17:00 | 34 | 7d | 0d | 营销代表 | 4h |
| 37 | 3.9 | 确定音频/视频要求 |  | 0.5d? | 2007-02-26 13:00 | 2007-02-26 17:00 | 34 | 7d | 0d | 营销代表 | 4h |
| 38 | 3.10 | 确定所有其他展位布置要求 |  | 0.5d? | 2007-02-26 13:00 | 2007-02-26 17:00 | 34 | 7d | 0d | 营销代表 | 4h |
| 39 | 3.11 | 审阅事件销售线索检索选项 |  | 0.5d? | 2007-02-26 13:00 | 2007-02-26 17:00 | 34 | 7d | 0d | 营销代表 | 4h |
| 40 | 3.12 | 确定付款选项 |  | 0.5d? | 2007-02-26 13:00 | 2007-02-26 17:00 | 34 | 7d | 0d | 营销代表 | 4h |
| 41 | 3.13 | 参展商服务申请表 |  | 0.5d? | 2007-02-26 13:00 | 2007-02-26 17:00 | 34 | 7d | 0d | 营销代表 | 4h |
| 42 | 3.14 | 完成注册和展位费提交 |  | 0.5d? | 2007-02-26 13:00 | 2007-02-26 17:00 | 34 | 7d | 0d | 营销代表 | 4h |
| 43 | 3.15 | 公司贸易展览说明 |  | 0.5d? | 2007-02-26 13:00 | 2007-02-26 17:00 | 34 | 7d | 0d | 营销人员 | 4h |
| 44 | 3.16 | 用于出版物/印刷材料、网站和事件标志的公司徽标 |  | 0.5d? | 2007-02-26 13:00 | 2007-02-26 17:00 | 34 | 7d | 0d | 营销人员 | 4h |
| 45 | 3.17 | 审阅展位布局规范和限制 |  | 0.5d? | 2007-02-26 13:00 | 2007-02-26 17:00 | 34 | 7d | 0d | 营销代表 | 4h |
| 46 | 3.18 | 确定对组织展位布置的改动 |  | 0.5d? | 2007-02-26 13:00 | 2007-02-26 17:00 | 34 | 7d | 0d | 营销代表 | 4h |
| 47 | 3.19 | 完成注册 | milestone | 0d | 2007-02-26 17:00 | 2007-02-26 17:00 | 29, 30, 31, 32, 33, 35, 36, 37, 38, 39, 40, 41, 42, 43, 44, 45, 46 | 7d | 0d |  |  |
| 48 | 4 | **贸易展览促销** |  | 13.5d? | 2007-02-27 08:00 | 2007-03-16 12:00 |  | 7d |  |  | 188h |
| 49 | 4.1 | 制定促销策略 |  | 3d? | 2007-02-27 08:00 | 2007-03-01 17:00 | 47 | 7d | 0d | 营销领导组 | 24h |
| 50 | 4.2 | 制定 PR 策略 |  | 2d? | 2007-03-02 08:00 | 2007-03-05 17:00 | 49 | 7d | 0d | 内部公关人员 | 16h |
| 51 | 4.3 | 重要分析人员的 PR 访谈和贸易展览新闻日程安排 |  | 5d? | 2007-03-06 08:00 | 2007-03-12 17:00 | 50 | 10.5d | 3.5d | 内部公关人员 | 40h |
| 52 | 4.4 | 确定促销时要使用的事件发布 |  | 2d? | 2007-03-06 08:00 | 2007-03-07 17:00 | 49, 50 | 7d | 0d | 营销人员 | 16h |
| 53 | 4.5 | 确定适合特定展示的新闻稿 |  | 2d? | 2007-03-06 08:00 | 2007-03-07 17:00 | 50 | 11.5d | 4.5d | 内部公关人员 | 16h |
| 54 | 4.6 | 在贸易展览上向观众促销 |  | 1.5d? | 2007-03-02 08:00 | 2007-03-05 12:00 | 49 | 9.5d | 2.5d | 营销代表; 内部公关人员 | 24h |
| 55 | 4.7 | 向周边的潜在客户、邮件列表和客户群发电子邮件 |  | 2d? | 2007-03-08 08:00 | 2007-03-09 17:00 | 52, 54 | 7d | 0d | 营销人员 | 16h |
| 56 | 4.8 | 请求与会者列表 |  | 0.5d? | 2007-03-12 08:00 | 2007-03-12 12:00 | 55 | 7d | 0d | 营销代表 | 4h |
| 57 | 4.9 | 确定演讲者/主办方机会和标准 |  | 1d? | 2007-03-12 13:00 | 2007-03-13 12:00 | 56 | 7d | 0d | 营销代表 | 8h |
| 58 | 4.10 | 拓宽贸易展览参与范围 |  | 1d? | 2007-03-13 13:00 | 2007-03-14 12:00 | 57 | 7d | 0d | 营销代表 | 8h |
| 59 | 4.11 | 执行促销 |  | 2d? | 2007-03-14 13:00 | 2007-03-16 12:00 | 49, 50, 52, 53, 58 | 7d | 0d | 营销代表 | 16h |
| 60 | 4.12 | 完成贸易展览促销 | milestone | 0d | 2007-03-16 12:00 | 2007-03-16 12:00 | 59, 51 | 7d |  |  |  |

Notes:
- 35: 标准电气服务租赁(110 伏 20 安)，208/230 伏 50 安单相，208/230 伏 50 安三相，便携式专用电气服务，连接到 208/230/480 配电板，衔接展示区域与配电板、固定带、设备拖板插座、人员调灯梯等。
- 36: 本地/长途模拟电话线，高速 Internet 线路(T1)，等等
- 37: LCD、屏幕、大屏幕监控器，等等
- 38: 椅子、展位地面地毯、垃圾桶，等等

| ID | WBS | Task | Type | Duration | Start | Finish | Predecessors | Total slack | Free slack | Resources | Work |
| --- | --- | --- | --- | --- | --- | --- | --- | --- | --- | --- | --- |
| 61 | 5 | **准备材料** |  | 14d? | 2007-02-26 08:00 | 2007-03-15 17:00 |  | 0d |  |  | 292h |
| 62 | 5.1 | 创建贸易展览材料 |  | 5d? | 2007-02-26 08:00 | 2007-03-02 17:00 | 27 | 0d |  | 创意人员 | 40h |
| 63 | 5.2 | 选择贸易展览材料 |  | 3d? | 2007-03-05 08:00 | 2007-03-07 17:00 | 62 | 0d |  | 营销领导组 | 24h |
| 64 | 5.3 | 确定特定贸易展览所需的数量 |  | 1d? | 2007-03-08 08:00 | 2007-03-08 17:00 | 63 | 0d |  | 营销代表 | 8h |
| 65 | 5.4 | 制作贸易展览材料 |  | 5d? | 2007-03-09 08:00 | 2007-03-15 17:00 | 64 | 0d |  | 供应商 | 40h |
| 66 | 5.5 | 确定贸易展览促销 |  | 5d? | 2007-02-26 08:00 | 2007-03-02 17:00 | 27 | 7d | 0d | 营销领导组 | 40h |
| 67 | 5.6 | 选择合适的演示 |  | 1d? | 2007-02-26 08:00 | 2007-02-26 17:00 | 27 | 8d | 0d | 营销代表 | 8h |
| 68 | 5.7 | 创建可执行的演示/Flash |  | 5d? | 2007-02-27 08:00 | 2007-03-05 17:00 | 67 | 8d |  | 营销人员 | 40h |
| 69 | 5.8 | 选择合适的产品/服务促销 |  | 2d? | 2007-03-05 08:00 | 2007-03-06 17:00 | 49, 66 | 7d |  | 营销代表 | 16h |
| 70 | 5.9 | 制定标志 |  | 5d? | 2007-02-26 08:00 | 2007-03-02 17:00 | 27 | 4.5d | 0d | 营销代表 | 40h |
| 71 | 5.10 | 确定赠品、竞赛和赠券 |  | 3d? | 2007-03-05 08:00 | 2007-03-07 17:00 | 70 | 4.5d | 0d | 营销代表 | 24h |
| 72 | 5.11 | 定购赠品和赠券 |  | 0.5d? | 2007-03-08 08:00 | 2007-03-08 12:00 | 71 | 4.5d | 0d | 营销人员 | 4h |
| 73 | 5.12 | 定购一般供应品 |  | 0.5d? | 2007-03-08 13:00 | 2007-03-08 17:00 | 72 | 4.5d | 0d | 营销人员 | 4h |
| 74 | 5.13 | 包装要在展会上派发的材料和供应品 |  | 0.5d? | 2007-03-09 08:00 | 2007-03-09 12:00 | 73 | 4.5d |  | 营销代表 | 4h |
| 75 | 5.14 | 完成材料准备 | milestone | 0d | 2007-03-15 17:00 | 2007-03-15 17:00 | 74, 65, 68, 69 | 0d |  |  |  |
| 76 | 6 | **贸易展览展示和设计** |  | 20.5d? | 2007-02-27 08:00 | 2007-03-27 12:00 |  | 0d |  |  | 96h |
| 77 | 6.1 | 审阅展位规范 |  | 0.5d? | 2007-03-16 08:00 | 2007-03-16 12:00 | 47, 75 | 0d |  | 营销代表 | 4h |
| 78 | 6.2 | 审阅供应商规则与条例 |  | 0.5d? | 2007-02-27 08:00 | 2007-02-27 12:00 | 47 | 13d |  | 营销代表 | 4h |
| 79 | 6.3 | 确定展示的展位大小 |  | 0.5d? | 2007-03-16 13:00 | 2007-03-16 17:00 | 77, 78 | 0d |  | 营销代表 | 4h |
| 80 | 6.4 | 根据展会的位置和类型确定合适的展示方式 |  | 0.5d? | 2007-02-27 08:00 | 2007-02-27 12:00 | 47 | 10d | 0d | 营销代表 | 4h |
| 81 | 6.5 | 确定展位类型(例如，展舱、桌面、区域和显示屏) |  | 0.5d? | 2007-02-27 13:00 | 2007-02-27 17:00 | 80 | 10d | 0d | 营销代表 | 4h |
| 82 | 6.6 | 设计展位外观和大体布局 |  | 3d? | 2007-02-28 08:00 | 2007-03-02 17:00 | 81 | 10d |  | 创意人员 | 24h |
| 83 | 6.7 | 建立空间规划模型 |  | 1d? | 2007-03-19 08:00 | 2007-03-19 17:00 | 82, 79 | 0d |  | 创意人员 | 8h |
| 84 | 6.8 | 定购或采购制作展位结构所需的服务 |  | 2d? | 2007-03-20 08:00 | 2007-03-21 17:00 | 83 | 0d |  | 营销代表 | 16h |
| 85 | 6.9 | 确定布置和拆卸过程 |  | 1d? | 2007-03-22 08:00 | 2007-03-22 17:00 | 84 | 0d |  | 营销代表 | 8h |
| 86 | 6.10 | 确定运输大小和规格 |  | 1d? | 2007-03-23 08:00 | 2007-03-23 17:00 | 85 | 0d |  | 营销代表 | 8h |
| 87 | 6.11 | 确定必需的设备支持 |  | 1d? | 2007-03-26 08:00 | 2007-03-26 17:00 | 86 | 0d |  | 营销代表 | 8h |
| 88 | 6.12 | 确定电源、电话和 Internet 要求 |  | 0.5d? | 2007-03-27 08:00 | 2007-03-27 12:00 | 87 | 0d |  | 营销代表 | 4h |
| 89 | 6.13 | 贸易展览展示和设计 | milestone | 0d | 2007-03-27 12:00 | 2007-03-27 12:00 | 88 | 0d |  |  |  |

Notes:
- 73: 展位材料: 笔、胶带、展位维护、剪刀，等等。

| ID | WBS | Task | Type | Duration | Start | Finish | Predecessors | Total slack | Free slack | Resources | Work |
| --- | --- | --- | --- | --- | --- | --- | --- | --- | --- | --- | --- |
| 90 | 7 | **运输** |  | 4d? | 2007-03-27 13:00 | 2007-04-02 12:00 |  | 0d |  |  | 32h |
| 91 | 7.1 | 运输说明 – 事件接收、存储、日期要求和运输 |  | 1d? | 2007-03-27 13:00 | 2007-03-28 12:00 | 60, 89 | 0d |  | 后勤领导组 | 8h |
| 92 | 7.2 | 运输贸易展览材料 |  | 1d? | 2007-03-28 13:00 | 2007-03-29 12:00 | 91 | 0d |  | 后勤领导组 | 8h |
| 93 | 7.3 | 运输贸易展览展位结构 |  | 1d? | 2007-03-29 13:00 | 2007-03-30 12:00 | 92 | 0d |  | 后勤领导组 | 8h |
| 94 | 7.4 | 运输必要的支持设备 |  | 1d? | 2007-03-30 13:00 | 2007-04-02 12:00 | 93 | 0d |  | 后勤领导组 | 8h |
| 95 | 7.5 | 完成运输 | milestone | 0d | 2007-04-02 12:00 | 2007-04-02 12:00 | 94 | 0d |  |  |  |
| 96 | 8 | **贸易展览人员分配和站位** |  | 4d? | 2007-02-27 08:00 | 2007-03-02 17:00 |  | 45.5d |  |  | 84h |
| 97 | 8.1 | 确定贸易展览人员 |  | 0.5d? | 2007-02-27 08:00 | 2007-02-27 12:00 | 47 | 47d | 0d | 营销领导组 | 4h |
| 98 | 8.2 | 分配贸易展览人员 |  | 0.5d? | 2007-02-27 13:00 | 2007-02-27 17:00 | 97 | 47d | 0d | 营销代表 | 4h |
| 99 | 8.3 | 贸易展览服装 |  | 0.5d? | 2007-02-28 08:00 | 2007-02-28 12:00 | 98 | 47d | 0d | 营销代表 | 4h |
| 100 | 8.4 | 列出尺寸和名称 |  | 0.5d? | 2007-02-28 13:00 | 2007-02-28 17:00 | 99 | 47d | 0d | 营销代表 | 4h |
| 101 | 8.5 | 订购贸易展览服装 |  | 0.5d? | 2007-03-01 08:00 | 2007-03-01 12:00 | 100 | 47d | 1.5d | 营销代表 | 4h |
| 102 | 8.6 | 贸易展览人员议程 |  | 0.5d? | 2007-02-27 08:00 | 2007-02-27 12:00 | 47 | 49d | 3.5d | 营销代表 | 4h |
| 103 | 8.7 | 贸易展览人员后勤工作 |  | 2d? | 2007-02-27 08:00 | 2007-02-28 17:00 | 47 | 47.5d | 2d | 营销代表 | 16h |
| 104 | 8.8 | 制定贸易展览人员使用的信息数据包 |  | 3d? | 2007-02-27 08:00 | 2007-03-01 17:00 | 47 | 45.5d | 0d | 营销代表 | 24h |
| 105 | 8.9 | 与贸易展览人员交流 |  | 1d? | 2007-03-02 08:00 | 2007-03-02 17:00 | 104, 98 | 45.5d | 0d | 营销代表 | 8h |
| 106 | 8.10 | 审阅销售线索检索系统 |  | 0.5d? | 2007-03-02 08:00 | 2007-03-02 12:00 | 104 | 46d | 0.5d | 营销代表 | 4h |
| 107 | 8.11 | 审阅用于收集名片的奖励物品/赠品 |  | 0.5d? | 2007-03-02 08:00 | 2007-03-02 12:00 | 104 | 46d | 0.5d | 营销代表 | 4h |
| 108 | 8.12 | 如何识别和验明销售线索 |  | 0.5d? | 2007-03-02 08:00 | 2007-03-02 12:00 | 104 | 46d | 0.5d | 营销代表 | 4h |
| 109 | 8.13 | 完成贸易展览人员分配和站位 | milestone | 0d | 2007-03-02 17:00 | 2007-03-02 17:00 | 101, 102, 103, 105, 106, 107, 108 | 45.5d |  |  |  |
| 110 | 9 | **布置、展示时间、拆卸** |  | 8.5d? | 2007-04-02 13:00 | 2007-04-12 17:00 |  | 0d |  |  | 124h |
| 111 | 9.1 | 审阅展位布置次数 |  | 0.5d? | 2007-04-02 13:00 | 2007-04-02 17:00 | 60, 95 | 0d |  | 贸易展览人员 | 4h |
| 112 | 9.2 | 加快运输 |  | 0.5d? | 2007-04-03 08:00 | 2007-04-03 12:00 | 111 | 0d |  | 贸易展览人员 | 4h |
| 113 | 9.3 | 销售线索检索设备 – 加速和功能性 |  | 0.5d? | 2007-04-03 08:00 | 2007-04-03 12:00 | 111 | 5d |  | 贸易展览人员 | 4h |
| 114 | 9.4 | 布置展示区域/展位 |  | 1d? | 2007-04-03 13:00 | 2007-04-04 12:00 | 112 | 4d |  | 贸易展览人员 | 8h |
| 115 | 9.5 | 展位人员检查注册/徽章 |  | 0.5d? | 2007-04-03 08:00 | 2007-04-03 12:00 | 111 | 0d |  | 贸易展览人员 | 4h |
| 116 | 9.6 | 进行展示 |  | 2d? | 2007-04-03 13:00 | 2007-04-05 12:00 | 112, 115 | 0d |  | 贸易展览人员 | 16h |
| 117 | 9.7 | 识别和验明销售线索 |  | 2d? | 2007-04-05 13:00 | 2007-04-09 12:00 | 116 | 0d |  | 贸易展览人员 | 16h |
| 118 | 9.8 | 制定到展位的路线 |  | 2d? | 2007-04-05 13:00 | 2007-04-09 12:00 | 116 | 0d |  | 贸易展览人员 | 16h |
| 119 | 9.9 | 管理事件材料 |  | 2d? | 2007-04-05 13:00 | 2007-04-09 12:00 | 116 | 0d |  | 贸易展览人员 | 16h |
| 120 | 9.10 | 管理事件演示 |  | 2d? | 2007-04-05 13:00 | 2007-04-09 12:00 | 116 | 0d |  | 贸易展览人员 | 16h |
| 121 | 9.11 | 完成贸易展览供应商时间 |  | 1d? | 2007-04-09 13:00 | 2007-04-10 12:00 | 116, 117, 118, 119, 120 | 0d |  |  |  |
| 122 | 9.12 | 包装事件材料、供应品和展位结构 |  | 0.5d? | 2007-04-10 13:00 | 2007-04-10 17:00 | 121, 113, 114 | 0d |  | 贸易展览人员 | 4h |
| 123 | 9.13 | 运回组织 |  | 2d? | 2007-04-11 08:00 | 2007-04-12 17:00 | 122 | 0d |  | 贸易展览人员 | 16h |
| 124 | 9.14 | 完成展示时间 | milestone | 0d | 2007-04-12 17:00 | 2007-04-12 17:00 | 123 | 0d |  |  |  |

Notes:
- 104: 目标、定位、注册、展位日程、材料、服装、事件位置

| ID | WBS | Task | Type | Duration | Start | Finish | Predecessors | Total slack | Free slack | Resources | Work |
| --- | --- | --- | --- | --- | --- | --- | --- | --- | --- | --- | --- |
| 125 | 10 | **安全性** |  | 1d? | 2007-02-27 08:00 | 2007-02-27 17:00 |  | 48.5d |  |  | 8h |
| 126 | 10.1 | 审阅事件安全性 |  | 0.5d? | 2007-02-27 08:00 | 2007-02-27 12:00 | 47 | 48.5d | 0d | 贸易展览人员 | 4h |
| 127 | 10.2 | 制定个人物品存储计划 |  | 0.5d? | 2007-02-27 13:00 | 2007-02-27 17:00 | 126 | 48.5d | 0d | 贸易展览人员 | 4h |
| 128 | 10.3 | 完成安全性审阅 | milestone | 0d | 2007-02-27 17:00 | 2007-02-27 17:00 | 127 | 48.5d |  |  |  |
| 129 | 11 | **总结** |  | 16.5d? | 2007-04-13 08:00 | 2007-05-07 12:00 |  | 0d |  |  | 340h |
| 130 | 11.1 | 听取事件人员汇报 |  | 1d? | 2007-04-13 08:00 | 2007-04-13 17:00 | 124 | 0d |  | 营销代表 | 8h |
| 131 | 11.2 | 审阅销售线索跟踪机制和数据 |  | 1d? | 2007-04-16 08:00 | 2007-04-16 17:00 | 130 | 0d |  | 营销代表 | 8h |
| 132 | 11.3 | 将信息扫描成合适的数据库格式 |  | 0.5d? | 2007-04-17 08:00 | 2007-04-17 12:00 | 131 | 0d |  | 营销人员 | 4h |
| 133 | 11.4 | 将贸易展览销售线索输入/上载到数据库 |  | 0.5d? | 2007-04-17 13:00 | 2007-04-17 17:00 | 132 | 0d |  | 营销人员 | 4h |
| 134 | 11.5 | 确定销售线索有效性 |  | 0.5d? | 2007-04-18 08:00 | 2007-04-18 12:00 | 133 | 0d |  | 营销代表 | 4h |
| 135 | 11.6 | 向展位参观者群发电子邮件 |  | 1d? | 2007-04-18 08:00 | 2007-04-18 17:00 | 133 | 0.5d | 0d | 营销人员 | 8h |
| 136 | 11.7 | 通知行业领先者、公司信息以及即将发生的事件日程等 |  | 1d? | 2007-04-18 08:00 | 2007-04-18 17:00 | 133 | 0.5d | 0d | 营销人员 | 8h |
| 137 | 11.8 | 将有效的销售线索传送给销售人员 |  | 0.5d? | 2007-04-18 08:00 | 2007-04-18 12:00 | 133 | 0d |  | 营销人员 | 4h |
| 138 | 11.9 | 销售人员选择并跟踪销售线索 |  | 2d? | 2007-04-18 13:00 | 2007-04-20 12:00 | 133, 134, 137 | 0d |  | 销售人员; 内部销售人员 | 32h |
| 139 | 11.10 | 遵循组织的销售线索跟踪过程和时间安排 |  | 1d? | 2007-04-19 08:00 | 2007-04-19 17:00 | 133, 135, 136 | 0.5d |  | 销售人员; 内部销售人员 | 16h |
| 140 | 11.11 | 审阅公司目标 |  | 0.5d? | 2007-04-13 08:00 | 2007-04-13 12:00 | 124 | 13d |  | 营销代表 | 4h |
| 141 | 11.12 | 审阅产生的收入 |  | 1d? | 2007-04-20 13:00 | 2007-04-23 12:00 | 138, 139 | 0d |  | 营销代表 | 8h |
| 142 | 11.13 | 收集贸易展览成本 |  | 2d? | 2007-04-13 08:00 | 2007-04-16 17:00 | 124 | 9.5d | 5.5d | 营销代表 | 16h |
| 143 | 11.14 | 审阅贸易展览估算和预算 |  | 1d? | 2007-04-23 13:00 | 2007-04-24 12:00 | 141 | 4d | 0d | 营销代表 | 8h |
| 144 | 11.15 | 确定贸易展览的回报价值 |  | 2d? | 2007-04-24 13:00 | 2007-04-26 12:00 | 130, 142, 143 | 4d | 0d | 营销领导组; 营销代表 | 32h |
| 145 | 11.16 | 交流贸易展览的活力 |  | 2d? | 2007-04-26 13:00 | 2007-04-30 12:00 | 144 | 4d |  | 营销代表 | 16h |
| 146 | 11.17 | 销售线索数量 |  | 1d? | 2007-04-18 08:00 | 2007-04-18 17:00 | 133 | 2.5d |  | 营销代表 | 8h |
| 147 | 11.18 | 主要联系人数量 |  | 1d? | 2007-04-20 13:00 | 2007-04-23 12:00 | 138 | 0d |  | 营销代表 | 8h |
| 148 | 11.19 | 根据贸易展览标准进行评估 |  | 1d? | 2007-04-23 13:00 | 2007-04-24 12:00 | 141, 146, 147 | 0d |  | 营销代表 | 8h |
| 149 | 11.20 | 完成最终财务分析 |  | 2d? | 2007-04-24 13:00 | 2007-04-26 12:00 | 148 | 0d |  | 营销代表 | 16h |
| 150 | 11.21 | 评估贸易展览响应 |  | 2d? | 2007-04-26 13:00 | 2007-04-30 12:00 | 130, 138, 149 | 0d |  | 营销代表 | 16h |
| 151 | 11.22 | 审阅销售结果 |  | 1d? | 2007-04-30 13:00 | 2007-05-01 12:00 | 150 | 0d |  | 营销代表 | 8h |
| 152 | 11.23 | 建议将来参与 |  | 1d? | 2007-05-01 13:00 | 2007-05-02 12:00 | 149, 150, 151 | 0d |  | 营销代表 | 8h |
| 153 | 11.24 | 确定所有帐单和合同 |  | 5d? | 2007-04-13 08:00 | 2007-04-19 17:00 | 124 | 8.5d |  | 营销代表 | 40h |
| 154 | 11.25 | 准备最终审阅 |  | 2d? | 2007-05-02 13:00 | 2007-05-04 12:00 | 153, 140, 152 | 0d |  | 营销领导组; 营销代表 | 32h |
| 155 | 11.26 | 与主办方一起审阅 |  | 1d? | 2007-05-04 13:00 | 2007-05-07 12:00 | 154, 145 | 0d |  | 营销领导组; 主办方 | 16h |
| 156 | 11.27 | 完成总结 | milestone | 0d | 2007-05-07 12:00 | 2007-05-07 12:00 | 155 | 0d |  |  |  |
| 157 | 12 | 完成贸易展览规划、执行和总结项目 | milestone | 0d | 2007-05-07 12:00 | 2007-05-07 12:00 | 156 | 0d |  |  |  |
