# 准备在过渡到 IFRS 的日期的期初资产负债表

Schedule from MS Project, 2007-01-01 to 2007-02-23.
从财务会计部门角度来看，在从以前的公认会计准则(GAAP)过渡到国际财务报表标准(IFRS)的时候，要求公司在过渡到 IFRS 之日准备期初资产负债表，此模板即能处理该重大活动。当前许多公司都正在进行此类过渡活动，因为欧盟要求所有在欧洲证券交易所上市的公司自 2005 年 1 月 1 日或之后起所提交的财务报表都必须遵循 IFRS 标准。IFRS 要求公司提供可供比较的信息，换而言之，采用日历年进行财务核算的实体过渡到 IFRS 的最终日期是 2004 年 1月 1 日。公司需要在过渡之日(2004 年 1月 1 日)准备一份遵循 IFRS 标准的期初资产负债表。

## Calendars

- 标准: Mon-Fri 08:00-12:00, 13:00-17:00; Sat-Sun off.

## Resources

| Resource |
| --- |
| 会计原则组 |
| CFO |
| 人力资源 |
| 总会计师 |
| 风险管理 |
| 会计 |
| 战略规划委员会 |
| CFO/总会计师 |
| 审计委员会 |

## Schedule

| ID | WBS | Task | Type | Duration | Start | Finish | Predecessors | Total slack | Resources | Work |
| --- | --- | --- | --- | --- | --- | --- | --- | --- | --- | --- |
| 1 | 1 | **进行初步规划** |  | 5d? | 2007-01-01 | 2007-01-05 |  | 0d |  | 60h |
| 2 | 1.1 | 准备项目计划 |  | 1d? | 2007-01-01 | 2007-01-01 |  | 0d | 会计原则组 | 8h |
| 3 | 1.2 | 组织工作组 |  | 1d? | 2007-01-02 | 2007-01-02 | 2 | 0d | CFO/总会计师 | 8h |
| 4 | 1.3 | 评估 IFRS 内部知识 |  | 1d? | 2007-01-03 | 2007-01-03 | 3 | 0d | 会计原则组; 人力资源 | 16h |
| 5 | 1.4 | 确定是否需要进行有关 IFRS 的其他培训 |  | 1d? | 2007-01-04 | 2007-01-04 | 4 | 0d | 会计原则组; 人力资源 | 16h |
| 6 | 1.5 | 启动会议 |  | 1d? | 2007-01-05 | 2007-01-05 | 5 | 0d | 会计原则组; 风险管理; 会计; CFO/总会计师 | 12h |
| 7 | 1.6 | 结束初步规划 | milestone | 0d | 2007-01-05 | 2007-01-05 | 6 | 0d |  |  |
| 8 | 2 | **确定与 IFRS 报告有关的当前“最佳做法”** |  | 2d? | 2007-01-08 | 2007-01-09 |  | 0d |  | 24h |
| 9 | 2.1 | 从外部审计员/其他来源获取 IFRS 报告手册/指南 |  | 1d? | 2007-01-08 | 2007-01-08 | 7 | 0d | 会计原则组 | 8h |
| 10 | 2.2 | 获取和审阅根据 IFRS 归档的竞争对手财务信息 |  | 1d? | 2007-01-08 | 2007-01-08 | 7 | 0d | 会计原则组 | 8h |
| 11 | 2.3 | 会见外部审计员以获取有关 IFRS 最佳做法的观点 |  | 1d? | 2007-01-09 | 2007-01-09 | 9, 10 | 0d | 会计原则组 | 8h |
| 12 | 2.4 | 完成审阅当前最佳做法 | milestone | 0d | 2007-01-09 | 2007-01-09 | 11 | 0d |  |  |
| 13 | 3 | **确定要使用的 IFRS 会计原则** |  | 7d? | 2007-01-10 | 2007-01-18 |  | 0d |  | 64h |
| 14 | 3.1 | 确定以前的 GAAP 中的哪些会计原则在 IFRS 下也可接受 |  | 1d? | 2007-01-10 | 2007-01-10 | 12 | 0d | 会计原则组 | 8h |
| 15 | 3.2 | 确定根据 IFRS，以前的 GAAP 会计原则在哪些地方不可接受 |  | 1d? | 2007-01-10 | 2007-01-10 | 11 | 0d | 会计原则组 | 8h |
| 16 | 3.3 | 确定哪些标准允许选择会计方法并选择方法 |  | 1d? | 2007-01-10 | 2007-01-10 | 11 | 0d | 会计原则组 | 8h |
| 17 | 3.4 | 确定所需追溯应用需要附加信息的区域 |  | 1d? | 2007-01-11 | 2007-01-11 | 14, 15, 16 | 0d | 会计原则组 | 8h |
| 18 | 3.5 | 向各个部门委派获取附加信息的责任 |  | 1d? | 2007-01-12 | 2007-01-12 | 17 | 0d | 会计原则组 | 8h |
| 19 | 3.6 | 确定会计需要有效判断/评估的会计区域/主题 |  | 1d? | 2007-01-15 | 2007-01-15 | 18 | 0d | CFO/总会计师 | 8h |
| 20 | 3.7 | 会见内部/外部审计员以解决这些区域最终的会计处理方法 |  | 1d? | 2007-01-16 | 2007-01-16 | 19 | 0d | CFO/总会计师 | 8h |
| 21 | 3.8 | 准备 IFRS 会计原则手册 |  | 1d? | 2007-01-17 | 2007-01-17 | 20 | 0d | 会计原则组 | 8h |
| 22 | 3.9 | 完成确定要使用的 IFRS 会计原则 |  | 1d? | 2007-01-18 | 2007-01-18 | 21 | 0d |  |  |
| 23 | 4 | **确定将利用 IFRS 1 中列出的哪些免税条款** |  | 10d? | 2007-01-19 | 2007-02-01 |  | 0d |  | 80h |
| 24 | 4.1 | 审阅过去的企业合并，并确定是否根据 IFRS 3 对 2004 年 1 月 1 日之前发生的合并进行再次声明 |  | 1d? | 2007-01-19 | 2007-01-19 | 22 | 0d | 会计原则组 | 8h |
| 25 | 4.2 | 确定实体是否将在 2004 年 1 月 1 日利用公平价值作为某些资产的认定成本 |  | 1d? | 2007-01-22 | 2007-01-22 | 24 | 0d | 会计原则组 | 8h |
| 26 | 4.3 | 确定对于根据 IAS 19 评估员工福利计划，雇用独立保险精算师的必要性 |  | 1d? | 2007-01-23 | 2007-01-23 | 25 | 0d | 会计原则组 | 8h |
| 27 | 4.4 | 确定在过渡期间对于未发现的保险精算获利/亏损的处理方法 |  | 1d? | 2007-01-24 | 2007-01-24 | 26 | 0d | 会计原则组 | 8h |
| 28 | 4.5 | 确定由使用外汇的子公司合并引起的累计转换差异的处理方法 |  | 1d? | 2007-01-25 | 2007-01-25 | 27 | 0d | 会计原则组 | 8h |
| 29 | 4.6 | 确定复合金融工具，并确定将责任与权益部分分离的必要性 |  | 1d? | 2007-01-26 | 2007-01-26 | 28 | 0d | 会计原则组 | 8h |
| 30 | 4.7 | 确定与子公司、联合公司和合资企业相关的资产/负债评估 |  | 1d? | 2007-01-29 | 2007-01-29 | 29 | 0d | 会计原则组 | 8h |
| 31 | 4.8 | 确定在过渡期日期所需的与金融工具相关的任命 |  | 1d? | 2007-01-30 | 2007-01-30 | 30 | 0d | 会计原则组 | 8h |
| 32 | 4.9 | 确定对于根据授予日期的股票支付交易的追溯会计，以及在过渡期间它们是否是既定的 |  | 1d? | 2007-01-31 | 2007-01-31 | 31 | 0d | 会计原则组 | 8h |
| 33 | 4.10 | 确定是否应用 IFRS 4 中与保险合同有关的过渡性条款 |  | 1d? | 2007-02-01 | 2007-02-01 | 32 | 0d | 会计原则组 | 8h |
| 34 | 4.11 | 完成确定将利用的 IFRS 1 免税条款 | milestone | 0d | 2007-02-01 | 2007-02-01 | 33 | 0d |  |  |

Notes:
- 13: 实体应在其期初 IFRS 资产负债表(即，2004 年 12 月 31 日)和第一次 IFRS 财务报表中陈述的所有期间使用相同的会计原则。对于第一次 IFRS 财务报表，这些会计原则应符合在报告日期(即，2005 年 12 月 31 日)有效的每个 IFRS，除非适用某些免税条款或例外条款。
- 16: 会计示例有: 库存；财产，工厂和设备；借款费用；无形资产；金融工具；投资财产。
- 17: 示例: 内部开发成本资本化
- 24: 实体不需要根据 IFRS 3 对 2004 年 1 月 1 日之前发生的企业合并进行再次声明。但是，如果他们选择这样做，则需要对所有后续企业合并适用 IFRS 3。
- 25: 示例: 财产，工厂和设备；无形资产；投资财产

| ID | WBS | Task | Type | Duration | Start | Finish | Predecessors | Total slack | Resources | Work |
| --- | --- | --- | --- | --- | --- | --- | --- | --- | --- | --- |
| 35 | 5 | **确定其他 IFRS 追溯应用的例外条款** |  | 7d? | 2007-02-02 | 2007-02-12 |  | 0d |  | 56h |
| 36 | 5.1 | 确定与 IAS 39 和 IFRS 4 相关的过渡日期 |  | 1d? | 2007-02-02 | 2007-02-02 | 34 | 0d | 会计原则组 | 8h |
| 37 | 5.2 | 应用对于过渡到 IAS 39 期间预期不承认金融资产/负债的要求 |  | 1d? | 2007-02-05 | 2007-02-05 | 36 | 0d | 会计原则组 | 8h |
| 38 | 5.3 | 确定在以前的 GAAP 下存在的套期保值关系 |  | 1d? | 2007-02-06 | 2007-02-06 | 37 | 0d | 风险管理 | 8h |
| 39 | 5.4 | 根据公平价值确定资产负债表中的所有衍生内容 |  | 1d? | 2007-02-07 | 2007-02-07 | 38 | 0d | 会计 | 8h |
| 40 | 5.5 | 如果根据 IFRS 应用套期保值会计，请准备相应的文档/效益测试 |  | 1d? | 2007-02-08 | 2007-02-08 | 39 | 0d | 风险管理 | 8h |
| 41 | 5.6 | 确定根据以前的 GAAP 作出的评估存在错误 |  | 1d? | 2007-02-09 | 2007-02-09 | 40 | 0d | 会计原则组 | 8h |
| 42 | 5.7 | 确定与待售资产和中止运作相关的相应会计 |  | 1d? | 2007-02-12 | 2007-02-12 | 41 | 0d | 会计原则组 | 8h |
| 43 | 5.8 | 完成确定例外条款 | milestone | 0d | 2007-02-12 | 2007-02-12 | 42 | 0d |  |  |
| 44 | 6 | **准备过渡调整，并编制期初 IFRS 资产负债表** |  | 8d? | 2007-02-13 | 2007-02-22 |  | 0d |  | 72h |
| 45 | 6.1 | 确认根据 IFRS 需要确认的所有资产和负债 |  | 1d? | 2007-02-13 | 2007-02-13 | 43 | 0d | 会计 | 8h |
| 46 | 6.2 | 如果 IFRS 不允许确认，则撤消确认资产或负债 |  | 1d? | 2007-02-14 | 2007-02-14 | 45 | 0d | 会计 | 8h |
| 47 | 6.3 | 根据 IFRS 对资产、负债或权益进行重新分类 |  | 1d? | 2007-02-15 | 2007-02-15 | 46 | 0d | 会计 | 8h |
| 48 | 6.4 | 在评估所有确认的资产和负债时应用 IFRS |  | 1d? | 2007-02-16 | 2007-02-16 | 47 | 0d | 会计 | 8h |
| 49 | 6.5 | 制作对认为必要的期初留成收益或其他帐户的过渡调整的相关日记帐分录 |  | 1d? | 2007-02-19 | 2007-02-19 | 48 | 0d | 会计 | 8h |
| 50 | 6.6 | 准备过渡期间根据以前的 GAAP 报告的权益与根据 IFRS 报告的权益之间的调节 |  | 1d? | 2007-02-20 | 2007-02-20 | 49 | 0d | 会计原则组; 会计 | 16h |
| 51 | 6.7 | 审阅期初 IFRS 资产负债表 |  | 1d? | 2007-02-21 | 2007-02-21 | 50 | 0d | CFO/总会计师 | 8h |
| 52 | 6.8 | 提交给外部审计员进行验证和核实 |  | 1d? | 2007-02-22 | 2007-02-22 | 51 | 0d | CFO/总会计师 | 8h |
| 53 | 6.9 | 完成过渡调整和期初 IFRS 资产负债表 | milestone | 0d | 2007-02-22 | 2007-02-22 | 52 | 0d |  |  |
| 54 | 7 | 完成过渡到 IFRS 的日期的期初资产负债表准备工作 |  | 1d? | 2007-02-23 | 2007-02-23 | 53 | 0d |  |  |
